# NGAO SD schedule v11

Schedule from MS Project, 2006-06-21 to 2008-04-04.
CARA

## Calendars

- Standard: Mon-Fri 08:00-12:00, 13:00-17:00; Sat-Sun off.

## Resources

| Resource | Group | Notes |
| --- | --- | --- |
| Flicker | WMKO | AO Modeller |
| Gavel | UCSC | EC |
| Neyman | WMKO | AO |
| Dekany | COO | EC |
| Bouchez | COO | AO Scientist |
| Max | UCSC | EC, Science |
| Wizinowich | WMKO | EC |
| Britton | COO | AO Modeller |
| Moore | COO | Instrum Sci |
| Velur | COO | AO Scientist |
| Chin | WMKO | EE |
| Johansson | WMKO | SE, EE |
| Meguro | WMKO | ME |
| Stomski | WMKO | SE |
| Clare | WMKO | AO Modeller |
| Adkins | WMKO | Prog mgmt |
| Bell | WMKO | ME |
| Sweeney | WMKO | MD |
| Kellner | WMKO | AO Postdoc |
| van Dam | WMKO | AO Scientist |
| Johnson | WMKO | SE |
| Bauman | UCSC | OE |
| Macintosh | UCSC | Science |
| Le Mignant | WMKO | Instrum Sci |
| Postdoc | UCSC | Science |
| Other |  |  |
| Cameron | COO | Grad student |
| Randolph | WMKO | MD |
| Summers | WMKO | SE |
| Woillez | WMKO | KI Scientist |
| Ammons | UCSC | Grad student |
| Dillon | UCSC | Laser EO |
| Cowley | UCSC | ME, Mgr |
| Kupke | UCSC | AO Postdoc |
| Kibrick | UCSC | SE |
| Lockwood | UCSC | ME |
| Reinig | UCSC | EE, ECE |
| Severson | UCSC | AO Scientist |
| Thomas | UCSC | AO Postdoc |
| Stover | UCSC | EE |
| Ireland | COO | Postdoc |
| Student |  | Science |

## Schedule

| ID | WBS | Task | Type | Duration | Start | Finish | Predecessors | Total slack | Free slack | Constraint | Resources | Work |
| --- | --- | --- | --- | --- | --- | --- | --- | --- | --- | --- | --- | --- |
| 1 | 1 | **SD Phase Management** |  | 468d? | 2006-06-21 | 2008-04-04 |  | 0d |  |  |  | 1745h |
| 2 | 1.1 | **Planning and Contracting** |  | 193d? | 2006-06-21 | 2007-03-16 |  | 275d |  |  |  | 220h |
| 3 | 1.1.1 | NGAO Proposal to SSC | milestone | 0d | 2006-06-21 | 2006-06-21 |  | 447d | 17d | start no earlier than 2006-06-21 |  |  |
| 4 | 1.1.2 | Management Structure Decision by Directors | milestone | 0d | 2006-07-14 | 2006-07-14 | 3 | 430d | 35d | start no earlier than 2006-07-14 |  |  |
| 5 | 1.1.3 | SD Phase System Engineering Management Plan |  | 21d? | 2006-09-01 | 2006-09-29 | 4 | 395d | 0d | finish no earlier than 2006-09-29 | Max [8.9%]; Gavel [8.9%]; Dekany [8.9%]; Wizinowich [20.8%] | 80h |
| 6 | 1.1.4 | SD Phase Contracts Generated |  | 23d? | 2006-09-27 | 2006-10-27 |  | 375d | 0d | start no earlier than 2006-09-27 | Adkins [16.7%]; Gavel [8.3%]; Dekany [8.3%] | 60h |
| 7 | 1.1.5 | Director Approval | milestone | 0d | 2006-10-09 | 2006-10-09 |  | 390d | 15d | start no earlier than 2006-10-09 |  |  |
| 8 | 1.1.6 | SD Partner Contracts Issued | milestone | 0d | 2006-10-27 | 2006-10-27 | 6, 7 | 375d |  | start no earlier than 2006-10-13 |  |  |
| 9 | 1.1.7 | Mid-year Replan |  | 10d | 2007-03-05 | 2007-03-16 |  | 275d |  | start no earlier than 2007-03-05 | Wizinowich [22.5%]; Dekany [10%]; Gavel [10%]; Max [7.5%] | 40h |
| 10 | 1.1.8 | FY08 Replan |  | 8d | 2006-09-05 | 2006-09-15 |  | 405.2d |  | start no earlier than 2006-09-05 | Wizinowich [28.1%]; Dekany [12.5%]; Gavel [12.5%]; Max [9.4%] | 40h |
| 11 | 1.2 | **Project Meetings** |  | 407d? | 2006-09-14 | 2008-04-04 |  | 0d |  |  |  | 780h |
| 12 | 1.2.1 | Executive Committee Telecons |  | 109.5d? | 2007-10-29 | 2008-03-28 |  | 5d |  | finish no earlier than 2008-03-28 | Wizinowich [8.6%]; Dekany [8.6%]; Gavel [8.6%]; Max [8.6%] | 300h |
| 13 | 1.2.2 | Science Advisory Committee Telecons |  | 390d? | 2006-10-02 | 2008-03-28 |  | 5d |  | start no earlier than 2006-10-02 | Max [1.4%] | 40h |
| 14 | 1.2.3 | **Team Meetings** |  | 407d | 2006-09-14 | 2008-04-04 |  | 0d |  |  |  | 440h |
| 15 | 1.2.3.1 | Team Meeting (mgmt, science & technical - Irvine) |  | 1d | 2006-09-14 | 2006-09-14 |  | 406d |  | start no earlier than 2006-09-14 | Wizinowich [125%]; Dekany [125%]; Gavel [125%]; Max [125%] | 40h |
| 16 | 1.2.3.2 | Team Meeting (CIT) |  | 1d | 2006-11-07 | 2006-11-07 |  | 368d |  | start no earlier than 2006-11-07 | Wizinowich [125%]; Dekany [125%]; Gavel [125%]; Max [125%] | 40h |
| 17 | 1.2.3.3 | Team Videocon |  | 0.5d | 2006-12-13 | 2006-12-13 |  | 342.5d |  | start no earlier than 2006-12-13 | Wizinowich [62.5%]; Dekany [62.5%]; Gavel [62.5%]; Max [62.5%] | 10h |
| 18 | 1.2.3.4 | Team Meeting (Keck) |  | 1d | 2007-01-22 | 2007-01-22 |  | 314d |  | start no earlier than 2007-01-22 | Wizinowich [125%]; Dekany [125%]; Gavel [125%]; Max [125%] | 40h |
| 19 | 1.2.3.5 | Team Videocon |  | 0.5d | 2007-03-07 | 2007-03-07 |  | 282.5d |  | start no earlier than 2007-03-07 | Wizinowich [62.5%]; Dekany [62.5%]; Gavel [62.5%]; Max [62.5%] | 10h |
| 20 | 1.2.3.6 | Team Meeting |  | 1d | 2007-04-18 | 2007-04-18 |  | 252d |  | start no earlier than 2007-04-18 | Wizinowich [31.2%]; Dekany [31.2%]; Gavel [31.2%]; Max [31.2%] | 10h |
| 21 | 1.2.3.7 | Team Videocon |  | 0.5d | 2007-05-30 | 2007-05-30 |  | 222d |  | finish no earlier than 2007-05-30 | Wizinowich [62.5%]; Dekany [62.5%]; Gavel [62.5%]; Max [62.5%] | 10h |
| 22 | 1.2.3.8 | Team Retreat (UCSC) |  | 5d | 2007-07-09 | 2007-07-13 |  | 190d |  | start no earlier than 2007-07-09 | Wizinowich [87.5%]; Dekany [87.5%]; Gavel [87.5%]; Max [87.5%] | 140h |
| 23 | 1.2.3.9 | Team Videocon |  | 0.5d | 2007-08-22 | 2007-08-22 |  | 162.5d |  | start no earlier than 2007-08-22 | Wizinowich [62.5%]; Dekany [62.5%]; Gavel [62.5%]; Max [62.5%] | 10h |
| 24 | 1.2.3.10 | Team Meeting (CIT) |  | 1d | 2007-09-11 | 2007-09-11 |  | 148d |  | start no earlier than 2007-09-11 | Wizinowich [125%]; Dekany [125%]; Gavel [125%]; Max [125%] | 40h |
| 25 | 1.2.3.11 | Team Videocon |  | 0.5d | 2007-11-05 | 2007-11-05 |  | 109.5d |  | start no earlier than 2007-11-05 | Wizinowich [62.5%]; Dekany [62.5%]; Gavel [62.5%]; Max [62.5%] | 10h |
| 26 | 1.2.3.12 | Team Meeting (Keck) |  | 3d | 2007-12-12 | 2007-12-14 |  | 80d |  | start no earlier than 2007-12-12 | Wizinowich [62.5%]; Dekany [62.5%]; Gavel [62.5%]; Max [62.5%] | 60h |
| 27 | 1.2.3.13 | Team Videocon |  | 0.5d | 2008-01-09 | 2008-01-09 |  | 62.5d |  | start no earlier than 2008-01-09 | Wizinowich [62.5%]; Dekany [62.5%]; Gavel [62.5%]; Max [62.5%] | 10h |
| 28 | 1.2.3.14 | Team Meeting (CA) |  | 1d | 2008-04-04 | 2008-04-04 | 39 | 0d |  | start no earlier than 2008-04-04 | Wizinowich [31.2%]; Dekany [31.2%]; Gavel [31.2%]; Max [31.2%] | 10h |

Notes:
- 1: PW
- 2: PW
- 5: PW
- 6: SA
- 8: SA
- 9: PW
- 10: PW
- 12: PW
- 13: CM

| ID | WBS | Task | Type | Duration | Start | Finish | Predecessors | Total slack | Free slack | Constraint | Resources | Work |
| --- | --- | --- | --- | --- | --- | --- | --- | --- | --- | --- | --- | --- |
| 29 | 1.3 | **Tracking and Reporting** |  | 394d? | 2006-09-29 | 2008-04-03 |  | 1d |  |  |  | 120h |
| 30 | 1.3.1 | Report Preparation/Presentation |  | 162.5d? | 2006-10-02 | 2007-05-16 |  | 232.5d |  | start no earlier than 2006-10-02 | Wizinowich [3.8%]; Dekany [35%]; Gavel [35%]; Max [35%] | 120h |
| 31 | 1.3.2 | Keck Science Meeting 06 (UCI) | milestone | 0d | 2006-09-29 | 2006-09-29 | 5 | 395d |  | finish no earlier than 2006-09-16 |  |  |
| 32 | 1.3.3 | SSC meeting (UCLA) | milestone | 0d | 2006-11-06 | 2006-11-06 |  | 370d |  | start no earlier than 2006-11-06 |  |  |
| 33 | 1.3.4 | SSC meeting (Keck) | milestone | 0d | 2007-01-24 | 2007-01-24 |  | 313d |  | start no earlier than 2007-01-24 |  |  |
| 34 | 1.3.5 | SSC meeting (CA) | milestone | 0d | 2007-04-03 | 2007-04-03 |  | 264d |  | start no earlier than 2007-04-03 |  |  |
| 35 | 1.3.6 | SSC meeting (Keck) | milestone | 0d | 2007-06-20 | 2007-06-20 |  | 208d |  | start no earlier than 2007-06-20 |  |  |
| 36 | 1.3.7 | Keck Science Meeting 07 | milestone | 0d | 2007-09-22 | 2007-09-22 |  | 140d |  | finish no earlier than 2007-09-22 |  |  |
| 37 | 1.3.8 | SSC meeting (CA) | milestone | 0d | 2007-11-06 | 2007-11-06 |  | 109d |  | start no earlier than 2007-11-06 |  |  |
| 38 | 1.3.9 | SSC meeting (Keck) | milestone | 0d | 2008-01-24 | 2008-01-24 |  | 52d |  | start no earlier than 2008-01-24 |  |  |
| 39 | 1.3.10 | SSC meeting (CA) | milestone | 0d | 2008-04-03 | 2008-04-03 |  | 0d |  | finish no earlier than 2008-04-03 |  |  |
| 40 | 1.4 | **Proposal & Fundraising Activities** |  | 326d? | 2006-10-02 | 2007-12-31 |  | 69d |  |  |  | 160h |
| 41 | 1.4.1 | Dates & deliverables identified by Directors | milestone | 0d | 2006-10-02 | 2006-10-02 |  | 134d | 65d | start no earlier than 2006-10-02 |  |  |
| 42 | 1.4.2 | Activities |  | 261d? | 2007-01-01 | 2007-12-31 | 41 | 69d |  | start no earlier than 2007-01-01 | Wizinowich [2.9%]; Max [3.8%]; Gavel [0.5%]; Dekany [0.5%] | 160h |
| 43 | 1.5 | **System Design Report & Review** |  | 82d? | 2007-11-15 | 2008-03-07 |  | 20d |  |  |  | 465h |
| 44 | 1.5.1 | System Design Report |  | 8d? | 2008-01-28 | 2008-02-06 | 324, 303, 134 | 20d | 0d | start no earlier than 2008-01-02 | Wizinowich [31.2%]; Gavel [7.8%]; Dekany [7.8%]; Adkins [7.8%]; Max [7.8%] | 40h |
| 45 | 1.5.2 | **System Design Review Activities** |  | 82d? | 2007-11-15 | 2008-03-07 |  | 20d |  |  |  | 425h |
| 46 | 1.5.2.1 | Reviewers Identified |  | 22d? | 2007-11-15 | 2007-12-14 |  | 80d |  | start no earlier than 2007-11-15 | Adkins [5.7%]; Wizinowich [1.1%]; Max [0.6%]; Gavel [0.6%]; Dekany [0.6%] | 15h |
| 47 | 1.5.2.2 | Review Package Distributed | milestone | 0d | 2008-02-06 | 2008-02-06 | 44 | 20d | 0d | start no earlier than 2008-01-14 |  |  |
| 48 | 1.5.2.3 | Reviewer Comments Received & Addressed |  | 5d? | 2008-02-27 | 2008-03-04 | 47FS+14d | 20d | 0d | finish no earlier than 2008-02-01 | Wizinowich [75%]; Dekany [60%]; Gavel [60%]; Max [65%]; Adkins [40%] | 120h |
| 49 | 1.5.2.4 | System Design Review Prep & Attendance |  | 16d? | 2008-02-07 | 2008-02-28 | 44 | 23d | 3d | start no earlier than 2007-01-16 | Wizinowich [48.8%]; Dekany [48.8%]; Gavel [48.8%]; Max [48.8%]; Adkins [6.2%] | 250h |
| 50 | 1.5.2.5 | System Design Review Meeting | milestone | 0d | 2008-03-04 | 2008-03-04 | 49, 48 | 20d | 0d | start no earlier than 2008-02-06 |  |  |
| 51 | 1.5.2.6 | Reviewer Report Received | milestone | 0d | 2008-03-04 | 2008-03-04 | 50 | 20d | 0d | start no earlier than 2008-02-15 |  |  |
| 52 | 1.5.2.7 | Response to Reviewer Report & Distribution |  | 3d? | 2008-03-05 | 2008-03-07 | 51 | 20d |  | start no earlier than 2008-02-18 | Wizinowich [41.7%]; Dekany [33.3%]; Gavel [33.3%]; Max [41.7%]; Adkins [16.7%] | 40h |

Notes:
- 29: PW
- 30: PW
- 43: SA
- 44: PW

| ID | WBS | Task | Duration | Start | Finish | Total slack | Constraint | Work |
| --- | --- | --- | --- | --- | --- | --- | --- | --- |
| 53 | 2 | **System Requirements** | 355d? | 2006-09-05 | 2008-01-15 | 59d |  | 3380h |
| 54 | 2.1 | **Science Requirements** | 344d? | 2006-09-05 | 2007-12-28 | 70d |  | 3090h |
| 55 | 2.1.1 | **Solar System** | 135d? | 2006-10-02 | 2007-04-06 | 260d |  | 650h |
| 56 | 2.1.1.1 | **Companions & Multiplicity of Small Solar System Bodies** | 75d? | 2006-10-02 | 2007-01-12 | 320d |  | 250h |
| 57 | 2.1.1.1.1 | Point Source Companion Sensitivity Requirements | 45d? | 2006-10-02 | 2006-12-01 | 350d | finish no earlier than 2006-12-01 | 100h |
| 58 | 2.1.1.1.2 | Spectral Sensitivity & Spectral Resolution Requirements | 45d? | 2006-10-02 | 2006-12-01 | 350d | finish no earlier than 2006-12-01 | 100h |
| 59 | 2.1.1.1.3 | Observing Scenarios | 30d? | 2006-12-04 | 2007-01-12 | 320d | finish no earlier than 2007-01-12 | 25h |
| 60 | 2.1.1.1.4 | Science Instrument Requirements | 30d? | 2006-12-04 | 2007-01-12 | 320d | start no earlier than 2006-12-04 | 25h |
| 61 | 2.1.1.2 | **Moons of the Giant Planets** | 70d? | 2006-12-04 | 2007-03-09 | 280d |  | 150h |
| 62 | 2.1.1.2.1 | Performance Requirements | 40d? | 2006-12-04 | 2007-01-26 | 310d | start no earlier than 2006-12-04 | 100h |
| 63 | 2.1.1.2.2 | Observing Scenarios | 30d? | 2007-01-29 | 2007-03-09 | 280d | finish no earlier than 2007-03-09 | 25h |
| 64 | 2.1.1.2.3 | Science Instrument Requirements | 30d? | 2007-01-29 | 2007-03-09 | 280d | start no earlier than 2007-01-29 | 25h |
| 65 | 2.1.1.3 | **Shape & Size of Asteroids** | 50d? | 2007-01-29 | 2007-04-06 | 260d |  | 250h |
| 66 | 2.1.1.3.1 | Spatial Resolution Requirements | 25d? | 2007-01-29 | 2007-03-02 | 285d | start no earlier than 2007-01-29 | 100h |
| 67 | 2.1.1.3.2 | Spectral Sensitivity & Spectral Resolution Requirements | 25d? | 2007-01-29 | 2007-03-02 | 285d | start no earlier than 2007-01-29 | 100h |
| 68 | 2.1.1.3.3 | Observing Scenarios | 25d? | 2007-03-05 | 2007-04-06 | 260d | finish no earlier than 2007-04-06 | 25h |
| 69 | 2.1.1.3.4 | Science Instrument Requirements | 25d? | 2007-03-05 | 2007-04-06 | 260d | start no earlier than 2007-03-05 | 25h |
| 70 | 2.1.2 | **Galactic** | 145d? | 2006-09-18 | 2007-04-06 | 260d |  | 1200h |
| 71 | 2.1.2.1 | **Galactic Center Proper Motions: Astrometry** | 85d? | 2006-09-18 | 2007-01-12 | 320d |  | 200h |
| 72 | 2.1.2.1.1 | Astrometry requirements | 50d? | 2006-09-18 | 2006-11-24 | 355d | finish no earlier than 2006-11-24 | 150h |
| 73 | 2.1.2.1.2 | Observing Scenarios | 35d? | 2006-11-27 | 2007-01-12 | 320d | finish no earlier than 2007-01-12 | 25h |
| 74 | 2.1.2.1.3 | Science Instrument Requirements | 35d? | 2006-11-27 | 2007-01-12 | 320d | start no earlier than 2006-11-27 | 25h |
| 75 | 2.1.2.2 | **Galactic Center Radial Velocities & Stellar Populations: Integral Field Spectroscopy** | 75d? | 2006-11-27 | 2007-03-09 | 280d |  | 200h |
| 76 | 2.1.2.2.1 | Performance Requirements | 45d? | 2006-11-27 | 2007-01-26 | 310d | finish no earlier than 2007-01-26 | 150h |
| 77 | 2.1.2.2.2 | Observing Scenarios | 30d? | 2007-01-29 | 2007-03-09 | 280d | start no earlier than 2007-01-29 | 25h |
| 78 | 2.1.2.2.3 | Science Instrument Requirements | 30d? | 2007-01-29 | 2007-03-09 | 280d | start no earlier than 2007-01-29 | 25h |

Notes:
- 54: CM
- 55: FM
- 70: ML
- 71: AG
- 75: AG

| ID | WBS | Task | Duration | Start | Finish | Total slack | Constraint | Work |
| --- | --- | --- | --- | --- | --- | --- | --- | --- |
| 79 | 2.1.2.3 | **Galactic Center Nature of Sgr A*: 3-5 um Color & 2 um Polarimetry Variability** | 50d? | 2007-01-29 | 2007-04-06 | 260d |  | 200h |
| 80 | 2.1.2.3.1 | Performance Requirements | 25d? | 2007-01-29 | 2007-03-02 | 285d | finish no earlier than 2007-03-02 | 150h |
| 81 | 2.1.2.3.2 | Observing Scenarios | 25d? | 2007-03-05 | 2007-04-06 | 260d | start no earlier than 2007-03-05 | 25h |
| 82 | 2.1.2.3.3 | Science Instrument Requirements | 25d? | 2007-03-05 | 2007-04-06 | 260d | finish no earlier than 2007-04-06 | 25h |
| 83 | 2.1.2.4 | **Planets around Low Mass Stars & Brown Dwarfs: Companion Sensitivity** | 85d? | 2006-09-18 | 2007-01-12 | 320d |  | 200h |
| 84 | 2.1.2.4.1 | Companion Sensitivity Performance Requirements | 50d? | 2006-09-18 | 2006-11-24 | 355d | finish no earlier than 2006-11-24 | 150h |
| 85 | 2.1.2.4.2 | Observing Scenarios | 35d? | 2006-11-27 | 2007-01-12 | 320d | start no earlier than 2006-11-27 | 25h |
| 86 | 2.1.2.4.3 | Science Instrument Requirements | 35d? | 2006-11-27 | 2007-01-12 | 320d | start no earlier than 2006-11-27 | 25h |
| 87 | 2.1.2.5 | **Debris Disks, Protostellar Envelopes & Outflows: Contrast** | 50d? | 2007-01-29 | 2007-04-06 | 260d |  | 200h |
| 88 | 2.1.2.5.1 | Contrast Performance Requirements | 25d? | 2007-01-29 | 2007-03-02 | 285d | finish no earlier than 2007-03-02 | 150h |
| 89 | 2.1.2.5.2 | Observing Scenarios | 25d? | 2007-03-05 | 2007-04-06 | 260d | start no earlier than 2007-03-05 | 25h |
| 90 | 2.1.2.5.3 | Science Instrument Requirements | 25d? | 2007-03-05 | 2007-04-06 | 260d | start no earlier than 2007-03-05 | 25h |
| 91 | 2.1.2.6 | **Debris Disks, Protostellar Envelopes & Outflows: Polarimetry** | 75d? | 2006-11-27 | 2007-03-09 | 280d |  | 200h |
| 92 | 2.1.2.6.1 | Polarimetry Performance Requirements | 45d? | 2006-11-27 | 2007-01-26 | 310d | finish no earlier than 2007-01-26 | 150h |
| 93 | 2.1.2.6.2 | Observing Scenarios | 30d? | 2007-01-29 | 2007-03-09 | 280d | start no earlier than 2007-01-29 | 25h |
| 94 | 2.1.2.6.3 | Science Instrument Requirements | 30d? | 2007-01-29 | 2007-03-09 | 280d | start no earlier than 2007-01-29 | 25h |
| 95 | 2.1.3 | **Extragalactic** | 160d? | 2006-09-18 | 2007-04-27 | 245d |  | 1000h |
| 96 | 2.1.3.1 | **Resolved Stellar Populations in Crowded Fields** | 100d? | 2006-09-18 | 2007-02-02 | 305d |  | 300h |
| 97 | 2.1.3.1.1 | Performance Requirements | 60d? | 2006-09-18 | 2006-12-08 | 345d | finish no earlier than 2006-12-08 | 250h |
| 98 | 2.1.3.1.2 | Observing Scenarios | 40d? | 2006-12-11 | 2007-02-02 | 305d | finish no earlier than 2007-02-02 | 25h |
| 99 | 2.1.3.1.3 | Science Instrument Requirements | 40d? | 2006-12-11 | 2007-02-02 | 305d | start no earlier than 2006-12-11 | 25h |
| 100 | 2.1.3.2 | **High Redshift Galaxies** | 100d? | 2006-09-18 | 2007-02-02 | 305d |  | 300h |
| 101 | 2.1.3.2.1 | Encircled Energy (& d-IFU) Performance Requirements | 60d? | 2006-09-18 | 2006-12-08 | 345d | finish no earlier than 2006-12-08 | 200h |
| 102 | 2.1.3.2.2 | Observing Scenarios | 40d? | 2006-12-11 | 2007-02-02 | 305d | start no earlier than 2006-12-11 | 50h |
| 103 | 2.1.3.2.3 | Science Instrument Requirements | 40d? | 2006-12-11 | 2007-02-02 | 305d | start no earlier than 2006-12-11 | 50h |

Notes:
- 79: AG
- 83: ML
- 87: LH
- 95: CM

| ID | WBS | Task | Duration | Start | Finish | Total slack | Free slack | Constraint | Resources | Work |
| --- | --- | --- | --- | --- | --- | --- | --- | --- | --- | --- |
| 104 | 2.1.3.3 | **Nearby Galaxies** | 100d? | 2006-12-11 | 2007-04-27 | 245d |  |  |  | 200h |
| 105 | 2.1.3.3.1 | Encircled Energy & PSF Performance Requirements | 60d? | 2006-12-11 | 2007-03-02 | 285d |  | finish no earlier than 2007-03-02 |  | 150h |
| 106 | 2.1.3.3.2 | Observing Scenarios | 40d? | 2007-03-05 | 2007-04-27 | 245d |  | finish no earlier than 2007-04-27 |  | 25h |
| 107 | 2.1.3.3.3 | Science Instrument Requirements | 40d? | 2007-03-05 | 2007-04-27 | 245d |  | start no earlier than 2007-03-05 |  | 25h |
| 108 | 2.1.3.4 | **Gravitational Lensing** | 100d? | 2006-12-11 | 2007-04-27 | 245d |  |  |  | 200h |
| 109 | 2.1.3.4.1 | Encircled Energy & PSF Performance Requirements | 60d? | 2006-12-11 | 2007-03-02 | 285d |  | start no earlier than 2006-12-11 |  | 150h |
| 110 | 2.1.3.4.2 | Observing Scenarios | 40d? | 2007-03-05 | 2007-04-27 | 245d |  | start no earlier than 2007-03-05 |  | 25h |
| 111 | 2.1.3.4.3 | Science Instrument Requirements | 40d? | 2007-03-05 | 2007-04-27 | 245d |  | start no earlier than 2007-03-05 |  | 25h |
| 112 | 2.1.4 | **Science Requirements Summary** | 344d? | 2006-09-05 | 2007-12-28 | 70d |  |  |  | 240h |
| 113 | 2.1.4.1 | Revision 1 | 29d? | 2006-09-05 | 2006-10-13 | 385d | 10d | finish no earlier than 2006-10-13 |  | 40h |
| 114 | 2.1.4.2 | Revision 2 | 21d? | 2007-02-02 | 2007-03-02 | 285d | 4d | finish no earlier than 2007-03-02 |  | 120h |
| 115 | 2.1.4.3 | Revision 3 | 15d? | 2007-06-04 | 2007-06-22 | 205d | 4d | finish no earlier than 2007-06-22 |  | 40h |
| 116 | 2.1.4.4 | Final SD Version | 20d? | 2007-12-03 | 2007-12-28 | 62d | 11d | finish no earlier than 2007-12-28 |  | 40h |
| 117 | 2.2 | **Observatory Requirements** | 325d? | 2006-10-02 | 2007-12-28 | 70d |  |  |  | 160h |
| 118 | 2.2.1 | Development Requirements | 20d? | 2006-10-02 | 2006-10-27 | 375d | 0d | finish no earlier than 2006-10-27 | Neyman [5%] | 8h |
| 119 | 2.2.2 | Observatory Interface Requirements | 20d? | 2006-10-02 | 2006-10-27 | 375d | 0d | finish no earlier than 2006-10-27 | Neyman [10%] | 16h |
| 120 | 2.2.3 | Science Operations Requirements | 20d? | 2006-10-02 | 2006-10-27 | 375d | 0d | finish no earlier than 2006-10-27 | Le Mignant [10%] | 16h |
| 121 | 2.2.4 | Revision 2 | 15d? | 2007-02-12 | 2007-03-02 | 285d | 4d | start no earlier than 2007-02-12 | Neyman [20%]; Other [41.7%]; Le Mignant [13.3%] | 90h |
| 122 | 2.2.5 | Revision 3 | 30d? | 2007-05-14 | 2007-06-22 | 205d | 4d | finish no earlier than 2007-06-22 | Neyman [8.3%] | 20h |
| 123 | 2.2.6 | Revision 4 | 20d? | 2007-12-03 | 2007-12-28 | 62d | 11d | finish no earlier than 2007-12-28 | Neyman [6.2%] | 10h |
| 124 | 2.3 | **System Requirements Document** | 331d? | 2006-10-09 | 2008-01-15 | 59d |  |  |  | 130h |
| 125 | 2.3.1 | **Technical Requirements Flow Down** | 331d? | 2006-10-09 | 2008-01-14 | 59d |  |  |  | 130h |
| 126 | 2.3.1.1 | Revision 1 | 10d? | 2006-10-09 | 2006-10-20 | 380d | 5d | finish no earlier than 2006-10-20 | Neyman [12.5%] | 10h |
| 127 | 2.3.1.2 | Revision 2 | 89d? | 2006-11-01 | 2007-03-05 | 284d | 3d | start no earlier than 2006-11-01 | Neyman [4.5%]; Wizinowich [2.2%]; Adkins [1.1%]; Flicker [3.4%] | 80h |
| 128 | 2.3.1.3 | Revision 3 | 10d? | 2007-06-15 | 2007-06-28 | 201d | 0d | finish no earlier than 2007-06-28 | Neyman [25%] | 20h |
| 129 | 2.3.1.4 | Revision 4 | 9d? | 2008-01-02 | 2008-01-14 | 51d | 0d | finish no earlier than 2008-01-14 | Neyman [27.8%] | 20h |

Notes:
- 112: CM
- 117: CN
- 118: CN
- 119: CN
- 120: DLM
- 121: CN
- 122: CN
- 123: CN
- 125: CN

| ID | WBS | Task | Type | Duration | Start | Finish | Predecessors | Total slack | Free slack | Constraint | Resources | Work |
| --- | --- | --- | --- | --- | --- | --- | --- | --- | --- | --- | --- | --- |
| 130 | 2.3.2 | **System Requirements Document** |  | 316d | 2006-10-27 | 2008-01-15 |  | 59d |  |  |  |  |
| 131 | 2.3.2.1 | Revision 1 Release | milestone | 0d | 2006-10-27 | 2006-10-27 | 113, 126, 118, 119, 120 | 375d |  | start no earlier than 2006-10-27 |  |  |
| 132 | 2.3.2.2 | Revision 2 Release | milestone | 0d | 2007-03-09 | 2007-03-09 | 114, 127, 121 | 281d |  | start no earlier than 2007-03-09 |  |  |
| 133 | 2.3.2.3 | Revision 3 Release | milestone | 0d | 2007-06-29 | 2007-06-29 | 115, 128, 122 | 201d |  | start no earlier than 2007-06-29 |  |  |
| 134 | 2.3.2.4 | Final SD Version Release | milestone | 0d | 2008-01-15 | 2008-01-15 | 116, 129, 123 | 51d | 15d | start no earlier than 2008-01-15 |  |  |
| 135 | 3 | **System Design** |  | 380d? | 2006-08-14 | 2008-01-25 |  | 50d |  |  |  | 10834h |
| 136 | 3.1 | **Systems Engineering** |  | 350d? | 2006-08-14 | 2007-12-14 |  | 80d |  |  |  | 5784h |
| 137 | 3.1.1 | **Performance Budgets** |  | 292d? | 2006-08-14 | 2007-09-25 |  | 138d |  |  |  | 2574h |
| 138 | 3.1.1.1 | **Model Assumptions** |  | 230d? | 2006-08-14 | 2007-06-29 |  | 200d |  |  |  | 260h |
| 139 | 3.1.1.1.1 | **TMT site monitoring data mining** |  | 230d? | 2006-08-14 | 2007-06-29 |  | 200d |  |  |  | 80h |
| 140 | 3.1.1.1.1.1 | Tools in place & 1st release |  | 24d? | 2006-08-14 | 2006-09-14 |  | 201d | 1d | finish no earlier than 2006-09-14 | Flicker [20.8%] | 40h |
| 141 | 3.1.1.1.1.2 | Release updated data (every two months) |  | 205d? | 2006-09-18 | 2007-06-29 | 140 | 200d |  | finish no earlier than 2007-06-29 | Flicker [2.4%] | 40h |
| 142 | 3.1.1.1.2 | Telescope dynamic performance data |  | 44d? | 2006-10-02 | 2006-11-30 |  | 316d | 1d | start no earlier than 2006-10-02 | Neyman [17%]; Flicker [17%] | 120h |
| 143 | 3.1.1.1.3 | Telescope static wavefront errors |  | 44d? | 2006-10-02 | 2006-11-30 |  | 316d | 1d | finish no earlier than 2006-11-30 | Neyman [5.7%] | 20h |
| 144 | 3.1.1.1.4 | Sodium return vs laser format |  | 22d? | 2006-11-01 | 2006-11-30 |  | 329d | 21d | start no earlier than 2006-11-01 | Gavel [11.4%]; Neyman [11.4%] | 40h |
| 145 | 3.1.1.2 | **Model/Tool Validation** |  | 90d? | 2006-08-14 | 2006-12-15 |  | 318d | 10d |  |  | 334h |
| 146 | 3.1.1.2.1 | Agreement between Tomography Codes |  | 35d? | 2006-08-14 | 2006-09-29 |  | 373d |  | start no earlier than 2006-08-14 | Flicker [5.4%]; Gavel [3.6%]; Neyman [5.4%] | 40h |
| 147 | 3.1.1.2.2 | Agreement between Sky Coverage Codes |  | 23d? | 2006-09-18 | 2006-10-18 |  | 360d |  | start no earlier than 2006-09-18 | Dekany [6.5%]; Gavel [6.5%]; Clare [8.7%] | 40h |
| 148 | 3.1.1.2.3 | Anchor to Keck II LGS AO PSFs |  | 21d? | 2006-10-02 | 2006-10-30 |  | 352d |  | finish no earlier than 2006-10-30 | Neyman [23.8%] | 40h |
| 149 | 3.1.1.2.4 | Anchor to On-sky MGSU Experiments |  | 3.67d? | 2006-11-10 | 2006-11-15 |  | 340d |  | finish no earlier than 2006-11-15 | Flicker [34.1%] | 10h |
| 150 | 3.1.1.2.5 | Anchor to LAO Lab Experiments |  | 30d? | 2006-11-06 | 2006-12-15 |  | 318d |  | start no earlier than 2006-11-06 | Gavel [1.7%]; Flicker [16.7%]; Kupke [33.3%]; Ammons [33.3%] | 204h |
| 151 | 3.1.1.3 | Throughput |  | 65d? | 2006-10-02 | 2006-12-29 |  | 330d |  | finish no earlier than 2006-12-29 | Bouchez [7.7%] | 40h |
| 152 | 3.1.1.4 | **Background** |  | 65d? | 2006-10-02 | 2006-12-29 |  | 330d |  |  |  | 90h |
| 153 | 3.1.1.4.1 | Document Proposal Analysis |  | 9d? | 2006-10-02 | 2006-10-12 |  | 386d |  | start no earlier than 2006-10-02 | Bouchez [13.9%] | 10h |
| 154 | 3.1.1.4.2 | Develop Background Performance Budget |  | 56d? | 2006-10-02 | 2006-12-29 |  | 330d |  | start no earlier than 2006-10-02 | Bouchez [17.9%] | 80h |

Notes:
- 137: RD
- 138: CN
- 139: RF
- 140: RF
- 141: RF
- 142: CN
- 143: CN
- 144: DG
- 145: CN
- 146: DG
- 147: RD
- 148: CN
- 149: RF
- 150: DG
- 151: AB
- 152: AB
- 153: AB
- 154: AB

| ID | WBS | Task | Duration | Start | Finish | Predecessors | Total slack | Free slack | Constraint | Resources | Work |
| --- | --- | --- | --- | --- | --- | --- | --- | --- | --- | --- | --- |
| 155 | 3.1.1.5 | **Wavefront Error vs Sky Coverage** | 87d? | 2006-10-02 | 2007-01-30 |  | 308d |  |  |  | 110h |
| 156 | 3.1.1.5.1 | Document & release version 1 | 24d? | 2006-10-02 | 2006-11-02 |  | 371d |  | start no earlier than 2006-10-02 | Dekany [20.8%] | 40h |
| 157 | 3.1.1.5.2 | Develop version 2, document & release | 22d? | 2007-01-01 | 2007-01-30 | 140, 144, 145, 184 | 308d |  | finish no earlier than 2007-01-30 | Dekany [22.7%]; Flicker [17%] | 70h |
| 158 | 3.1.1.6 | Encircled Energy vs Sky Coverage | 50d? | 2006-10-23 | 2006-12-29 |  | 330d |  | start no earlier than 2006-10-23 | Dekany [17.5%]; Gavel [17.5%] | 140h |
| 159 | 3.1.1.7 | Photometric Accuracy | 75d? | 2006-10-16 | 2007-01-26 |  | 310d |  | start no earlier than 2006-10-16 | Britton [20%]; Neyman [10%]; Flicker [10%] | 240h |
| 160 | 3.1.1.8 | Astrometric Accuracy | 55d? | 2006-11-13 | 2007-01-26 |  | 310d |  | start no earlier than 2006-11-13 | Neyman [18.2%]; Britton [9.1%]; Flicker [9.1%]; Cameron [18.2%] | 240h |
| 161 | 3.1.1.9 | Polarimetric Accuracy | 25d? | 2007-02-05 | 2007-03-09 |  | 280d |  | start no earlier than 2007-02-05 | Ireland [20%] | 40h |
| 162 | 3.1.1.10 | Companion Sensitivity | 55d? | 2006-11-13 | 2007-01-26 |  | 310d |  | start no earlier than 2006-11-13 | Macintosh [18.2%]; Neyman [18.2%]; Other [18.2%]; Flicker [18.2%] | 320h |
| 163 | 3.1.1.11 | Observing Efficiency | 30d? | 2007-02-05 | 2007-03-16 |  | 275d |  | start no earlier than 2007-02-05 | Le Mignant [8.3%]; Other [58.3%] | 160h |
| 164 | 3.1.1.12 | Observing Uptime | 30d? | 2007-02-05 | 2007-03-16 |  | 275d |  | start no earlier than 2007-02-05 | Chin [16.7%]; Johansson [16.7%] | 80h |
| 165 | 3.1.1.13 | **Performance Budgets Summary** | 110d? | 2007-01-15 | 2007-06-15 |  | 166d | 130d |  |  | 160h |
| 166 | 3.1.1.13.1 | Performance Budgets Version 1 | 20d? | 2007-01-15 | 2007-02-09 |  | 256d | 0d | start no earlier than 2007-01-15 | Dekany [25%]; Neyman [37.5%] | 100h |
| 167 | 3.1.1.13.2 | Performance Budgets Version 2 | 25d? | 2007-05-14 | 2007-06-15 |  | 166d |  | start no earlier than 2007-05-14 | Dekany [10%]; Neyman [20%] | 60h |
| 168 | 3.1.1.14 | **Science Products** | 52d? | 2007-07-16 | 2007-09-25 |  | 138d |  |  |  | 360h |
| 169 | 3.1.1.14.1 | All-In Science Simulations | 20d? | 2007-07-16 | 2007-08-10 | 167 | 170d |  | start no earlier than 2007-07-16 | Neyman [50%]; Flicker [50%] | 160h |
| 170 | 3.1.1.14.2 | **Additional Science Characterization Results** | 32d? | 2007-08-13 | 2007-09-25 |  | 138d |  |  |  | 200h |
| 171 | 3.1.1.14.2.1 | Point Source Sensitivities | 15d? | 2007-08-13 | 2007-08-31 | 169 | 155d |  | start no earlier than 2007-04-02 | Bouchez [33.3%] | 40h |
| 172 | 3.1.1.14.2.2 | PSF Uniformity & Stability | 15d? | 2007-08-13 | 2007-08-31 | 169 | 155d |  | start no earlier than 2007-04-02 | Neyman [66.7%] | 80h |
| 173 | 3.1.1.14.2.3 | Other | 15d? | 2007-09-05 | 2007-09-25 | 169 | 138d |  | start no earlier than 2007-09-05 |  | 80h |
| 174 | 3.1.2 | **Trade Studies** | 160d? | 2006-10-16 | 2007-05-25 |  | 133d |  |  |  | 1950h |
| 175 | 3.1.2.1 | **System Architecture Trade Studies** | 100d? | 2006-10-16 | 2007-03-02 |  | 285d |  |  |  | 770h |
| 176 | 3.1.2.1.1 | MOAO & MCAO TS | 25d? | 2006-11-13 | 2006-12-15 |  | 340d |  | finish no earlier than 2006-12-15 |  | 80h |
| 177 | 3.1.2.1.2 | NGAO versus Keck AO upgrades TS (meeting 5) | 20d? | 2007-02-05 | 2007-03-02 |  | 285d |  | start no earlier than 2007-02-05 | Neyman [37.5%]; Wizinowich [25%] | 100h |
| 178 | 3.1.2.1.3 | Adaptive Secondary Mirror option TS (m5) | 20d? | 2007-02-05 | 2007-03-02 |  | 285d |  | start no earlier than 2007-02-05 | Bouchez [15%]; Wizinowich [10%] | 40h |
| 179 | 3.1.2.1.4 | K & L-band Science TS (m5) | 20d? | 2007-02-05 | 2007-03-02 |  | 285d |  | start no earlier than 2007-02-05 | Bouchez [25%] | 40h |
| 180 | 3.1.2.1.5 | Keck Interferometer Support TS (m5) | 100d? | 2006-10-16 | 2007-03-02 |  | 285d |  | start no earlier than 2006-10-16 | Neyman [22.5%]; Wizinowich [2.5%] | 200h |
| 181 | 3.1.2.1.6 | Instrument Balance TS | 20d? | 2006-11-13 | 2006-12-08 |  | 345d |  | start no earlier than 2006-11-13 | Adkins [6.2%] | 10h |
| 182 | 3.1.2.1.7 | GLAO for non-NGAO Instruments TS (m5) | 20d? | 2007-02-05 | 2007-03-02 |  | 285d |  | start no earlier than 2007-02-05 | Flicker [12.5%] | 20h |
| 183 | 3.1.2.1.8 | Science Instrument Re-use Cost/Benefit TS (m3) | 20d? | 2006-11-13 | 2006-12-08 |  | 345d |  | start no earlier than 2006-11-13 | Adkins [25%]; Moore [50%] | 120h |
| 184 | 3.1.2.1.9 | Telescope Wavefront Errors TS | 13d? | 2006-12-04 | 2006-12-20 | 142, 143 | 315d | 7d | finish no earlier than 2006-12-20 | Neyman [38.5%]; Flicker [38.5%] | 80h |
| 185 | 3.1.2.1.10 | Observing Model TS | 45d? | 2006-11-13 | 2007-01-12 |  | 320d |  | finish no earlier than 2007-01-12 | Le Mignant [22.2%] | 80h |

Notes:
- 155: RD
- 156: RD
- 157: RD
- 158: DG
- 159: MB
- 160: CN
- 161: MI
- 162: BM
- 163: DLM
- 164: JC
- 166: RD
- 167: RD
- 169: CN
- 171: AB
- 172: CN
- 176: DG
- 177: PW
- 178: AB
- 179: AB
- 180: CN
- 181: SA
- 182: RF
- 183: SA
- 184: CN
- 185: DLM

| ID | WBS | Task | Duration | Start | Finish | Total slack | Free slack | Constraint | Resources | Work |
| --- | --- | --- | --- | --- | --- | --- | --- | --- | --- | --- |
| 186 | 3.1.2.2 | **Adaptive Optics System Trade Studies** | 150d? | 2006-10-30 | 2007-05-25 | 123d |  |  |  | 950h |
| 187 | 3.1.2.2.1 | AO Enclosure Temperature TS (m6) | 74d? | 2007-01-02 | 2007-04-13 | 141d | 0d | start no earlier than 2007-01-02 | Bouchez [5.1%]; Meguro [6.8%]; Other [5.1%] | 100h |
| 188 | 3.1.2.2.2 | Optical Relay TS (m6) | 74d? | 2007-01-02 | 2007-04-13 | 101d | 0d | finish no earlier than 2007-04-13 | Bauman [5.1%]; Dekany [5.1%] | 60h |
| 189 | 3.1.2.2.3 | Field Rotation Strategy TS (m6) | 74d? | 2007-01-02 | 2007-04-13 | 101d | 0d | start no earlier than 2007-01-02 | Bauman [10.1%]; Meguro [3.4%] | 80h |
| 190 | 3.1.2.2.4 | Dichroics & Beamsplitters TS (m6) | 74d? | 2007-01-02 | 2007-04-13 | 101d | 0d | start no earlier than 2007-01-02 | Velur [10.1%] | 60h |
| 191 | 3.1.2.2.5 | Rayleigh Rejection TS (m3) | 30d? | 2006-10-30 | 2006-12-08 | 345d |  | start no earlier than 2006-10-30 | Kellner [16.7%] | 40h |
| 192 | 3.1.2.2.6 | LGS WFS Type TS (m4) | 35d? | 2006-12-04 | 2007-01-19 | 38d | 0d | start no earlier than 2006-12-04 | Velur [10.7%] | 30h |
| 193 | 3.1.2.2.7 | LGS WFS number of subapertures TS (m4) | 35d? | 2006-12-04 | 2007-01-19 | 38d | 0d | start no earlier than 2006-12-04 | Velur [7.1%] | 20h |
| 194 | 3.1.2.2.8 | Slow WFS TS (m7) | 25d? | 2007-04-23 | 2007-05-25 | 38d | 0d | start no earlier than 2007-04-23 | Velur [40%] | 80h |
| 195 | 3.1.2.2.9 | LOWFS Architecture TS | 35d? | 2006-12-04 | 2007-01-19 | 226d | 60d | start no earlier than 2006-12-04 | Kellner [71.4%] | 200h |
| 196 | 3.1.2.2.10 | Number & Type of LOWFS TS (m4) | 35d? | 2006-12-04 | 2007-01-19 | 226d | 60d | start no earlier than 2006-12-04 | Kellner [21.4%] | 60h |
| 197 | 3.1.2.2.11 | Centroid Anisoplanatism TS (m7) | 25d? | 2007-04-23 | 2007-05-25 | 225d |  | start no earlier than 2007-04-23 | Kellner [20%] | 40h |
| 198 | 3.1.2.2.12 | Deformable Mirror Stroke Requirement TS (m6) | 74d? | 2007-01-02 | 2007-04-13 | 255d |  | start no earlier than 2007-01-02 | Flicker [8.4%] | 50h |
| 199 | 3.1.2.2.13 | Stand-alone vs DM on T/T Stage TS (m3) | 30d? | 2006-10-30 | 2006-12-08 | 345d |  | start no earlier than 2006-10-30 | Bauman [25%] | 60h |
| 200 | 3.1.2.2.14 | Correcting Fast T/T with DM TS | 30d? | 2006-10-30 | 2006-12-08 | 345d |  | finish no earlier than 2006-12-08 | Bauman [8.3%]; Flicker [8.3%] | 40h |
| 201 | 3.1.2.2.15 | Focus Compensation TS (m6) | 74d? | 2007-01-22 | 2007-05-03 | 241d |  | start no earlier than 2007-01-22 | Bouchez [5.1%] | 30h |
| 202 | 3.1.2.3 | **Laser Facility Trade Studies** | 155d? | 2006-10-23 | 2007-05-25 | 225d |  |  |  | 230h |
| 203 | 3.1.2.3.1 | Laser Pulse Format TS (m6) | 74d? | 2007-01-02 | 2007-04-13 | 255d |  | start no earlier than 2007-01-02 | Velur [16.9%] | 100h |
| 204 | 3.1.2.3.2 | Free Space vs Fiber TS (m7) | 25d? | 2007-04-23 | 2007-05-25 | 225d |  | start no earlier than 2007-04-23 | Neyman [50%] | 100h |
| 205 | 3.1.2.3.3 | LGS Asterism Geometry & Size TS (m2) | 5d? | 2006-10-23 | 2006-10-27 | 375d |  | finish no earlier than 2006-10-27 | Flicker [50%] | 20h |
| 206 | 3.1.2.3.4 | Variable vs fixed LGS Asterism Cost/Benefit TS (m2) | 5d? | 2006-10-23 | 2006-10-27 | 375d |  | finish no earlier than 2006-10-27 | Velur [25%] | 10h |
| 207 | 3.1.3 | **System Architecture** | 293d? | 2006-11-01 | 2007-12-14 | 80d |  |  |  | 1260h |
| 208 | 3.1.3.1 | System Architecture Version 1 | 36d? | 2006-11-01 | 2006-12-20 | 269d | 8d | start no earlier than 2006-11-01 | Dekany [10.4%]; Gavel [10.4%]; Wizinowich [6.9%] | 80h |
| 209 | 3.1.3.2 | System Architecture Version 2 | 20d? | 2007-10-01 | 2007-10-26 | 115d |  | start no earlier than 2007-10-01 | Dekany [12.5%]; Gavel [12.5%]; Wizinowich [12.5%] | 60h |

Notes:
- 187: AB
- 188: RD
- 189: BB
- 190: VV
- 191: VV
- 192: VV
- 193: VV
- 194: VV
- 195: SK
- 196: SK
- 197: SK
- 198: RF
- 199: BB
- 200: BB
- 201: AB
- 203: VV
- 204: CN
- 205: RF
- 206: VV

| ID | WBS | Task | Duration | Start | Finish | Predecessors | Total slack | Free slack | Constraint | Resources | Work |
| --- | --- | --- | --- | --- | --- | --- | --- | --- | --- | --- | --- |
| 210 | 3.1.3.3 | **Functional Requirements** | 244d? | 2007-01-02 | 2007-12-07 |  | 41d | 5d |  |  | 1000h |
| 211 | 3.1.3.3.1 | AO System Functional Requirements Version 1 | 17.25d? | 2007-01-10 | 2007-02-02 | 208 | 261d |  | finish no earlier than 2007-02-02 | Neyman [54.3%]; Chin [18.1%]; Stomski [18.1%]; Meguro [18.1%]; Bauman [18.1%]; Johansson [18.1%] | 200h |
| 212 | 3.1.3.3.2 | AO System Functional Requirements Version 2 | 25d? | 2007-10-29 | 2007-11-30 |  | 46d |  | start no earlier than 2007-10-29 | Neyman [12.5%]; Chin [7.5%]; Stomski [7.5%]; Meguro [7.5%]; Bauman [7.5%]; Johansson [7.5%] | 100h |
| 213 | 3.1.3.3.3 | Laser System Functional Requirements Version 1 | 20d? | 2007-02-05 | 2007-03-02 | 208 | 241d |  | finish no earlier than 2007-03-02 | Chin [34.4%]; Velur [34.4%]; Stomski [15.6%] | 135h |
| 214 | 3.1.3.3.4 | Laser System Functional Requirements Version 2 | 25d? | 2007-11-05 | 2007-12-07 |  | 41d |  | start no earlier than 2007-11-05 | Chin [12.5%]; Velur [12.5%]; Stomski [7.5%] | 65h |
| 215 | 3.1.3.3.5 | Science Operations Functional Requirements Version 1 | 24d? | 2007-01-02 | 2007-02-02 | 208 | 261d |  | finish no earlier than 2007-02-02 | Le Mignant [20.8%]; Other [31.2%] | 100h |
| 216 | 3.1.3.3.6 | Science Operations Functional Requirements Version 2 | 25d? | 2007-10-29 | 2007-11-30 |  | 46d |  | start no earlier than 2007-10-29 | Le Mignant [20%]; Other [30%] | 100h |
| 217 | 3.1.3.3.7 | Science Instruments Functional Requirements Version 1 | 24d? | 2007-01-02 | 2007-02-02 |  | 261d |  | start no earlier than 2007-01-02 | Adkins [20.8%]; Other [41.7%] | 120h |
| 218 | 3.1.3.3.8 | Science Instruments Functional Requirements Version 2 | 25d? | 2007-10-29 | 2007-11-30 |  | 46d |  | start no earlier than 2007-10-29 | Adkins [20%]; Other [70%] | 180h |
| 219 | 3.1.3.4 | Technology Drivers Summary | 3.63d? | 2007-12-03 | 2007-12-06 |  | 42.37d | 6.37d | start no earlier than 2007-12-03 | Neyman [82.7%]; Gavel [55.1%] | 40h |
| 220 | 3.1.3.5 | Technical Risk Analysis Version 1 | 23d? | 2007-03-19 | 2007-04-18 |  | 252d |  | start no earlier than 2007-03-19 | Neyman [13%]; Gavel [8.7%] | 40h |
| 221 | 3.1.3.6 | Technical Risk Analysis Version 2 | 25d? | 2007-11-12 | 2007-12-14 |  | 36d | 0d | start no earlier than 2007-11-12 | Neyman [12%]; Gavel [8%] | 40h |
| 222 | 3.2 | **AO System** | 247d? | 2007-01-02 | 2007-12-12 |  | 38d | 2d |  |  | 2090h |
| 223 | 3.2.1 | AO System Architecture | 60d? | 2007-02-05 | 2007-04-27 |  | 201d |  | start no earlier than 2007-02-05 | Neyman [33.3%]; Other [35.4%] | 330h |
| 224 | 3.2.2 | AO Enclosure | 70d? | 2007-04-16 | 2007-07-20 | 187 | 141d |  | start no earlier than 2007-01-22 |  | 100h |
| 225 | 3.2.3 | **Opto-mechanical** | 203d? | 2007-03-05 | 2007-12-12 |  | 38d |  |  |  | 660h |
| 226 | 3.2.3.1 | Field Rotation | 55d? | 2007-04-16 | 2007-06-29 | 189 | 101d | 0d | finish no earlier than 2007-06-29 | Bauman [4.5%]; Meguro [2.3%] | 30h |
| 227 | 3.2.3.2 | Optical Relay | 55d? | 2007-04-16 | 2007-06-29 | 188 | 101d | 0d | start no earlier than 2007-03-05 | Bauman [5.7%]; Meguro [3.4%] | 40h |
| 228 | 3.2.3.3 | Optical Switchyard | 55d? | 2007-04-16 | 2007-06-29 | 190 | 101d | 0d | finish no earlier than 2007-06-29 | Bauman [5.7%]; Meguro [5.7%] | 50h |
| 229 | 3.2.3.4 | Optical Support Structure | 55d? | 2007-07-02 | 2007-09-14 | 226, 227, 228 | 101d |  | start no earlier than 2007-04-16 | Meguro [9.1%]; Bauman [4.5%] | 60h |
| 230 | 3.2.3.5 | **Wavefront Sensors** | 173d? | 2007-04-16 | 2007-12-12 |  | 38d |  |  |  | 240h |
| 231 | 3.2.3.5.1 | High Order LGS Wavefront Sensors | 173d? | 2007-04-16 | 2007-12-12 | 192, 193 | 38d |  | start no earlier than 2007-04-16 | Velur [4.3%]; Meguro [1.4%] | 80h |
| 232 | 3.2.3.5.2 | High Order NGS Wavefront Sensor | 173d? | 2007-04-16 | 2007-12-12 |  | 38d |  | start no earlier than 2007-04-16 | Velur [2.2%]; Meguro [0.7%] | 40h |
| 233 | 3.2.3.5.3 | Low Order NGS Wavefront Sensors | 173d? | 2007-04-16 | 2007-12-12 | 195, 196 | 38d |  | finish no earlier than 2007-12-12 | Kellner [2.9%]; Meguro [2.9%] | 80h |
| 234 | 3.2.3.5.4 | Calibration Wavefront Sensor | 143d? | 2007-05-28 | 2007-12-12 | 194 | 38d |  | start no earlier than 2007-04-16 | Kellner [3.5%] | 40h |

Notes:
- 211: CN
- 212: CN
- 213: JC
- 214: JC
- 215: DLM
- 216: DLM
- 217: SA
- 218: SA
- 219: DG
- 220: DG
- 221: DG
- 226: BB
- 227: BB
- 228: BB
- 229: BB
- 231: VV
- 232: VV
- 233: SK
- 234: SK

| ID | WBS | Task | Duration | Start | Finish | Total slack | Free slack | Constraint | Resources | Work |
| --- | --- | --- | --- | --- | --- | --- | --- | --- | --- | --- |
| 235 | 3.2.3.6 | **Wavefront Correctors** | 85d? | 2007-03-05 | 2007-06-29 | 156d |  |  |  | 140h |
| 236 | 3.2.3.6.1 | Tip/Tilt Corrector | 85d? | 2007-03-05 | 2007-06-29 | 156d |  | start no earlier than 2007-03-05 | Flicker [2.9%] | 20h |
| 237 | 3.2.3.6.2 | Deformable Mirror | 85d? | 2007-03-05 | 2007-06-29 | 156d |  | start no earlier than 2007-03-05 | Flicker [5.9%]; Bauman [11.8%] | 120h |
| 238 | 3.2.3.7 | **Acquisition Cameras** | 85d? | 2007-03-05 | 2007-06-29 | 156d |  |  |  | 20h |
| 239 | 3.2.3.7.1 | NGS Acquisition Camera | 85d? | 2007-03-05 | 2007-06-29 | 156d |  | start no earlier than 2007-03-05 | Bouchez [1.5%] | 10h |
| 240 | 3.2.3.7.2 | LGS Acquisition Camera | 85d? | 2007-03-05 | 2007-06-29 | 156d |  | start no earlier than 2007-03-05 | Bouchez [1.5%] | 10h |
| 241 | 3.2.3.8 | Atmospheric Dispersion Correction | 85d? | 2007-03-05 | 2007-06-29 | 156d |  | start no earlier than 2007-03-05 | Kellner [2.9%] | 20h |
| 242 | 3.2.3.9 | Alignment, Calibration, Diagnostics, Metrology and Monitoring | 85d? | 2007-03-05 | 2007-06-29 | 156d |  | finish no earlier than 2007-06-29 | Neyman [4.4%]; Flicker [4.4%] | 60h |
| 243 | 3.2.4 | **Non-real-time Control** | 64d? | 2007-05-01 | 2007-07-27 | 136d |  |  |  | 500h |
| 244 | 3.2.4.1 | Non-RTC Software Design | 64d? | 2007-05-01 | 2007-07-27 | 136d |  | finish no earlier than 2007-07-27 | Johansson [19.5%]; Stomski [19.5%]; Johnson [9.8%] | 250h |
| 245 | 3.2.4.2 | Non-RTC Electrical Design | 64d? | 2007-05-01 | 2007-07-27 | 136d |  | start no earlier than 2007-05-01 | Chin [24.4%]; Other [24.4%] | 250h |
| 246 | 3.2.5 | **Real-time Control** | 119d? | 2007-01-02 | 2007-06-15 | 166d |  |  |  | 500h |
| 247 | 3.2.5.1 | RTC Architecture Analysis and Design Study | 64d? | 2007-01-02 | 2007-03-30 | 221d |  | finish no earlier than 2007-03-30 | Gavel [19.5%]; Johansson [15.6%]; Flicker [13.7%] | 250h |
| 248 | 3.2.5.2 | RTC Software Module Definition | 75d? | 2007-03-05 | 2007-06-15 | 166d |  | finish no earlier than 2007-06-15 |  | 125h |
| 249 | 3.2.5.3 | RTC Hardware Module Definition | 75d? | 2007-03-05 | 2007-06-15 | 166d |  | finish no earlier than 2007-06-15 |  | 125h |
| 250 | 3.3 | **Laser Facility** | 154d? | 2007-01-02 | 2007-08-03 | 131d | 95d |  |  | 910h |
| 251 | 3.3.1 | Laser System Architecture | 85d? | 2007-01-02 | 2007-04-30 | 200d |  | start no earlier than 2007-01-02 |  | 100h |
| 252 | 3.3.2 | Laser Enclosure | 43d? | 2007-05-01 | 2007-06-28 | 157d |  | start no earlier than 2007-05-01 |  | 100h |
| 253 | 3.3.3 | Laser | 35d? | 2007-01-15 | 2007-03-02 | 241d |  | start no earlier than 2007-01-15 |  | 100h |
| 254 | 3.3.4 | **Laser Launch Facility** | 83d? | 2007-02-05 | 2007-05-30 | 178d |  |  |  | 420h |
| 255 | 3.3.4.1 | Laser Beam Transport | 60d? | 2007-02-05 | 2007-04-27 | 201d |  | start no earlier than 2007-02-05 | Neyman [7.3%]; Kellner [4.2%]; Chin [1%] | 60h |
| 256 | 3.3.4.2 | Laser Pointing & Diagnostics | 43d? | 2007-04-02 | 2007-05-30 | 178d |  | start no earlier than 2007-04-02 | Neyman [20.3%]; Kellner [20.3%]; Chin [5.8%] | 160h |
| 257 | 3.3.4.3 | Laser Launch Telescope | 61d? | 2007-02-05 | 2007-04-30 | 200d |  | start no earlier than 2007-02-05 | Neyman [16.4%]; Kellner [16.4%]; Chin [8.2%] | 200h |
| 258 | 3.3.5 | **Laser Safety Systems** | 20d? | 2007-07-09 | 2007-08-03 | 131d |  |  |  | 40h |
| 259 | 3.3.5.1 | Personnel and Equipment Safety Systems | 20d? | 2007-07-09 | 2007-08-03 | 131d |  | start no earlier than 2007-07-09 | Chin [12.5%] | 20h |
| 260 | 3.3.5.2 | Aircraft, Satellite & Laser Traffic Control Safety Systems | 20d? | 2007-07-09 | 2007-08-03 | 131d |  | start no earlier than 2007-07-09 | Chin [12.5%] | 20h |

Notes:
- 236: RF
- 237: RF
- 239: AB
- 240: AB
- 241: SK
- 242: CN
- 244: EJ
- 245: JC
- 246: DG
- 247: DG
- 248: EJ
- 255: CN
- 256: CN
- 257: CN
- 259: JC
- 260: JC

| ID | WBS | Task | Duration | Start | Finish | Total slack | Free slack | Constraint | Resources | Work |
| --- | --- | --- | --- | --- | --- | --- | --- | --- | --- | --- |
| 261 | 3.3.6 | **Laser System Control** | 83d? | 2007-02-05 | 2007-05-30 | 178d |  |  |  | 150h |
| 262 | 3.3.6.1 | Laser System Software | 83d? | 2007-02-05 | 2007-05-30 | 178d |  | start no earlier than 2007-02-05 | Johansson [6%]; Stomski [6%] | 80h |
| 263 | 3.3.6.2 | Laser System Electronics | 83d? | 2007-02-05 | 2007-05-30 | 178d |  | start no earlier than 2007-02-05 | Chin [10.5%] | 70h |
| 264 | 3.4 | **Science Operations** | 154d? | 2007-01-02 | 2007-08-03 | 131d | 95d |  |  | 670h |
| 265 | 3.4.1 | **Astronomical Observations Operations** | 108d? | 2007-03-01 | 2007-07-30 | 135d |  |  |  | 220h |
| 266 | 3.4.1.1 | **Pre-Observing Interfaces** | 22d? | 2007-05-01 | 2007-05-30 | 178d |  |  |  | 60h |
| 267 | 3.4.1.1.1 | AO Guide Star Interface | 22d? | 2007-05-01 | 2007-05-30 | 178d |  | finish no earlier than 2007-05-30 |  | 20h |
| 268 | 3.4.1.1.2 | Science Observations Simulation Tools | 22d? | 2007-05-01 | 2007-05-30 | 178d |  | start no earlier than 2007-05-01 |  | 40h |
| 269 | 3.4.1.2 | **Observing Interfaces** | 43d? | 2007-03-01 | 2007-04-30 | 200d |  |  |  | 80h |
| 270 | 3.4.1.2.1 | Acquisition | 43d? | 2007-03-01 | 2007-04-30 | 200d |  | finish no earlier than 2007-04-30 |  | 20h |
| 271 | 3.4.1.2.2 | Observing Sequences | 43d? | 2007-03-01 | 2007-04-30 | 200d |  | start no earlier than 2007-03-01 |  | 20h |
| 272 | 3.4.1.2.3 | Instrument, AO & Telescope Observer Interfaces | 43d? | 2007-03-01 | 2007-04-30 | 200d |  | start no earlier than 2007-03-01 |  | 20h |
| 273 | 3.4.1.2.4 | Science Data Quality Monitoring | 43d? | 2007-03-01 | 2007-04-30 | 200d |  | start no earlier than 2007-03-01 |  | 20h |
| 274 | 3.4.1.3 | **Post-Observing Interfaces** | 42d? | 2007-06-01 | 2007-07-30 | 135d |  |  |  | 80h |
| 275 | 3.4.1.3.1 | Generic Data Products | 42d? | 2007-06-01 | 2007-07-30 | 135d |  | finish no earlier than 2007-07-30 |  | 20h |
| 276 | 3.4.1.3.2 | Science Data Quality Assessment | 42d? | 2007-06-01 | 2007-07-30 | 135d |  | start no earlier than 2007-06-01 |  | 20h |
| 277 | 3.4.1.3.3 | Science Data Archiving | 42d? | 2007-06-01 | 2007-07-30 | 135d |  | start no earlier than 2007-06-01 |  | 40h |
| 278 | 3.4.2 | **AO-Instrument Operations** | 154d? | 2007-01-02 | 2007-08-03 | 131d |  |  |  | 450h |
| 279 | 3.4.2.1 | **AO-Instrument Operations Architecture** | 154d? | 2007-01-02 | 2007-08-03 | 131d |  |  |  | 270h |
| 280 | 3.4.2.1.1 | AO-Instrument Observing Modes | 24d? | 2007-01-02 | 2007-02-02 | 261d |  | start no earlier than 2007-01-02 | Le Mignant [20.8%]; Other [20.8%] | 80h |
| 281 | 3.4.2.1.2 | AO-Instrument Operations Support | 83d? | 2007-02-05 | 2007-05-30 | 178d |  | finish no earlier than 2007-05-30 |  | 20h |
| 282 | 3.4.2.1.3 | AO-Instrument Configuration & Setup | 83d? | 2007-02-05 | 2007-05-30 | 178d |  | start no earlier than 2007-02-05 |  | 20h |
| 283 | 3.4.2.1.4 | AO-Instrument Calibrations | 83d? | 2007-02-05 | 2007-05-30 | 178d |  | start no earlier than 2007-02-05 |  | 20h |
| 284 | 3.4.2.1.5 | AO-Instrument Nighttime Operation Modes | 83d? | 2007-02-05 | 2007-05-30 | 178d |  | start no earlier than 2007-02-05 |  | 20h |
| 285 | 3.4.2.1.6 | AO-Instrument Science Acquisition & Control | 83d? | 2007-02-05 | 2007-05-30 | 178d |  | start no earlier than 2007-02-05 |  | 20h |
| 286 | 3.4.2.1.7 | AO-Instrument Health Monitoring & Automated Recovery | 83d? | 2007-02-05 | 2007-05-30 | 178d |  | start no earlier than 2007-02-05 |  | 20h |
| 287 | 3.4.2.1.8 | AO-Instrument Laser Traffic Control | 20d? | 2007-07-09 | 2007-08-03 | 131d |  | start no earlier than 2007-07-09 | Summers [6.2%] | 10h |
| 288 | 3.4.2.1.9 | AO-Instrument User Interfaces | 20d? | 2007-06-04 | 2007-06-29 | 156d |  | finish no earlier than 2007-06-29 |  | 40h |
| 289 | 3.4.2.1.10 | AO-Instrument Maintenance Plan | 20d? | 2007-07-02 | 2007-07-27 | 136d |  | finish no earlier than 2007-07-27 |  | 20h |

Notes:
- 262: EJ
- 263: JC
- 264: DLM
- 265: DLM
- 278: DLM
- 279: DLM
- 280: DLM
- 287: DS

| ID | WBS | Task | Duration | Start | Finish | Predecessors | Total slack | Free slack | Constraint | Resources | Work |
| --- | --- | --- | --- | --- | --- | --- | --- | --- | --- | --- | --- |
| 290 | 3.4.2.2 | **AO-Instrument Operations Optimization** | 45d? | 2007-03-05 | 2007-05-04 |  | 196d |  |  |  | 180h |
| 291 | 3.4.2.2.1 | AO-Instrument Performance Prediction | 30d? | 2007-03-05 | 2007-04-13 |  | 211d |  | start no earlier than 2007-03-05 | Flicker [25%]; Other [8.3%] | 80h |
| 292 | 3.4.2.2.2 | AO-Instrument Real-Time Optimization | 30d? | 2007-03-05 | 2007-04-13 |  | 211d |  | start no earlier than 2007-03-05 | Flicker [25%]; Other [8.3%] | 80h |
| 293 | 3.4.2.2.3 | AO-Instrument Environment Monitoring | 15d? | 2007-04-16 | 2007-05-04 |  | 196d |  | finish no earlier than 2007-05-04 |  | 20h |
| 294 | 3.5 | **Science Instruments** | 173d? | 2006-10-02 | 2007-05-30 |  | 178d | 142d |  |  | 1300h |
| 295 | 3.5.1 | OSIRIS | 43d? | 2006-12-01 | 2007-01-30 |  | 264d |  | start no earlier than 2006-12-01 | Adkins [4.7%]; Other [24.4%] | 100h |
| 296 | 3.5.2 | Interferometer | 130d? | 2006-10-02 | 2007-03-30 |  | 221d |  | start no earlier than 2006-10-02 | Adkins [1.5%]; Neyman [7.7%]; Other [10%] | 200h |
| 297 | 3.5.3 | OHANA | 20d? | 2007-02-01 | 2007-02-28 |  | 243d |  | start no earlier than 2007-02-01 | Adkins [5%]; Other [11.2%]; Woillez [15%] | 50h |
| 298 | 3.5.4 | Near-IR Imager | 87d? | 2006-10-02 | 2007-01-30 |  | 264d |  | start no earlier than 2006-10-02 | Adkins [4.3%]; Other [31.6%] | 250h |
| 299 | 3.5.5 | Visible Imager | 87d? | 2006-10-02 | 2007-01-30 |  | 264d |  | start no earlier than 2006-10-02 | Adkins [4.3%]; Other [31.6%] | 250h |
| 300 | 3.5.6 | Visible IFU | 64d? | 2007-01-02 | 2007-03-30 |  | 221d |  | start no earlier than 2007-01-02 | Adkins [3.1%]; Other [16.4%] | 100h |
| 301 | 3.5.7 | Deployable Near-IR IFU | 63d? | 2007-02-01 | 2007-04-30 |  | 200d |  | start no earlier than 2007-02-01 | Adkins [7.9%]; Other [35.7%]; Neyman [15.9%] | 300h |
| 302 | 3.5.8 | Mid-IR IFU | 22d? | 2007-05-01 | 2007-05-30 |  | 178d |  | start no earlier than 2007-05-01 | Adkins [4.5%]; Other [23.9%] | 50h |
| 303 | 3.6 | System Design Manual | 29d? | 2007-12-17 | 2008-01-25 | 210, 221, 294, 165, 264, 219, 250, 222 | 20d | 0d | finish no earlier than 2007-11-16 | Wizinowich [17.2%]; Dekany [8.6%]; Gavel [8.6%] | 80h |
| 304 | 4 | **Systems Engineering Management Plan (SEMP)** | 253d? | 2007-01-15 | 2008-01-02 |  | 37d |  |  |  | 986h |
| 305 | 4.1 | **Project Plan** | 59.25d? | 2007-09-17 | 2007-12-07 |  | 64d | 5d |  |  | 340h |
| 306 | 4.1.1 | Task Definition | 4.25d? | 2007-09-17 | 2007-09-21 |  | 119d |  | finish no earlier than 2007-09-21 | Wizinowich [58.8%]; Dekany [58.8%]; Gavel [58.8%]; Max [58.8%] | 80h |
| 307 | 4.1.2 | Cost Estimation | 10d? | 2007-10-22 | 2007-11-02 |  | 89d |  | finish no earlier than 2007-11-02 | Wizinowich [62.5%]; Dekany [62.5%]; Gavel [62.5%]; Other [62.5%] | 200h |
| 308 | 4.1.3 | Major Project Milestones | 2.5d? | 2007-11-09 | 2007-11-13 |  | 82d |  | finish no earlier than 2007-11-13 | Wizinowich [50%]; Dekany [50%] | 20h |
| 309 | 4.1.4 | MS Project Plan | 4.5d? | 2007-12-03 | 2007-12-07 |  | 64d |  | finish no earlier than 2007-12-07 | Wizinowich [27.8%]; Dekany [27.8%]; Gavel [27.8%]; Max [27.8%] | 40h |
| 310 | 4.2 | Risk Assessment & Management Plan | 23d? | 2007-11-14 | 2007-12-14 |  | 59d | 0d | finish no earlier than 2007-12-14 |  | 40h |
| 311 | 4.3 | **Preliminary Design Phase Plan** | 140d? | 2007-02-05 | 2007-08-17 |  | 144d | 85d |  |  | 166h |
| 312 | 4.3.1 | Version 1 to Support Observatory FY08 Planning | 20d? | 2007-02-05 | 2007-03-02 |  | 264d |  | start no earlier than 2007-02-05 | Wizinowich [10%]; Dekany [6.2%]; Gavel [6.2%]; Max [3.8%] | 42h |
| 313 | 4.3.2 | Intermediate Versions | 30d? | 2007-04-09 | 2007-05-18 |  | 209d |  | start no earlier than 2007-04-09 | Wizinowich [7.5%]; Dekany [3.3%]; Gavel [3.3%]; Max [2.5%] | 40h |
| 314 | 4.3.3 | Final Version | 15d? | 2007-07-30 | 2007-08-17 |  | 144d |  | start no earlier than 2007-07-30 | Wizinowich [26.7%]; Dekany [16.7%]; Gavel [16.7%]; Max [10%] | 84h |

Notes:
- 294: SA
- 304: PW
- 305: PW
- 306: PW
- 307: PW
- 308: PW
- 309: PW
- 311: PW
- 312: PW
- 313: PW
- 314: PW

| ID | WBS | Task | Duration | Start | Finish | Predecessors | Total slack | Free slack | Constraint | Resources | Work |
| --- | --- | --- | --- | --- | --- | --- | --- | --- | --- | --- | --- |
| 315 | 4.4 | **Integration and Test Plans** | 187d? | 2007-03-12 | 2007-11-27 |  | 72d |  |  |  | 200h |
| 316 | 4.4.1 | **Subsystem Testing Plans** | 22d? | 2007-10-29 | 2007-11-27 |  | 72d | 13d |  |  | 100h |
| 317 | 4.4.1.1 | AO System Test Plan | 22d? | 2007-10-29 | 2007-11-27 |  | 72d |  | start no earlier than 2007-10-29 | Neyman [14.2%] | 25h |
| 318 | 4.4.1.2 | Laser System Test Plan | 22d? | 2007-10-29 | 2007-11-27 |  | 72d |  | start no earlier than 2007-10-29 | Neyman [14.2%] | 25h |
| 319 | 4.4.1.3 | Science Operations Test Plan | 22d? | 2007-10-29 | 2007-11-27 |  | 72d |  | start no earlier than 2007-10-29 | Neyman [14.2%] | 25h |
| 320 | 4.4.1.4 | Science Instruments Test Plan | 22d? | 2007-10-29 | 2007-11-27 |  | 72d |  | start no earlier than 2007-10-29 | Neyman [14.2%] | 25h |
| 321 | 4.4.2 | System Integration & Test Plans | 30d? | 2007-03-12 | 2007-04-20 |  | 229d | 170d | finish no earlier than 2007-04-20 | Neyman [41.7%] | 100h |
| 322 | 4.5 | Configuration Management Plan | 25d? | 2007-01-15 | 2007-02-16 |  | 274d | 215d | start no earlier than 2007-01-15 | Johnson [25%]; Other [10%]; Chin [5%] | 80h |
| 323 | 4.6 | Project Management Plan | 20d? | 2007-02-12 | 2007-03-09 |  | 259d | 200d | start no earlier than 2007-02-12 | Wizinowich [12.5%]; Dekany [12.5%]; Gavel [12.5%]; Max [12.5%] | 80h |
| 324 | 4.7 | SEMP Document | 13d? | 2007-12-17 | 2008-01-02 | 305, 311, 316, 321, 322, 323, 310 | 59d | 23d | finish no earlier than 2008-01-02 | Wizinowich [30.8%]; Dekany [15.4%]; Gavel [15.4%]; Max [15.4%] | 80h |

Notes:
- 315: CN
- 316: CN
- 317: CN
- 318: CN
- 319: CN
- 320: CN
- 321: CN
- 322: JJ
- 323: PW
- 324: PW
