# NGAO SD schedule v13

Schedule from MS Project, 2006-06-21 to 2008-05-20, costs in $.
CARA

## Calendars

- Standard: Mon-Fri 08:00-12:00, 13:00-17:00; Sat-Sun off.

## Resources

| Resource | Group | Rate | Notes |
| --- | --- | --- | --- |
| Flicker | WMKO | 40 | AO Modeller |
| Gavel | UCSC | 62 | EC |
| Neyman | WMKO | 62 | AO |
| Dekany | COO | 62 | EC |
| Bouchez | COO | 62 | AO Scientist |
| Max | UCSC | 62 | EC, Science |
| Wizinowich | WMKO | 62 | EC |
| Britton | COO | 62 | AO Modeller |
| Moore | COO | 62 | Instrum Sci |
| Velur | COO | 62 | AO Scientist |
| Chin | WMKO | 62 | EE |
| Johansson | WMKO | 62 | SE, EE |
| Meguro | WMKO | 62 | ME |
| Stomski | WMKO | 62 | SE |
| Clare | WMKO | 40 | AO Modeller |
| Adkins | WMKO | 62 | Prog mgmt |
| Bell | WMKO | 61.86 | ME |
| Sweeney | WMKO | 62 | MD |
| Kellner | WMKO |  | AO Postdoc |
| van Dam | WMKO | 62 | AO Scientist |
| Johnson | WMKO | 62 | SE |
| Bauman | UCSC | 62 | OE |
| Macintosh | UCSC | 62 | Science |
| Le Mignant | WMKO | 62 | Instrum Sci |
| Postdoc | UCSC | 40 | Science |
| Other |  |  |  |
| Cameron | COO |  | Grad student |
| Randolph | WMKO | 62 | MD |
| Summers | WMKO | 62 | SE |
| Woillez | WMKO | 62 | KI Scientist |
| Ammons | UCSC |  | Grad student |
| Dillon | UCSC |  | Laser EO |
| Cowley | UCSC | 62 | ME, Mgr |
| Kupke | UCSC |  | AO Postdoc |
| Kibrick | UCSC | 62 | SE |
| Lockwood | UCSC | 61.86 | ME |
| Reinig | UCSC | 62 | EE, ECE |
| Severson | UCSC | 62 | AO Scientist |
| Thomas | UCSC | 40 | AO Postdoc |
| Stover | UCSC | 62 | EE |
| Ireland | COO | 40 | Postdoc |
| Student |  | 31 | Science |

## Schedule

| ID | WBS | Task | Type | Duration | Start | Finish | Predecessors | Total slack | Free slack | Constraint | Resources | Work | Cost | Text1 |
| --- | --- | --- | --- | --- | --- | --- | --- | --- | --- | --- | --- | --- | --- | --- |
| 1 | 1 | **SD Phase Management** |  | 500d? | 2006-06-21 | 2008-05-20 |  | 0d |  |  |  | 2889h | 174,911.41 |  |
| 2 | 1.1 | **Planning and Contracting** |  | 323d? | 2006-06-21 | 2007-09-14 |  | 177d |  |  |  | 220h | 13,640 |  |
| 3 | 1.1.1 | NGAO Proposal to SSC | milestone | 0d | 2006-06-21 | 2006-06-21 |  | 479d | 17d | start no earlier than 2006-06-21 |  |  |  |  |
| 4 | 1.1.2 | Management Structure Decision by Directors | milestone | 0d | 2006-07-14 | 2006-07-14 | 3 | 462d | 35d | start no earlier than 2006-07-14 |  |  |  |  |
| 5 | 1.1.3 | SD Phase System Engineering Management Plan |  | 21d? | 2006-09-01 | 2006-09-29 | 4 | 427d |  | finish no earlier than 2006-09-29 | Max [8.9%]; Gavel [8.9%]; Dekany [8.9%]; Wizinowich [20.8%] | 80h | 4,960 |  |
| 6 | 1.1.4 | SD Phase Contracts Generated |  | 23d? | 2006-09-27 | 2006-10-27 |  | 407d | 0d | start no earlier than 2006-09-27 | Adkins [16.7%]; Gavel [8.3%]; Dekany [8.3%] | 60h | 3,720 |  |
| 7 | 1.1.5 | Director Approval | milestone | 0d | 2006-10-09 | 2006-10-09 |  | 146d | 0d | start no earlier than 2006-10-09 |  |  |  |  |
| 8 | 1.1.6 | SD Partner Contracts Issued | milestone | 0d | 2006-10-27 | 2006-10-27 | 6, 7 | 407d |  | start no earlier than 2006-10-13 |  |  |  |  |
| 9 | 1.1.7 | Mid-year Replan |  | 10d | 2007-03-05 | 2007-03-16 |  | 307d |  | start no earlier than 2007-03-05 | Wizinowich [22.5%]; Dekany [10%]; Gavel [10%]; Max [7.5%] | 40h | 2,480 |  |
| 10 | 1.1.8 | FY08 Replan |  | 8d | 2007-09-05 | 2007-09-14 |  | 177d |  | start no earlier than 2007-09-05 | Wizinowich [28.1%]; Dekany [12.5%]; Gavel [12.5%]; Max [9.4%] | 40h | 2,480 | change date |
| 11 | 1.2 | **Project Meetings** |  | 500d? | 2006-06-21 | 2008-05-20 |  | 0d |  |  |  | 1916h | 115,624 |  |
| 12 | 1.2.1 | Executive Committee Telecons |  | 500d | 2006-06-21 | 2008-05-20 |  | 0d |  |  | Wizinowich [2.5%]; Dekany [2.5%]; Gavel [2.5%]; Max [2.5%] | 400h | 24,800 | 300 hr |
| 13 | 1.2.2 | Science Advisory Committee Telecons |  | 390d? | 2006-10-02 | 2008-03-28 |  | 37d |  | start no earlier than 2006-10-02 | Max [1.4%] | 40h | 2,480 |  |
| 14 | 1.2.3 | **Team Meetings** |  | 407d | 2006-09-14 | 2008-04-04 |  | 32d |  |  |  | 1476h | 88,344 |  |
| 15 | 1.2.3.1 | Team Meeting #1 (mgmt, science & technical - Irvine) |  | 1d | 2006-09-14 | 2006-09-14 |  | 438d |  | start no earlier than 2006-09-14 | Wizinowich; Dekany; Gavel; Max; Bauman; Bouchez; Velur; Flicker; Neyman; Britton; Le Mignant | 68h | 4,040 | 40 |
| 16 | 1.2.3.2 | Team Meeting #2 (CIT) |  | 1d | 2006-11-07 | 2006-11-07 |  | 400d |  | start no earlier than 2006-11-07 | Wizinowich; Dekany; Gavel; Max; Bauman; Bouchez; Velur; Flicker; Neyman; Britton; Le Mignant | 80h | 4,784 | 40 |
| 17 | 1.2.3.3 | Team Videocon #3 |  | 1d | 2006-12-13 | 2006-12-13 |  | 374d |  | start no earlier than 2006-12-13 | Wizinowich; Dekany; Gavel; Max; Bauman; Bouchez; Velur; Flicker; Neyman; Britton; Le Mignant | 80h | 4,784 | 10 |
| 18 | 1.2.3.4 | Team Meeting #4 (Keck) |  | 1d | 2007-01-22 | 2007-01-22 |  | 346d |  | start no earlier than 2007-01-22 | Wizinowich; Dekany; Gavel; Max; Bauman; Bouchez; Velur; Flicker; Neyman; Britton; Le Mignant | 80h | 4,784 | 40 |
| 19 | 1.2.3.5 | Team Videocon #5 |  | 1d | 2007-03-07 | 2007-03-07 |  | 314d |  | start no earlier than 2007-03-07 | Wizinowich; Dekany; Gavel; Max; Bauman; Bouchez; Velur; Flicker; Neyman; Britton; Le Mignant | 80h | 4,784 | 10 |
| 20 | 1.2.3.6 | Team Meeting #6 (UCSC) |  | 1d | 2007-04-18 | 2007-04-18 |  | 284d |  | start no earlier than 2007-04-18 | Wizinowich; Dekany; Gavel; Max; Bauman; Bouchez; Velur; Flicker; Neyman; Britton; Le Mignant | 80h | 4,784 | 10 |
| 21 | 1.2.3.7 | Team Videocon #7 |  | 1d | 2007-05-30 | 2007-05-30 |  | 254d |  | finish no earlier than 2007-05-30 | Wizinowich; Dekany; Gavel; Max; Bauman; Bouchez; Velur; Flicker; Neyman; Britton; Le Mignant | 80h | 4,784 | 10 |
| 22 | 1.2.3.8 | Team Retreat #8 (UCSC) |  | 5d | 2007-07-09 | 2007-07-13 |  | 222d |  | start no earlier than 2007-07-09 | Wizinowich; Dekany; Gavel; Max; Bauman; Bouchez; Velur; Flicker; Neyman; Britton; Le Mignant | 440h | 26,400 | 140 |
| 23 | 1.2.3.9 | Team Videocon #9 |  | 1d | 2007-08-22 | 2007-08-22 |  | 194d |  | start no earlier than 2007-08-22 | Wizinowich; Dekany; Gavel; Max; Bauman; Bouchez; Velur; Flicker; Neyman; Britton; Le Mignant | 80h | 4,784 | 10 |
| 24 | 1.2.3.10 | Team Meeting #10 (CIT) |  | 1d | 2007-09-11 | 2007-09-11 |  | 180d |  | start no earlier than 2007-09-11 | Wizinowich; Dekany; Gavel; Max; Bauman; Bouchez; Velur; Flicker; Neyman; Britton; Le Mignant | 80h | 4,784 | 40 |
| 25 | 1.2.3.11 | Team Videocon #11 |  | 1d | 2007-11-05 | 2007-11-05 |  | 141d |  | start no earlier than 2007-11-05 | Wizinowich; Dekany; Gavel; Max; Bauman; Bouchez; Velur; Flicker; Neyman; Britton; Le Mignant | 80h | 4,784 | 10 |
| 26 | 1.2.3.12 | Team Meeting #12 (Keck) |  | 1d | 2007-12-12 | 2007-12-12 |  | 114d |  | start no earlier than 2007-12-12 | Wizinowich; Dekany; Gavel; Max; Bauman; Bouchez; Velur; Flicker; Neyman; Britton; Le Mignant | 80h | 4,784 | 60 |
| 27 | 1.2.3.13 | Team Videocon #13 |  | 1d | 2008-01-09 | 2008-01-09 |  | 94d |  | start no earlier than 2008-01-09 | Wizinowich; Dekany; Gavel; Max; Bauman; Bouchez; Velur; Flicker; Neyman; Britton; Le Mignant | 80h | 4,784 | 10 |
| 28 | 1.2.3.14 | Team Meeting #14 (Keck) - SDR |  | 1d | 2008-04-04 | 2008-04-04 |  | 32d |  | start no earlier than 2008-04-04 | Wizinowich; Dekany; Gavel; Max; Bauman; Bouchez; Velur; Flicker; Neyman; Britton; Le Mignant | 88h | 5,280 | 10 |

Notes:
- 1: PW
- 2: PW
- 5: PW
- 6: SA
- 8: SA
- 9: PW
- 10: PW
- 12: PW / 1 hr per week x 4 persons for duration of SD phase is about 400 wk-hours total - RD
- 13: CM

| ID | WBS | Task | Type | Duration | Start | Finish | Predecessors | Total slack | Free slack | Constraint | Resources | Work | Cost | Text1 |
| --- | --- | --- | --- | --- | --- | --- | --- | --- | --- | --- | --- | --- | --- | --- |
| 29 | 1.3 | **Tracking and Reporting** |  | 404d? | 2006-09-16 | 2008-04-03 |  | 33d |  |  |  | 120h | 7,440 |  |
| 30 | 1.3.1 | Report Preparation/Presentation |  | 312.5d? | 2006-10-02 | 2007-12-12 |  | 114.5d |  | start no earlier than 2006-10-02 | Wizinowich [2%]; Dekany [2%]; Gavel [2%]; Max [2%] | 120h | 7,440 |  |
| 31 | 1.3.2 | Keck Science Meeting 06 (UCI) | milestone | 0d | 2006-09-16 | 2006-09-16 |  | 437d |  | finish no earlier than 2006-09-16 |  |  |  |  |
| 32 | 1.3.3 | SSC meeting (UCLA) | milestone | 0d | 2006-11-06 | 2006-11-06 |  | 402d |  | start no earlier than 2006-11-06 |  |  |  |  |
| 33 | 1.3.4 | SSC meeting (Keck) | milestone | 0d | 2007-01-24 | 2007-01-24 |  | 345d |  | start no earlier than 2007-01-24 |  |  |  |  |
| 34 | 1.3.5 | SSC meeting (CA) | milestone | 0d | 2007-04-03 | 2007-04-03 |  | 296d |  | start no earlier than 2007-04-03 |  |  |  |  |
| 35 | 1.3.6 | SSC meeting (Keck) | milestone | 0d | 2007-06-20 | 2007-06-20 |  | 240d |  | start no earlier than 2007-06-20 |  |  |  |  |
| 36 | 1.3.7 | Keck Science Meeting 07 | milestone | 0d | 2007-09-22 | 2007-09-22 |  | 172d |  | finish no earlier than 2007-09-22 |  |  |  |  |
| 37 | 1.3.8 | SSC meeting (CA) | milestone | 0d | 2007-11-06 | 2007-11-06 |  | 141d |  | start no earlier than 2007-11-06 |  |  |  |  |
| 38 | 1.3.9 | SSC meeting (Keck) | milestone | 0d | 2008-01-24 | 2008-01-24 |  | 84d |  | start no earlier than 2008-01-24 |  |  |  |  |
| 39 | 1.3.10 | SSC meeting (CA) | milestone | 0d | 2008-04-03 | 2008-04-03 |  | 33d |  | finish no earlier than 2008-04-03 |  |  |  |  |
| 40 | 1.4 | **Proposals and Fundraising** |  | 306d? | 2006-10-27 | 2007-12-31 |  | 101d |  |  |  | 160h | 9,920 | change name |
| 41 | 1.4.1 | Dates & deliverables identified by Directors | milestone | 0d | 2006-10-27 | 2006-10-27 | 7FS+3w | 146d | 45d |  |  |  |  |  |
| 42 | 1.4.2 | Support Advancement Office |  | 261d? | 2007-01-01 | 2007-12-31 | 41 | 101d |  | start no earlier than 2007-01-01 | Wizinowich [2.9%]; Max [3.8%]; Gavel [0.5%]; Dekany [0.5%] | 160h | 9,920 |  |
| 43 | 1.5 | **System Design Report & Review** |  | 142d? | 2007-09-17 | 2008-04-01 |  | 35d |  |  |  | 473h | 28,287.41 |  |
| 44 | 1.5.1 | System Design Report |  | 8d? | 2008-02-11 | 2008-02-20 | 324, 303, 134 | 35d | 0d |  | Wizinowich [31.2%]; Gavel [7.8%]; Dekany [7.8%]; Adkins [7.8%]; Max [7.8%] | 40h | 2,480 | change constraint |
| 45 | 1.5.2 | **System Design Review** |  | 142d? | 2007-09-17 | 2008-04-01 |  | 35d |  |  |  | 433h | 25,807.41 | change name |
| 46 | 1.5.2.1 | Identify Reviewers |  | 65d? | 2007-09-17 | 2007-12-14 |  | 83d | 39d | start no earlier than 2007-09-17 | Adkins [1.9%]; Wizinowich [0.4%]; Max [0.2%]; Gavel [0.2%]; Dekany [0.2%] | 15h | 930 | start earlier |
| 47 | 1.5.2.2 | Review Package Distributed |  | 1d | 2008-02-21 | 2008-02-21 | 44, 46 | 35d | 0d | start no earlier than 2008-01-14 | Adkins | 8h | 496 | 0hr, asgn adkins |
| 48 | 1.5.2.3 | Reviewer Comments Addressed |  | 5d? | 2008-03-07 | 2008-03-13 | 47FS+10d | 35d | 0d | finish no earlier than 2008-02-01 | Wizinowich [75%]; Dekany [60%]; Gavel [60%]; Max [65%]; Adkins [40%] | 120h | 7,440 | changed name |
| 49 | 1.5.2.4 | System Design Review Prep |  | 8.41d? | 2008-02-21 | 2008-03-04 | 44 | 42.59d | 7.59d | start no earlier than 2007-01-16 | Wizinowich [34%]; Dekany [35%]; Gavel [35%]; Max [35%]; Bauman [35%]; Bouchez [12.5%]; Velur [60%]; Flicker; Neyman [83%]; Britton [40%]; Le Mignant [10%] | 250h | 14,461.41 | changed name |
| 50 | 1.5.2.5 | System Design Review Meeting | milestone | 0d | 2008-03-13 | 2008-03-13 | 49, 48 | 35d | 0d | start no earlier than 2008-02-06 |  |  |  | already in line 28… |
| 51 | 1.5.2.6 | Reviewer Report Received | milestone | 0d | 2008-03-27 | 2008-03-27 | 50FS+10d | 35d | 0d | start no earlier than 2008-02-15 |  |  |  |  |
| 52 | 1.5.2.7 | Response to Reviewer Report & Distribution |  | 3d? | 2008-03-28 | 2008-04-01 | 51 | 35d |  | start no earlier than 2008-02-18 | Wizinowich [41.7%]; Dekany [33.3%]; Gavel [33.3%]; Max [41.7%]; Adkins [16.7%] | 40h | 2,480 |  |

Notes:
- 29: PW
- 30: PW
- 43: SA
- 44: PW

| ID | WBS | Task | Duration | Start | Finish | Total slack | Constraint | Work | Cost | Text1 |
| --- | --- | --- | --- | --- | --- | --- | --- | --- | --- | --- |
| 53 | 2 | **System Requirements** | 305d? | 2006-09-18 | 2007-11-16 | 105d |  | 3534h | 33,820 | suggest CN |
| 54 | 2.1 | **Science Requirements** | 281d? | 2006-09-18 | 2007-10-15 | 156d |  | 3090h | 9,920 |  |
| 55 | 2.1.1 | **Solar System Science Requirements** | 135d? | 2006-10-02 | 2007-04-06 | 292d |  | 650h |  | ch name |
| 56 | 2.1.1.1 | **Companions & Multiplicity of Small Solar System Bodies** | 75d? | 2006-10-02 | 2007-01-12 | 352d |  | 250h |  |  |
| 57 | 2.1.1.1.1 | Point Source Companion Sensitivity Requirements | 45d? | 2006-10-02 | 2006-12-01 | 382d | finish no earlier than 2006-12-01 | 100h |  |  |
| 58 | 2.1.1.1.2 | Spectral Sensitivity & Spectral Resolution Requirements | 45d? | 2006-10-02 | 2006-12-01 | 382d | finish no earlier than 2006-12-01 | 100h |  |  |
| 59 | 2.1.1.1.3 | Observing Scenarios | 30d? | 2006-12-04 | 2007-01-12 | 352d | finish no earlier than 2007-01-12 | 25h |  |  |
| 60 | 2.1.1.1.4 | Science Instrument Requirements | 30d? | 2006-12-04 | 2007-01-12 | 352d | start no earlier than 2006-12-04 | 25h |  |  |
| 61 | 2.1.1.2 | **Moons of the Giant Planets** | 70d? | 2006-12-04 | 2007-03-09 | 312d |  | 150h |  |  |
| 62 | 2.1.1.2.1 | Performance Requirements | 40d? | 2006-12-04 | 2007-01-26 | 342d | start no earlier than 2006-12-04 | 100h |  |  |
| 63 | 2.1.1.2.2 | Observing Scenarios | 30d? | 2007-01-29 | 2007-03-09 | 312d | finish no earlier than 2007-03-09 | 25h |  |  |
| 64 | 2.1.1.2.3 | Science Instrument Requirements | 30d? | 2007-01-29 | 2007-03-09 | 312d | start no earlier than 2007-01-29 | 25h |  |  |
| 65 | 2.1.1.3 | **Shape & Size of Asteroids** | 50d? | 2007-01-29 | 2007-04-06 | 292d |  | 250h |  |  |
| 66 | 2.1.1.3.1 | Spatial Resolution Requirements | 25d? | 2007-01-29 | 2007-03-02 | 317d | start no earlier than 2007-01-29 | 100h |  |  |
| 67 | 2.1.1.3.2 | Spectral Sensitivity & Spectral Resolution Requirements | 25d? | 2007-01-29 | 2007-03-02 | 317d | start no earlier than 2007-01-29 | 100h |  |  |
| 68 | 2.1.1.3.3 | Observing Scenarios | 25d? | 2007-03-05 | 2007-04-06 | 292d | finish no earlier than 2007-04-06 | 25h |  |  |
| 69 | 2.1.1.3.4 | Science Instrument Requirements | 25d? | 2007-03-05 | 2007-04-06 | 292d | start no earlier than 2007-03-05 | 25h |  |  |
| 70 | 2.1.2 | **Galactic Science Requirements** | 145d? | 2006-09-18 | 2007-04-06 | 292d |  | 1200h |  | ch name |
| 71 | 2.1.2.1 | **Galactic Center Proper Motions: Astrometry** | 85d? | 2006-09-18 | 2007-01-12 | 352d |  | 200h |  |  |
| 72 | 2.1.2.1.1 | Astrometry requirements | 50d? | 2006-09-18 | 2006-11-24 | 387d | finish no earlier than 2006-11-24 | 150h |  |  |
| 73 | 2.1.2.1.2 | Observing Scenarios | 35d? | 2006-11-27 | 2007-01-12 | 352d | finish no earlier than 2007-01-12 | 25h |  |  |
| 74 | 2.1.2.1.3 | Science Instrument Requirements | 35d? | 2006-11-27 | 2007-01-12 | 352d | start no earlier than 2006-11-27 | 25h |  |  |
| 75 | 2.1.2.2 | **Galactic Center Radial Velocities & Stellar Populations: Integral Field Spectroscopy** | 75d? | 2006-11-27 | 2007-03-09 | 312d |  | 200h |  |  |
| 76 | 2.1.2.2.1 | Performance Requirements | 45d? | 2006-11-27 | 2007-01-26 | 342d | finish no earlier than 2007-01-26 | 150h |  |  |
| 77 | 2.1.2.2.2 | Observing Scenarios | 30d? | 2007-01-29 | 2007-03-09 | 312d | start no earlier than 2007-01-29 | 25h |  |  |
| 78 | 2.1.2.2.3 | Science Instrument Requirements | 30d? | 2007-01-29 | 2007-03-09 | 312d | start no earlier than 2007-01-29 | 25h |  |  |

Notes:
- 53: CN
- 54: CM
- 55: FM
- 70: ML
- 71: AG
- 75: AG

| ID | WBS | Task | Duration | Start | Finish | Total slack | Constraint | Work | Text1 |
| --- | --- | --- | --- | --- | --- | --- | --- | --- | --- |
| 79 | 2.1.2.3 | **Galactic Center Nature of Sgr A*: 3-5 um Color & 2 um Polarimetry Variability** | 50d? | 2007-01-29 | 2007-04-06 | 292d |  | 200h |  |
| 80 | 2.1.2.3.1 | Performance Requirements | 25d? | 2007-01-29 | 2007-03-02 | 317d | finish no earlier than 2007-03-02 | 150h |  |
| 81 | 2.1.2.3.2 | Observing Scenarios | 25d? | 2007-03-05 | 2007-04-06 | 292d | start no earlier than 2007-03-05 | 25h |  |
| 82 | 2.1.2.3.3 | Science Instrument Requirements | 25d? | 2007-03-05 | 2007-04-06 | 292d | finish no earlier than 2007-04-06 | 25h |  |
| 83 | 2.1.2.4 | **Planets around Low Mass Stars & Brown Dwarfs: Companion Sensitivity** | 85d? | 2006-09-18 | 2007-01-12 | 352d |  | 200h |  |
| 84 | 2.1.2.4.1 | Companion Sensitivity Performance Requirements | 50d? | 2006-09-18 | 2006-11-24 | 387d | finish no earlier than 2006-11-24 | 150h |  |
| 85 | 2.1.2.4.2 | Observing Scenarios | 35d? | 2006-11-27 | 2007-01-12 | 352d | start no earlier than 2006-11-27 | 25h |  |
| 86 | 2.1.2.4.3 | Science Instrument Requirements | 35d? | 2006-11-27 | 2007-01-12 | 352d | start no earlier than 2006-11-27 | 25h |  |
| 87 | 2.1.2.5 | **Debris Disks, Protostellar Envelopes & Outflows: Contrast** | 50d? | 2007-01-29 | 2007-04-06 | 292d |  | 200h |  |
| 88 | 2.1.2.5.1 | Contrast Performance Requirements | 25d? | 2007-01-29 | 2007-03-02 | 317d | finish no earlier than 2007-03-02 | 150h |  |
| 89 | 2.1.2.5.2 | Observing Scenarios | 25d? | 2007-03-05 | 2007-04-06 | 292d | start no earlier than 2007-03-05 | 25h |  |
| 90 | 2.1.2.5.3 | Science Instrument Requirements | 25d? | 2007-03-05 | 2007-04-06 | 292d | start no earlier than 2007-03-05 | 25h |  |
| 91 | 2.1.2.6 | **Debris Disks, Protostellar Envelopes & Outflows: Polarimetry** | 75d? | 2006-11-27 | 2007-03-09 | 312d |  | 200h |  |
| 92 | 2.1.2.6.1 | Polarimetry Performance Requirements | 45d? | 2006-11-27 | 2007-01-26 | 342d | finish no earlier than 2007-01-26 | 150h |  |
| 93 | 2.1.2.6.2 | Observing Scenarios | 30d? | 2007-01-29 | 2007-03-09 | 312d | start no earlier than 2007-01-29 | 25h |  |
| 94 | 2.1.2.6.3 | Science Instrument Requirements | 30d? | 2007-01-29 | 2007-03-09 | 312d | start no earlier than 2007-01-29 | 25h |  |
| 95 | 2.1.3 | **Extragalactic Science Requirements** | 160d? | 2006-09-18 | 2007-04-27 | 277d |  | 1000h | ch name |
| 96 | 2.1.3.1 | **Resolved Stellar Populations in Crowded Fields** | 100d? | 2006-09-18 | 2007-02-02 | 337d |  | 300h |  |
| 97 | 2.1.3.1.1 | Performance Requirements | 60d? | 2006-09-18 | 2006-12-08 | 377d | finish no earlier than 2006-12-08 | 250h |  |
| 98 | 2.1.3.1.2 | Observing Scenarios | 40d? | 2006-12-11 | 2007-02-02 | 337d | finish no earlier than 2007-02-02 | 25h |  |
| 99 | 2.1.3.1.3 | Science Instrument Requirements | 40d? | 2006-12-11 | 2007-02-02 | 337d | start no earlier than 2006-12-11 | 25h |  |
| 100 | 2.1.3.2 | **High Redshift Galaxies** | 100d? | 2006-09-18 | 2007-02-02 | 337d |  | 300h |  |
| 101 | 2.1.3.2.1 | Encircled Energy (& d-IFU) Performance Requirements | 60d? | 2006-09-18 | 2006-12-08 | 377d | finish no earlier than 2006-12-08 | 200h |  |
| 102 | 2.1.3.2.2 | Observing Scenarios | 40d? | 2006-12-11 | 2007-02-02 | 337d | start no earlier than 2006-12-11 | 50h |  |
| 103 | 2.1.3.2.3 | Science Instrument Requirements | 40d? | 2006-12-11 | 2007-02-02 | 337d | start no earlier than 2006-12-11 | 50h |  |

Notes:
- 79: AG
- 83: ML
- 87: LH
- 95: CM

| ID | WBS | Task | Duration | Start | Finish | Predecessors | Total slack | Free slack | Constraint | Resources | Work | Cost | Text1 |
| --- | --- | --- | --- | --- | --- | --- | --- | --- | --- | --- | --- | --- | --- |
| 104 | 2.1.3.3 | **Nearby Galaxies** | 100d? | 2006-12-11 | 2007-04-27 |  | 277d |  |  |  | 200h |  |  |
| 105 | 2.1.3.3.1 | Encircled Energy & PSF Performance Requirements | 60d? | 2006-12-11 | 2007-03-02 |  | 317d |  | finish no earlier than 2007-03-02 |  | 150h |  |  |
| 106 | 2.1.3.3.2 | Observing Scenarios | 40d? | 2007-03-05 | 2007-04-27 |  | 277d |  | finish no earlier than 2007-04-27 |  | 25h |  |  |
| 107 | 2.1.3.3.3 | Science Instrument Requirements | 40d? | 2007-03-05 | 2007-04-27 |  | 277d |  | start no earlier than 2007-03-05 |  | 25h |  |  |
| 108 | 2.1.3.4 | **Gravitational Lensing** | 100d? | 2006-12-11 | 2007-04-27 |  | 277d |  |  |  | 200h |  |  |
| 109 | 2.1.3.4.1 | Encircled Energy & PSF Performance Requirements | 60d? | 2006-12-11 | 2007-03-02 |  | 317d |  | start no earlier than 2006-12-11 |  | 150h |  |  |
| 110 | 2.1.3.4.2 | Observing Scenarios | 40d? | 2007-03-05 | 2007-04-27 |  | 277d |  | start no earlier than 2007-03-05 |  | 25h |  |  |
| 111 | 2.1.3.4.3 | Science Instrument Requirements | 40d? | 2007-03-05 | 2007-04-27 |  | 277d |  | start no earlier than 2007-03-05 |  | 25h |  |  |
| 112 | 2.1.4 | **Science Requirements Summary** | 271d? | 2006-10-02 | 2007-10-15 |  | 146d |  |  |  | 240h | 9,920 |  |
| 113 | 2.1.4.1 | Science Requirements Summary Rev 1 | 14d? | 2006-10-02 | 2006-10-19 |  | 403d | 66d | finish no earlier than 2006-10-19 | Max [17.9%]; Wizinowich [17.9%] | 40h | 2,480 | ch name, ch date |
| 114 | 2.1.4.2 | Science Requirements Summary Rev 2 | 13.89d? | 2007-02-13 | 2007-03-02 |  | 307d | 25d | finish no earlier than 2007-03-02 | Max [18%]; Wizinowich [18%]; Other | 120h | 2,480 | ch name |
| 115 | 2.1.4.3 | Science Requirements Summary Rev 3 | 13.89d? | 2007-06-05 | 2007-06-22 |  | 227d | 15d | finish no earlier than 2007-06-22 | Max [18%]; Wizinowich [18%] | 40h | 2,480 | ch name |
| 116 | 2.1.4.4 | Science Requirements Summary Final | 13.89d? | 2007-09-26 | 2007-10-15 |  | 109d | 65d | finish no earlier than 2007-10-15 | Max [18%]; Wizinowich [18%] | 40h | 2,480 | ch name |
| 117 | 2.2 | **Observatory Requirements** | 285d? | 2006-10-02 | 2007-11-02 |  | 95d |  |  |  | 234h | 11,408 |  |
| 118 | 2.2.1 | Development Requirements | 40d? | 2006-10-02 | 2006-11-24 |  | 135d | 40d | start no earlier than 2006-10-02 | Neyman [2.5%]; Wizinowich [2.5%] | 16h | 992 |  |
| 119 | 2.2.2 | Observatory Interface Requirements | 20d? | 2006-10-02 | 2006-10-27 |  | 155d | 60d | start no earlier than 2006-10-02 | Neyman [5%]; Wizinowich [5%]; Adkins [5%] | 24h | 1,488 | 16hr, added adkins |
| 120 | 2.2.3 | Science Operations Requirements | 80d? | 2006-10-02 | 2007-01-19 |  | 95d | 0d | start no earlier than 2006-10-02 | Le Mignant [5%]; Wizinowich [5%]; Bouchez [5%] | 64h | 3,968 | 16 hrs, incr + added Bouchez |
| 121 | 2.2.4 | Observatory Requirements Rev 2 | 15d? | 2007-03-19 | 2007-04-06 | 118FS+8w, 119FS+8w, 120FS+8w | 95d | 0d |  | Neyman [20%]; Other [41.7%]; Le Mignant [13.3%] | 90h | 2,480 | ch name, ch constraint |
| 122 | 2.2.5 | Observatory Requirements Rev 3 | 30d? | 2007-06-04 | 2007-07-13 | 121FS+8w | 95d | 0d |  | Neyman [8.3%] | 20h | 1,240 | ch name, ch constraint |
| 123 | 2.2.6 | Observatory Requirements Rev 4 | 40d? | 2007-09-10 | 2007-11-02 | 122FS+8w | 95d | 51d |  | Neyman [6.2%] | 20h | 1,240 | 10, ch name, ch constraint |
| 124 | 2.3 | **System Requirements Document** | 290d? | 2006-10-09 | 2007-11-16 |  | 132d |  |  |  | 210h | 12,492 |  |
| 125 | 2.3.1 | **Tracability Matrix** | 270d? | 2006-10-09 | 2007-10-20 |  | 142d |  |  |  | 130h | 7,532 | ch name |
| 126 | 2.3.1.1 | Tracability Matrix Rev 1 | 10d? | 2006-10-09 | 2006-10-20 |  | 402d | 65d | finish no earlier than 2006-10-20 | Neyman [12.5%] | 10h | 620 | ch name, 0hr |
| 127 | 2.3.1.2 | Tracability Matrix Rev 2 | 12d? | 2007-02-12 | 2007-02-27 |  | 310d | 28d | start no earlier than 2007-02-12 | Neyman [25%]; Wizinowich [25%]; Adkins [25%]; Flicker [25%] | 80h | 4,432 | ch name, 0hr |
| 128 | 2.3.1.3 | Tracability Matrix Rev 3 | 10d? | 2007-06-15 | 2007-06-28 |  | 223d | 11d | finish no earlier than 2007-06-28 | Neyman [25%] | 20h | 1,240 | ch name, 0hr |
| 129 | 2.3.1.4 | Tracability Matrix Rev 4 | 9d? | 2007-10-09 | 2007-10-20 |  | 105d | 61d | finish no earlier than 2007-10-20 | Neyman [27.8%] | 20h | 1,240 | ch name, 0hr |

Notes:
- 112: CM
- 117: CN
- 118: CN
- 119: CN
- 120: DLM
- 121: CN
- 122: CN
- 123: CN
- 125: CN

| ID | WBS | Task | Duration | Start | Finish | Predecessors | Total slack | Free slack | Constraint | Resources | Work | Cost | Text1 |
| --- | --- | --- | --- | --- | --- | --- | --- | --- | --- | --- | --- | --- | --- |
| 130 | 2.3.2 | **System Requirements Document** | 215d | 2007-01-22 | 2007-11-16 |  | 132d |  |  |  | 80h | 4,960 |  |
| 131 | 2.3.2.1 | SRD Rev 1 | 10d | 2007-01-22 | 2007-02-02 | 113, 126, 118, 119, 120 | 337d |  | start no earlier than 2006-10-27 | Neyman [25%] | 20h | 1,240 | ch name |
| 132 | 2.3.2.2 | SRD Rev 2 | 10d | 2007-04-09 | 2007-04-20 | 114, 127, 121 | 282d |  | start no earlier than 2007-03-09 | Neyman [25%] | 20h | 1,240 | ch name |
| 133 | 2.3.2.3 | SRD Rev 3 | 10d | 2007-07-16 | 2007-07-27 | 115, 128, 122 | 212d |  | start no earlier than 2007-06-29 | Neyman [25%] | 20h | 1,240 | ch name |
| 134 | 2.3.2.4 | SRD Final SD Phase Version | 10d | 2007-11-05 | 2007-11-16 | 116, 129, 123 | 95d | 45d |  | Neyman [25%] | 20h | 1,240 | ch name |
| 135 | 3 | **System Design** | 390d? | 2006-08-14 | 2008-02-08 |  | 72d |  |  |  | 10226h | 402,594 | suggest PW |
| 136 | 3.1 | **Systems Engineering** | 365d? | 2006-08-14 | 2008-01-04 |  | 97d |  |  |  | 5646h | 257,502 | suggest RD |
| 137 | 3.1.1 | **Performance Budgets** | 292d? | 2006-08-14 | 2007-09-25 |  | 170d |  |  |  | 2486h | 109,770 |  |
| 138 | 3.1.1.1 | **Model Assumptions** | 230d? | 2006-08-14 | 2007-06-29 |  | 217d |  |  |  | 260h | 13,040 |  |
| 139 | 3.1.1.1.1 | **TMT site monitoring data mining** | 230d? | 2006-08-14 | 2007-06-29 |  | 232d |  |  |  | 80h | 3,200 |  |
| 140 | 3.1.1.1.1.1 | Tools in place & 1st release | 24d? | 2006-08-14 | 2006-09-14 |  | 233d | 1d | finish no earlier than 2006-09-14 | Flicker [20.8%] | 40h | 1,600 |  |
| 141 | 3.1.1.1.1.2 | Release updated data (every two months) | 205d? | 2006-09-18 | 2007-06-29 | 140 | 232d |  | finish no earlier than 2007-06-29 | Flicker [2.4%] | 40h | 1,600 |  |
| 142 | 3.1.1.1.2 | Telescope dynamic performance data | 44d? | 2006-10-02 | 2006-11-30 |  | 182d | 1d | start no earlier than 2006-10-02 | Neyman [17%]; Flicker [17%] | 120h | 6,120 |  |
| 143 | 3.1.1.1.3 | Telescope static wavefront errors | 44d? | 2006-10-02 | 2006-11-30 |  | 182d | 1d | finish no earlier than 2006-11-30 | Neyman [5.7%] | 20h | 1,240 |  |
| 144 | 3.1.1.1.4 | Sodium return vs laser format | 22d? | 2006-11-01 | 2006-11-30 |  | 195d | 18d | start no earlier than 2006-11-01 | Gavel [11.4%]; Neyman [11.4%] | 40h | 2,480 |  |
| 145 | 3.1.1.2 | **Model/Tool Validation** | 90d? | 2006-08-14 | 2006-12-15 |  | 184d | 7d |  |  | 334h | 9,006 |  |
| 146 | 3.1.1.2.1 | Agreement between Tomography Codes | 35d? | 2006-08-14 | 2006-09-29 |  | 239d |  | start no earlier than 2006-08-14 | Flicker [5.4%]; Gavel [3.6%]; Neyman [5.4%] | 40h | 2,150 |  |
| 147 | 3.1.1.2.2 | Agreement between Sky Coverage Codes | 23d? | 2006-09-18 | 2006-10-18 |  | 226d |  | start no earlier than 2006-09-18 | Dekany [6.5%]; Gavel [6.5%]; Clare [8.7%] | 40h | 2,128 |  |
| 148 | 3.1.1.2.3 | Anchor to Keck II LGS AO PSFs | 21d? | 2006-10-02 | 2006-10-30 |  | 218d |  | finish no earlier than 2006-10-30 | Neyman [23.8%] | 40h | 2,480 |  |
| 149 | 3.1.1.2.4 | Anchor to On-sky MGSU Experiments | 3.67d? | 2006-11-10 | 2006-11-15 |  | 206d |  | finish no earlier than 2006-11-15 | Flicker [34.1%] | 10h | 400 | incr or eliminate? |
| 150 | 3.1.1.2.5 | Anchor to LAO Lab Experiments | 30d? | 2006-11-06 | 2006-12-15 |  | 184d |  | start no earlier than 2006-11-06 | Gavel [1.7%]; Flicker [16.7%]; Kupke [33.3%]; Ammons [33.3%] | 204h | 1,848 | needs basis -> |
| 151 | 3.1.1.3 | Throughput | 80d? | 2006-09-11 | 2006-12-29 |  | 205d | 55d | finish no earlier than 2006-12-29 | Bouchez [5%] | 32h | 1,984 | 40, postponed |
| 152 | 3.1.1.4 | **Background** | 71.5d? | 2006-10-02 | 2007-01-09 |  | 198.5d | 48.5d |  |  | 50h | 3,100 |  |
| 153 | 3.1.1.4.1 | Document Proposal Analysis | 9d? | 2006-10-02 | 2006-10-12 |  | 261d |  | start no earlier than 2006-10-02 | Bouchez [13.9%] | 10h | 620 |  |
| 154 | 3.1.1.4.2 | Develop Background Performance Budget | 62.5d? | 2006-10-02 | 2007-01-09 |  | 198.5d |  | start no earlier than 2006-10-02 | Bouchez [8%] | 40h | 2,480 |  |

Notes:
- 135: PW
- 136: RD
- 137: RD
- 138: CN
- 139: RF
- 140: RF
- 141: RF
- 142: CN
- 143: CN
- 144: DG
- 145: CN
- 146: DG
- 147: RD
- 148: CN
- 149: RF
- 150: DG
- 151: AB
- 152: AB
- 153: AB
- 154: AB

| ID | WBS | Task | Duration | Start | Finish | Predecessors | Total slack | Free slack | Constraint | Resources | Work | Cost | Text1 |
| --- | --- | --- | --- | --- | --- | --- | --- | --- | --- | --- | --- | --- | --- |
| 155 | 3.1.1.5 | **Wavefront Error vs Sky Coverage** | 87d? | 2006-10-02 | 2007-01-30 |  | 177d | 0d |  |  | 110h | 6,160 |  |
| 156 | 3.1.1.5.1 | Document WFE Budget Rev 1 | 50d? | 2006-10-02 | 2006-12-08 |  | 214d |  | start no earlier than 2006-10-02 | Dekany [10%] | 40h | 2,480 | ch name, ch units |
| 157 | 3.1.1.5.2 | Document WFE Budget Rev 2 | 25d? | 2006-12-27 | 2007-01-30 | 140, 144, 145, 184 | 177d |  | finish no earlier than 2007-01-30 | Dekany [20%]; Flicker [17%] | 70h | 3,680 | ch name, ch units |
| 158 | 3.1.1.6 | Encircled Energy vs Sky Coverage | 50d? | 2006-10-23 | 2006-12-29 |  | 199d | 22d | start no earlier than 2006-10-23 | Dekany [17.5%]; Gavel [17.5%] | 110h | 6,820 | ch task type |
| 159 | 3.1.1.7 | Photometric Accuracy | 75d? | 2006-10-16 | 2007-01-26 |  | 179d | 2d | start no earlier than 2006-10-16 | Britton [20%]; Neyman [10%]; Flicker [10%] | 240h | 13,560 |  |
| 160 | 3.1.1.8 | Astrometric Accuracy | 55d? | 2006-11-13 | 2007-01-26 |  | 185d | 35d | start no earlier than 2006-11-13 | Neyman [9.1%]; Britton [13.6%]; Flicker [9.1%]; Cameron [13.6%]; Wizinowich [9.1%] | 240h | 10,280 |  |
| 161 | 3.1.1.9 | Polarimetric Accuracy | 25d? | 2007-02-05 | 2007-03-09 |  | 155d | 5d | start no earlier than 2007-02-05 | Ireland [20%] | 40h | 1,600 |  |
| 162 | 3.1.1.10 | Companion Sensitivity | 55d? | 2006-11-13 | 2007-01-26 |  | 179d | 2d | start no earlier than 2006-11-13 | Macintosh [18.2%]; Neyman [18.2%]; Other [18.2%]; Flicker [18.2%] | 320h | 13,120 |  |
| 163 | 3.1.1.11 | Observing Efficiency | 30d? | 2007-02-05 | 2007-03-16 |  | 150d | 0d | start no earlier than 2007-02-05 | Le Mignant [8.3%]; Other [58.3%] | 160h | 1,240 |  |
| 164 | 3.1.1.12 | Observing Uptime | 30d? | 2007-02-05 | 2007-03-16 |  | 150d | 0d | start no earlier than 2007-02-05 | Chin [16.7%]; Johansson [16.7%] | 80h | 4,960 |  |
| 165 | 3.1.1.13 | **Performance Budgets Summary** | 58d? | 2007-01-31 | 2007-04-20 |  | 150d |  |  |  | 160h | 9,920 |  |
| 166 | 3.1.1.13.1 | Performance Budgets Summary Ver 1 | 20d? | 2007-01-31 | 2007-02-27 | 155, 158, 159, 162 | 177d | 0d | start no earlier than 2007-01-15 | Dekany [25%]; Neyman [37.5%] | 100h | 6,200 |  |
| 167 | 3.1.1.13.2 | Performance Budgets Summary Ver 2 | 25d? | 2007-03-19 | 2007-04-20 | 155, 158, 159, 160, 161, 162, 163, 164, 151, 152 | 150d | 25d |  | Dekany [10%]; Neyman [20%] | 60h | 3,720 |  |
| 168 | 3.1.1.14 | **Science Products** | 52d? | 2007-07-16 | 2007-09-25 |  | 170d |  |  |  | 350h | 14,980 |  |
| 169 | 3.1.1.14.1 | All-In Science Simulations | 20d? | 2007-07-16 | 2007-08-10 | 167 | 187d | 0d | start no earlier than 2007-07-16 | Neyman [50%]; Flicker [50%] | 160h | 8,160 |  |
| 170 | 3.1.1.14.2 | **Additional Science Characterization Results** | 32d? | 2007-08-13 | 2007-09-25 |  | 170d |  |  |  | 190h | 6,820 |  |
| 171 | 3.1.1.14.2.1 | Point Source Sensitivities | 18.75d? | 2007-08-13 | 2007-09-06 | 169 | 183.25d |  | start no earlier than 2007-04-02 | Bouchez [20%] | 30h | 1,860 |  |
| 172 | 3.1.1.14.2.2 | PSF Uniformity & Stability | 15d? | 2007-08-13 | 2007-08-31 | 169 | 187d |  | start no earlier than 2007-04-02 | Neyman [66.7%] | 80h | 4,960 |  |
| 173 | 3.1.1.14.2.3 | Other | 15d? | 2007-09-05 | 2007-09-25 | 169 | 170d |  | start no earlier than 2007-09-05 |  | 80h |  |  |
| 174 | 3.1.2 | **Trade Studies** | 160d? | 2006-10-16 | 2007-05-25 |  | 119.5d |  |  |  | 1900h | 90,692 | suggest RD |
| 175 | 3.1.2.1 | **System Architecture Trade Studies** | 100d? | 2006-10-16 | 2007-03-02 |  | 185d | 60d |  |  | 730h | 35,012 |  |
| 176 | 3.1.2.1.1 | MOAO & MCAO TS | 25d? | 2006-11-13 | 2006-12-15 |  | 240d |  | finish no earlier than 2006-12-15 |  | 80h |  |  |
| 177 | 3.1.2.1.2 | NGAO versus Keck AO upgrades TS (meeting 5) | 20d? | 2007-02-05 | 2007-03-02 |  | 185d |  | start no earlier than 2007-02-05 | Neyman [37.5%]; Wizinowich [25%] | 100h | 6,200 |  |
| 178 | 3.1.2.1.3 | Adaptive Secondary Mirror option TS (m5) | 20d? | 2007-02-05 | 2007-03-02 |  | 185d |  | start no earlier than 2007-02-05 | Other [15%]; Wizinowich [10%] | 40h | 992 | remove AB |
| 179 | 3.1.2.1.4 | K & L-band Science TS (m5) | 20d? | 2007-02-05 | 2007-03-02 |  | 185d |  | start no earlier than 2007-02-05 | Other [25%] | 40h |  | remove AB |
| 180 | 3.1.2.1.5 | Keck Interferometer Support TS (m5) | 100d? | 2006-10-16 | 2007-03-02 |  | 185d |  | start no earlier than 2006-10-16 | Neyman [22.5%]; Wizinowich [2.5%] | 160h | 9,920 | 200 |
| 181 | 3.1.2.1.6 | Instrument Balance TS | 20d? | 2006-11-13 | 2006-12-08 |  | 245d |  | start no earlier than 2006-11-13 | Adkins [6.2%] | 10h | 620 |  |
| 182 | 3.1.2.1.7 | GLAO for non-NGAO Instruments TS (m5) | 20d? | 2007-02-05 | 2007-03-02 |  | 185d |  | start no earlier than 2007-02-05 | Flicker [12.5%] | 20h | 800 |  |
| 183 | 3.1.2.1.8 | Science Instrument Re-use Cost/Benefit TS (m3) | 20d? | 2006-11-13 | 2006-12-08 |  | 245d |  | start no earlier than 2006-11-13 | Adkins [25%]; Moore [50%] | 120h | 7,440 |  |
| 184 | 3.1.2.1.9 | Telescope Wavefront Errors TS | 13d? | 2006-12-04 | 2006-12-20 | 142, 143 | 181d | 4d | finish no earlier than 2006-12-20 | Neyman [38.5%]; Flicker [38.5%] | 80h | 4,080 |  |
| 185 | 3.1.2.1.10 | Observing Model TS | 45d? | 2006-11-13 | 2007-01-12 |  | 220d |  | finish no earlier than 2007-01-12 | Le Mignant [22.2%] | 80h | 4,960 |  |

Notes:
- 155: RD
- 156: RD
- 157: RD
- 158: DG
- 159: MB
- 160: CN
- 161: MI
- 162: BM
- 163: DLM
- 164: JC
- 166: RD
- 167: RD
- 169: CN
- 171: AB
- 172: CN
- 174: RD
- 176: DG
- 177: PW
- 180: CN
- 181: SA
- 182: RF
- 183: SA
- 184: CN
- 185: DLM

| ID | WBS | Task | Duration | Start | Finish | Predecessors | Total slack | Free slack | Constraint | Resources | Work | Cost | Text1 |
| --- | --- | --- | --- | --- | --- | --- | --- | --- | --- | --- | --- | --- | --- |
| 186 | 3.1.2.2 | **Adaptive Optics System Trade Studies** | 150d? | 2006-10-30 | 2007-05-25 |  | 109.5d | 0d |  |  | 950h | 42,480 |  |
| 187 | 3.1.2.2.1 | AO Enclosure Temperature TS (m6) | 74d? | 2007-01-02 | 2007-04-13 |  | 155d |  | start no earlier than 2007-01-02 | Bouchez [5.1%]; Meguro [6.8%]; Other [5.1%] | 100h | 4,340 |  |
| 188 | 3.1.2.2.2 | Optical Relay TS (m6) | 74d? | 2007-01-02 | 2007-04-13 |  | 95.75d | 0d | finish no earlier than 2007-04-13 | Bauman [5.1%]; Dekany [5.1%] | 60h | 3,720 |  |
| 189 | 3.1.2.2.3 | Field Rotation Strategy TS (m6) | 74d? | 2007-01-02 | 2007-04-13 |  | 101.25d | 0d | start no earlier than 2007-01-02 | Bauman [10.1%]; Meguro [3.4%] | 80h | 4,960 |  |
| 190 | 3.1.2.2.4 | Dichroics & Beamsplitters TS (m6) | 74d? | 2007-01-02 | 2007-04-13 |  | 128.75d | 0d | start no earlier than 2007-01-02 | Velur [10.1%] | 60h | 3,720 |  |
| 191 | 3.1.2.2.5 | Rayleigh Rejection TS (m3) | 30d? | 2006-10-30 | 2006-12-08 |  | 245d |  | start no earlier than 2006-10-30 | Kellner [16.7%] | 40h |  |  |
| 192 | 3.1.2.2.6 | LGS WFS Type TS (m4) | 35d? | 2006-12-04 | 2007-01-19 |  | 112d | 60d | start no earlier than 2006-12-04 | Velur [10.7%] | 30h | 1,860 |  |
| 193 | 3.1.2.2.7 | LGS WFS number of subapertures TS (m4) | 35d? | 2006-12-04 | 2007-01-19 |  | 112d | 60d | start no earlier than 2006-12-04 | Velur [7.1%] | 20h | 1,240 |  |
| 194 | 3.1.2.2.8 | Slow WFS TS (m7) | 25d? | 2007-04-23 | 2007-05-25 |  | 52d | 0d | start no earlier than 2007-04-23 | Velur [40%] | 80h | 4,960 |  |
| 195 | 3.1.2.2.9 | LOWFS Architecture TS | 62.5d? | 2006-12-04 | 2007-02-28 |  | 84.5d | 32.5d | start no earlier than 2006-12-04 | Kellner [71.4%]; Velur [20%] | 200h | 6,200 | split with VV |
| 196 | 3.1.2.2.10 | Number & Type of LOWFS TS (m4) | 40d? | 2006-12-04 | 2007-01-26 |  | 107d | 55d | start no earlier than 2006-12-04 | Kellner [21.4%]; Velur [9.4%] | 60h | 1,860 | split with VV |
| 197 | 3.1.2.2.11 | Centroid Anisoplanatism TS (m7) | 25d? | 2007-04-23 | 2007-05-25 |  | 125d |  | start no earlier than 2007-04-23 | Kellner [20%] | 40h |  |  |
| 198 | 3.1.2.2.12 | Deformable Mirror Stroke Requirement TS (m6) | 74d? | 2007-01-02 | 2007-04-13 |  | 155d |  | start no earlier than 2007-01-02 | Flicker [8.4%] | 50h | 2,000 |  |
| 199 | 3.1.2.2.13 | Stand-alone vs DM on T/T Stage TS (m3) | 30d? | 2006-10-30 | 2006-12-08 |  | 245d |  | start no earlier than 2006-10-30 | Bauman [25%] | 60h | 3,720 |  |
| 200 | 3.1.2.2.14 | Correcting Fast T/T with DM TS | 30d? | 2006-10-30 | 2006-12-08 |  | 245d |  | finish no earlier than 2006-12-08 | Bauman [8.3%]; Flicker [8.3%] | 40h | 2,040 |  |
| 201 | 3.1.2.2.15 | Focus Compensation TS (m6) | 74d? | 2007-01-22 | 2007-05-03 |  | 141d |  | start no earlier than 2007-01-22 | Bouchez [5.1%] | 30h | 1,860 |  |
| 202 | 3.1.2.3 | **Laser Facility Trade Studies** | 101d? | 2006-10-16 | 2007-03-05 |  | 161d | 0d |  |  | 220h | 13,200 |  |
| 203 | 3.1.2.3.1 | Laser Pulse Format TS (m6) | 20d? | 2007-01-02 | 2007-01-29 |  | 161d | 0d | start no earlier than 2007-01-02 | Velur [50%] | 80h | 4,960 | 100 |
| 204 | 3.1.2.3.2 | Free Space vs Fiber TS (m7) | 25d? | 2007-01-30 | 2007-03-05 | 203 | 161d | 0d |  | Neyman [50%] | 100h | 6,200 |  |
| 205 | 3.1.2.3.3 | LGS Asterism Geometry & Size TS (m2) | 5d? | 2006-10-23 | 2006-10-27 |  | 252d | 91d | finish no earlier than 2006-10-27 | Flicker [50%] | 20h | 800 |  |
| 206 | 3.1.2.3.4 | Variable vs fixed LGS Asterism Cost/Benefit TS (m2) | 10d? | 2006-10-16 | 2006-10-27 |  | 252d |  | finish no earlier than 2006-10-27 | Velur [25%] | 20h | 1,240 | 10 |
| 207 | 3.1.3 | **System Architecture** | 223d? | 2007-02-28 | 2008-01-04 |  | 97d |  |  |  | 1260h | 57,040 | suggest RD |
| 208 | 3.1.3.1 | System Architecture Ver 1 | 36d? | 2007-02-28 | 2007-04-18 | 166 | 177d | 0d | start no earlier than 2006-11-01 | Dekany [10.4%]; Gavel [10.4%]; Wizinowich [6.9%] | 80h | 4,960 |  |
| 209 | 3.1.3.2 | System Architecture Ver 2 | 20d? | 2007-05-28 | 2007-06-22 | 167, 175, 186, 202 | 125d | 90d |  | Dekany [12.5%]; Gavel [12.5%]; Wizinowich [12.5%] | 60h | 3,720 |  |

Notes:
- 187: AB
- 188: RD
- 189: BB
- 190: VV
- 191: VV
- 192: VV
- 193: VV
- 194: VV
- 195: SK
- 196: SK
- 197: SK
- 198: RF
- 199: BB
- 200: BB
- 201: AB
- 203: VV
- 204: CN
- 205: RF
- 206: VV
- 207: RD

| ID | WBS | Task | Duration | Start | Finish | Predecessors | Total slack | Free slack | Constraint | Resources | Work | Cost | Text1 |
| --- | --- | --- | --- | --- | --- | --- | --- | --- | --- | --- | --- | --- | --- |
| 210 | 3.1.3.3 | **Functional Requirements** | 167d? | 2007-04-19 | 2007-12-07 |  | 55d | 20d |  |  | 1000h | 40,920 |  |
| 211 | 3.1.3.3.1 | AO System Functional Requirements Ver 1 | 17.25d? | 2007-04-19 | 2007-05-14 | 208 | 204.75d |  | finish no earlier than 2007-02-02 | Neyman [54.3%]; Chin [18.1%]; Stomski [18.1%]; Meguro [18.1%]; Bauman [18.1%]; Johansson [18.1%] | 200h | 12,400 |  |
| 212 | 3.1.3.3.2 | AO System Functional Requirements Ver 2 | 25d? | 2007-10-29 | 2007-11-30 | 209 | 35d | 0d | start no earlier than 2007-10-29 | Neyman [12.5%]; Chin [7.5%]; Stomski [7.5%]; Meguro [7.5%]; Bauman [7.5%]; Johansson [7.5%] | 100h | 6,200 |  |
| 213 | 3.1.3.3.3 | Laser System Functional Requirements Ver 1 | 20d? | 2007-04-19 | 2007-05-16 | 208 | 202d |  | finish no earlier than 2007-03-02 | Chin [34.4%]; Velur [34.4%]; Stomski [15.6%] | 135h | 8,370 |  |
| 214 | 3.1.3.3.4 | Laser System Functional Requirements Ver 2 | 25d? | 2007-11-05 | 2007-12-07 | 209 | 55d |  | start no earlier than 2007-11-05 | Chin [12.5%]; Velur [12.5%]; Stomski [7.5%] | 65h | 4,030 |  |
| 215 | 3.1.3.3.5 | Science Operations Functional Requirements Ver 1 | 24d? | 2007-04-19 | 2007-05-22 | 208 | 198d |  | finish no earlier than 2007-02-02 | Le Mignant [20.8%]; Other [31.2%] | 100h | 2,480 |  |
| 216 | 3.1.3.3.6 | Science Operations Functional Requirements Ver 2 | 25d? | 2007-10-29 | 2007-11-30 | 209 | 60d |  | start no earlier than 2007-10-29 | Le Mignant [20%]; Other [30%] | 100h | 2,480 |  |
| 217 | 3.1.3.3.7 | Science Instruments Functional Requirements Ver 1 | 24d? | 2007-04-19 | 2007-05-22 | 208 | 198d |  | start no earlier than 2007-01-02 | Adkins [20.8%]; Other [41.7%] | 120h | 2,480 |  |
| 218 | 3.1.3.3.8 | Science Instruments Functional Requirements Ver 2 | 25d? | 2007-10-29 | 2007-11-30 | 209 | 60d |  | start no earlier than 2007-10-29 | Adkins [20%]; Other [70%] | 180h | 2,480 |  |
| 219 | 3.1.3.4 | Technology Drivers Summary | 3.63d? | 2007-05-28 | 2007-05-31 | 208, 167, 175, 186, 202 | 191.37d | 0d |  | Neyman [82.7%]; Gavel [55.1%] | 40h | 2,480 |  |
| 220 | 3.1.3.5 | Technical Risk Analysis Ver 1 | 23d? | 2007-05-31 | 2007-07-03 | 219 | 230.37d |  | start no earlier than 2007-03-19 | Neyman [13%]; Gavel [8.7%] | 40h | 2,480 |  |
| 221 | 3.1.3.6 | Technical Risk Analysis Ver 2 | 25d? | 2007-12-03 | 2008-01-04 | 212 | 35d | 0d |  | Neyman [12%]; Gavel [8%] | 40h | 2,480 |  |
| 222 | 3.2 | **AO System** | 223d? | 2007-02-05 | 2007-12-12 |  | 52d | 17d |  |  | 1780h | 81,020 | suggest DG |
| 223 | 3.2.1 | AO System Architecture | 45d? | 2007-04-19 | 2007-06-20 | 208 | 177d |  | start no earlier than 2007-02-05 | Neyman [33.3%]; Other [35.4%] | 240h | 7,440 |  |
| 224 | 3.2.2 | AO Enclosure | 70d? | 2007-05-14 | 2007-08-17 | 227SS+4w | 135d |  |  |  | 100h |  |  |
| 225 | 3.2.3 | **Opto-mechanical** | 203d? | 2007-03-05 | 2007-12-12 |  | 52d |  |  |  | 700h | 35,220 | consider renaming? |
| 226 | 3.2.3.1 | Field Rotation | 82.5d? | 2007-04-16 | 2007-08-08 | 189 | 101.25d | 5.5d | finish no earlier than 2007-06-29 | Bauman [4.5%]; Meguro [2.3%] | 45h | 2,790 | 30 |
| 227 | 3.2.3.2 | Optical Relay | 88d? | 2007-04-16 | 2007-08-15 | 188 | 95.75d | 0d | start no earlier than 2007-03-05 | Bauman [5.7%]; Meguro [3.4%]; Dekany [2%] | 60h | 3,720 | 40 |
| 228 | 3.2.3.3 | Optical Switchyard | 55d? | 2007-04-16 | 2007-06-29 | 190 | 128.75d | 33d | finish no earlier than 2007-06-29 | Bauman [5.7%]; Meguro [5.7%] | 50h | 3,100 |  |
| 229 | 3.2.3.4 | Optical Support Structure | 41.25d? | 2007-08-16 | 2007-10-12 | 226, 227, 228 | 95.75d |  | start no earlier than 2007-04-16 | Meguro [9.1%]; Bauman [4.5%] | 45h | 2,790 | 60 |
| 230 | 3.2.3.5 | **Wavefront Sensors** | 173d? | 2007-04-16 | 2007-12-12 |  | 52d |  |  |  | 240h | 9,920 |  |
| 231 | 3.2.3.5.1 | High Order LGS Wavefront Sensors | 173d? | 2007-04-16 | 2007-12-12 | 192, 193 | 52d |  | start no earlier than 2007-04-16 | Velur [4.3%]; Meguro [1.4%] | 80h | 4,960 |  |
| 232 | 3.2.3.5.2 | High Order NGS Wavefront Sensor | 173d? | 2007-04-16 | 2007-12-12 |  | 52d |  | start no earlier than 2007-04-16 | Velur [2.2%]; Meguro [0.7%] | 40h | 2,480 |  |
| 233 | 3.2.3.5.3 | Low Order NGS Wavefront Sensors | 173d? | 2007-04-16 | 2007-12-12 | 195, 196 | 52d |  | finish no earlier than 2007-12-12 | Kellner [2.9%]; Meguro [2.9%] | 80h | 2,480 | shift to VV? |
| 234 | 3.2.3.5.4 | Calibration Wavefront Sensor | 143d? | 2007-05-28 | 2007-12-12 | 194 | 52d |  | start no earlier than 2007-04-16 | Kellner [3.5%] | 40h |  |  |

Notes:
- 211: CN
- 212: CN
- 213: JC
- 214: JC
- 215: DLM
- 216: DLM
- 217: SA
- 218: SA
- 219: DG
- 220: DG
- 221: DG
- 222: DG
- 226: BB
- 227: BB
- 228: BB
- 229: BB
- 231: VV
- 232: VV
- 233: SK
- 234: SK

| ID | WBS | Task | Duration | Start | Finish | Predecessors | Total slack | Free slack | Constraint | Resources | Work | Cost | Text1 |
| --- | --- | --- | --- | --- | --- | --- | --- | --- | --- | --- | --- | --- | --- |
| 235 | 3.2.3.6 | **Wavefront Correctors** | 85d? | 2007-03-05 | 2007-06-29 |  | 170d |  |  |  | 140h | 7,360 |  |
| 236 | 3.2.3.6.1 | Tip/Tilt Corrector | 85d? | 2007-03-05 | 2007-06-29 |  | 170d |  | start no earlier than 2007-03-05 | Flicker [2.9%] | 20h | 800 |  |
| 237 | 3.2.3.6.2 | Deformable Mirror | 85d? | 2007-03-05 | 2007-06-29 |  | 170d |  | start no earlier than 2007-03-05 | Flicker [5.9%]; Bauman [11.8%]; Dekany [15%] | 120h | 6,560 | ch work |
| 238 | 3.2.3.7 | **Acquisition Cameras** | 125d? | 2007-03-05 | 2007-08-24 |  | 130d |  |  |  | 40h | 2,480 |  |
| 239 | 3.2.3.7.1 | NGS Acquisition Camera | 125d? | 2007-03-05 | 2007-08-24 |  | 130d |  | start no earlier than 2007-03-05 | Bouchez [2%] | 20h | 1,240 | 10 |
| 240 | 3.2.3.7.2 | LGS Acquisition Camera | 125d? | 2007-03-05 | 2007-08-24 |  | 130d |  | start no earlier than 2007-03-05 | Bouchez [2%] | 20h | 1,240 | 10 |
| 241 | 3.2.3.8 | Atmospheric Dispersion Correction | 85d? | 2007-03-05 | 2007-06-29 |  | 170d |  | start no earlier than 2007-03-05 | Kellner [2.9%] | 20h |  |  |
| 242 | 3.2.3.9 | Alignment, Calibration, Diagnostics, Metrology and Monitoring | 85d? | 2007-03-05 | 2007-06-29 |  | 170d |  | finish no earlier than 2007-06-29 | Neyman [4.4%]; Flicker [4.4%] | 60h | 3,060 |  |
| 243 | 3.2.4 | **Non-real-time Control** | 125d? | 2007-05-01 | 2007-10-22 |  | 89d |  |  |  | 400h | 18,600 |  |
| 244 | 3.2.4.1 | Non-RTC Software | 51.2d? | 2007-05-17 | 2007-07-27 |  | 150d |  | finish no earlier than 2007-07-27 | Johansson [19.5%]; Stomski [19.5%]; Johnson [9.8%] | 200h | 12,400 | 250,ch name |
| 245 | 3.2.4.2 | Non-RTC Electronics | 125d? | 2007-05-01 | 2007-10-22 |  | 89d |  | start no earlier than 2007-05-01 | Chin [10%]; Other [10%] | 200h | 6,200 | 250,ch name |
| 246 | 3.2.5 | **Real-time Control** | 109.52d? | 2007-02-05 | 2007-07-06 |  | 165.48d |  |  |  | 340h | 19,760 |  |
| 247 | 3.2.5.1 | RTC Architecture Analysis and Design Study | 42.86d? | 2007-02-05 | 2007-04-04 |  | 165.48d | 0d | start no earlier than 2007-02-05 | Gavel [25%]; Johansson [20%]; Flicker [17.5%] | 180h | 9,840 | 250 |
| 248 | 3.2.5.2 | RTC Software Module Definition | 66.67d? | 2007-04-04 | 2007-07-06 | 247 | 165.48d |  |  | Johansson [15%] | 80h | 4,960 | 125 |
| 249 | 3.2.5.3 | RTC Hardware Module Definition | 66.67d? | 2007-04-04 | 2007-07-06 | 247 | 165.48d |  |  | Johansson [15%] | 80h | 4,960 | 125 |
| 250 | 3.3 | **Laser Facility** | 109d? | 2007-03-06 | 2007-08-03 |  | 145d | 110d |  |  | 750h | 27,900 | suggest VV |
| 251 | 3.3.1 | Laser System Architecture | 50d? | 2007-03-06 | 2007-05-14 | 155, 158, 202 | 161d | 0d |  | Velur [20%] | 80h | 4,960 | ch date, suggest VV,100hr |
| 252 | 3.3.2 | Laser Enclosure | 43d? | 2007-05-15 | 2007-07-12 | 251 | 161d |  |  |  | 80h |  | 100hr, ch date, suggest JB |
| 253 | 3.3.3 | Laser | 35d? | 2007-05-15 | 2007-07-02 | 251 | 169d |  | start no earlier than 2007-03-05 |  | 100h |  | ch date, suggest VV |
| 254 | 3.3.4 | **Laser Launch Facility** | 40d? | 2007-03-06 | 2007-04-30 |  | 214d |  |  |  | 300h | 11,160 |  |
| 255 | 3.3.4.1 | Laser Beam Transport | 40d? | 2007-03-06 | 2007-04-30 | 203, 204 | 214d |  |  | Neyman [10.9%]; Kellner [6.2%]; Chin [1.6%] | 60h | 2,480 |  |
| 256 | 3.3.4.2 | Laser Pointing & Diagnostics | 40d? | 2007-03-06 | 2007-04-30 | 203, 204 | 214d |  |  | Neyman [21.9%]; Kellner [21.9%]; Chin [6.2%] | 120h | 4,340 | 160 |
| 257 | 3.3.4.3 | Laser Launch Telescope | 28.12d? | 2007-03-06 | 2007-04-13 | 205, 203, 204 | 225.88d |  |  | Neyman [22.2%]; Kellner [22.2%]; Chin [11.1%] | 120h | 4,340 | 200 |
| 258 | 3.3.5 | **Laser Safety Systems** | 20d? | 2007-07-09 | 2007-08-03 |  | 145d |  |  |  | 40h | 2,480 |  |
| 259 | 3.3.5.1 | Personnel and Equipment Safety Systems | 20d? | 2007-07-09 | 2007-08-03 |  | 145d |  | start no earlier than 2007-07-09 | Chin [12.5%] | 20h | 1,240 |  |
| 260 | 3.3.5.2 | Aircraft, Satellite & Laser Traffic Control Safety Systems | 20d? | 2007-07-09 | 2007-08-03 |  | 145d |  | start no earlier than 2007-07-09 | Chin [12.5%] | 20h | 1,240 |  |

Notes:
- 236: RF
- 237: RF
- 239: AB
- 240: AB
- 241: SK
- 242: CN
- 244: EJ
- 245: JC
- 246: DG
- 247: DG
- 248: EJ
- 249: EJ
- 250: VV
- 251: VV
- 252: JB
- 253: VV
- 255: CN
- 256: CN
- 257: CN
- 259: JC
- 260: JC

| ID | WBS | Task | Duration | Start | Finish | Total slack | Free slack | Constraint | Resources | Work | Cost |
| --- | --- | --- | --- | --- | --- | --- | --- | --- | --- | --- | --- |
| 261 | 3.3.6 | **Laser System Control** | 85d? | 2007-04-09 | 2007-08-03 | 145d |  |  |  | 150h | 9,300 |
| 262 | 3.3.6.1 | Laser System Software | 85d? | 2007-04-09 | 2007-08-03 | 145d |  | start no earlier than 2007-04-09 | Johansson [5.9%]; Stomski [5.9%] | 80h | 4,960 |
| 263 | 3.3.6.2 | Laser System Electronics | 85d? | 2007-04-09 | 2007-08-03 | 145d |  | start no earlier than 2007-04-09 | Chin [10.3%] | 70h | 4,340 |
| 264 | 3.4 | **Science Operations** | 154d? | 2007-01-02 | 2007-08-03 | 145d | 110d |  |  | 670h | 7,900 |
| 265 | 3.4.1 | **Astronomical Observations Operations** | 108d? | 2007-03-01 | 2007-07-30 | 149d |  |  |  | 220h |  |
| 266 | 3.4.1.1 | **Pre-Observing Interfaces** | 22d? | 2007-05-01 | 2007-05-30 | 192d |  |  |  | 60h |  |
| 267 | 3.4.1.1.1 | AO Guide Star Interface | 22d? | 2007-05-01 | 2007-05-30 | 192d |  | finish no earlier than 2007-05-30 |  | 20h |  |
| 268 | 3.4.1.1.2 | Science Observations Simulation Tools | 22d? | 2007-05-01 | 2007-05-30 | 192d |  | start no earlier than 2007-05-01 |  | 40h |  |
| 269 | 3.4.1.2 | **Observing Interfaces** | 43d? | 2007-03-01 | 2007-04-30 | 214d |  |  |  | 80h |  |
| 270 | 3.4.1.2.1 | Acquisition | 43d? | 2007-03-01 | 2007-04-30 | 214d |  | finish no earlier than 2007-04-30 |  | 20h |  |
| 271 | 3.4.1.2.2 | Observing Sequences | 43d? | 2007-03-01 | 2007-04-30 | 214d |  | start no earlier than 2007-03-01 |  | 20h |  |
| 272 | 3.4.1.2.3 | Instrument, AO & Telescope Observer Interfaces | 43d? | 2007-03-01 | 2007-04-30 | 214d |  | start no earlier than 2007-03-01 |  | 20h |  |
| 273 | 3.4.1.2.4 | Science Data Quality Monitoring | 43d? | 2007-03-01 | 2007-04-30 | 214d |  | start no earlier than 2007-03-01 |  | 20h |  |
| 274 | 3.4.1.3 | **Post-Observing Interfaces** | 42d? | 2007-06-01 | 2007-07-30 | 149d |  |  |  | 80h |  |
| 275 | 3.4.1.3.1 | Generic Data Products | 42d? | 2007-06-01 | 2007-07-30 | 149d |  | finish no earlier than 2007-07-30 |  | 20h |  |
| 276 | 3.4.1.3.2 | Science Data Quality Assessment | 42d? | 2007-06-01 | 2007-07-30 | 149d |  | start no earlier than 2007-06-01 |  | 20h |  |
| 277 | 3.4.1.3.3 | Science Data Archiving | 42d? | 2007-06-01 | 2007-07-30 | 149d |  | start no earlier than 2007-06-01 |  | 40h |  |
| 278 | 3.4.2 | **AO-Instrument Operations** | 154d? | 2007-01-02 | 2007-08-03 | 145d |  |  |  | 450h | 7,900 |
| 279 | 3.4.2.1 | **AO-Instrument Operations Architecture** | 154d? | 2007-01-02 | 2007-08-03 | 145d |  |  |  | 270h | 3,100 |
| 280 | 3.4.2.1.1 | AO-Instrument Observing Modes | 24d? | 2007-01-02 | 2007-02-02 | 275d |  | start no earlier than 2007-01-02 | Le Mignant [20.8%]; Other [20.8%] | 80h | 2,480 |
| 281 | 3.4.2.1.2 | AO-Instrument Operations Support | 83d? | 2007-02-05 | 2007-05-30 | 192d |  | finish no earlier than 2007-05-30 |  | 20h |  |
| 282 | 3.4.2.1.3 | AO-Instrument Configuration & Setup | 83d? | 2007-02-05 | 2007-05-30 | 192d |  | start no earlier than 2007-02-05 |  | 20h |  |
| 283 | 3.4.2.1.4 | AO-Instrument Calibrations | 83d? | 2007-02-05 | 2007-05-30 | 192d |  | start no earlier than 2007-02-05 |  | 20h |  |
| 284 | 3.4.2.1.5 | AO-Instrument Nighttime Operation Modes | 83d? | 2007-02-05 | 2007-05-30 | 192d |  | start no earlier than 2007-02-05 |  | 20h |  |
| 285 | 3.4.2.1.6 | AO-Instrument Science Acquisition & Control | 83d? | 2007-02-05 | 2007-05-30 | 192d |  | start no earlier than 2007-02-05 |  | 20h |  |
| 286 | 3.4.2.1.7 | AO-Instrument Health Monitoring & Automated Recovery | 83d? | 2007-02-05 | 2007-05-30 | 192d |  | start no earlier than 2007-02-05 |  | 20h |  |
| 287 | 3.4.2.1.8 | AO-Instrument Laser Traffic Control | 20d? | 2007-07-09 | 2007-08-03 | 145d |  | start no earlier than 2007-07-09 | Summers [6.2%] | 10h | 620 |
| 288 | 3.4.2.1.9 | AO-Instrument User Interfaces | 20d? | 2007-06-04 | 2007-06-29 | 170d |  | finish no earlier than 2007-06-29 |  | 40h |  |
| 289 | 3.4.2.1.10 | AO-Instrument Maintenance Plan | 20d? | 2007-07-02 | 2007-07-27 | 150d |  | finish no earlier than 2007-07-27 |  | 20h |  |

Notes:
- 262: EJ
- 263: JC
- 264: DLM
- 265: DLM
- 278: DLM
- 279: DLM
- 280: DLM
- 287: DS

| ID | WBS | Task | Duration | Start | Finish | Predecessors | Total slack | Free slack | Constraint | Resources | Work | Cost | Text1 |
| --- | --- | --- | --- | --- | --- | --- | --- | --- | --- | --- | --- | --- | --- |
| 290 | 3.4.2.2 | **AO-Instrument Operations Optimization** | 45d? | 2007-03-05 | 2007-05-04 |  | 210d |  |  |  | 180h | 4,800 |  |
| 291 | 3.4.2.2.1 | AO-Instrument Performance Prediction | 30d? | 2007-03-05 | 2007-04-13 |  | 225d |  | start no earlier than 2007-03-05 | Flicker [25%]; Other [8.3%] | 80h | 2,400 |  |
| 292 | 3.4.2.2.2 | AO-Instrument Real-Time Optimization | 30d? | 2007-03-05 | 2007-04-13 |  | 225d |  | start no earlier than 2007-03-05 | Flicker [25%]; Other [8.3%] | 80h | 2,400 |  |
| 293 | 3.4.2.2.3 | AO-Instrument Environment Monitoring | 15d? | 2007-04-16 | 2007-05-04 |  | 210d |  | finish no earlier than 2007-05-04 |  | 20h |  |  |
| 294 | 3.5 | **Science Instruments** | 296.33d? | 2006-10-02 | 2007-11-20 |  | 68.67d | 33.67d |  |  | 1300h | 23,312 | levelled adkins fract |
| 295 | 3.5.1 | OSIRIS | 66.67d? | 2006-12-01 | 2007-03-05 |  | 254.33d |  | start no earlier than 2006-12-01 | Adkins [3%]; Other [24.4%] | 100h | 992 |  |
| 296 | 3.5.2 | Interferometer | 130d? | 2006-10-02 | 2007-03-30 |  | 235d |  | start no earlier than 2006-10-02 | Adkins [1.5%]; Neyman [7.7%]; Other [10%] | 100h | 3,472 | 200 |
| 297 | 3.5.3 | OHANA | 50d? | 2007-02-01 | 2007-04-11 |  | 227d |  | start no earlier than 2007-02-01 | Adkins [2%]; Other [11.2%]; Woillez [15%] | 50h | 1,984 |  |
| 298 | 3.5.4 | Near-IR Imager | 150d? | 2006-10-02 | 2007-04-27 |  | 215d |  | start no earlier than 2006-10-02 | Adkins [2%]; Other [31.6%] | 200h | 1,488 | 250 |
| 299 | 3.5.5 | Visible Imager | 150d? | 2006-10-02 | 2007-04-27 |  | 215d |  | start no earlier than 2006-10-02 | Adkins [2%]; Other [31.6%] | 200h | 1,488 | 250 |
| 300 | 3.5.6 | Visible IFU | 100d? | 2007-01-02 | 2007-05-21 |  | 199d |  | start no earlier than 2007-01-02 | Adkins [2%]; Other [16.4%] | 100h | 992 |  |
| 301 | 3.5.7 | Deployable Near-IR IFU | 208.33d? | 2007-02-01 | 2007-11-20 |  | 68.67d |  | start no earlier than 2007-02-01 | Adkins [4%]; Other [35.7%]; Neyman [15.9%] | 500h | 12,400 | 300 |
| 302 | 3.5.8 | Mid-IR IFU | 100d? | 2007-05-01 | 2007-09-17 |  | 114d |  | start no earlier than 2007-05-01 | Adkins [1%]; Other [23.9%] | 50h | 496 |  |
| 303 | 3.6 | System Design Manual | 24d? | 2008-01-07 | 2008-02-08 | 210, 221, 294, 165, 264, 219, 250, 222 | 35d | 0d | finish no earlier than 2008-01-18 | Wizinowich [20.8%]; Dekany [10.4%]; Gavel [10.4%] | 80h | 4,960 | suggest PW |
| 304 | 4 | **Systems Engineering Management Plan (SEMP)** | 253d? | 2007-01-15 | 2008-01-02 |  | 62d |  |  |  | 986h | 54,312 |  |
| 305 | 4.1 | **Project Plan** | 59.25d? | 2007-09-17 | 2007-12-07 |  | 67d | 5d |  |  | 340h | 17,980 |  |
| 306 | 4.1.1 | Task Definition | 4.25d? | 2007-09-17 | 2007-09-21 |  | 122d |  | finish no earlier than 2007-09-21 | Wizinowich [58.8%]; Dekany [58.8%]; Gavel [58.8%]; Max [58.8%] | 80h | 4,960 |  |
| 307 | 4.1.2 | Cost Estimation | 10d? | 2007-10-22 | 2007-11-02 |  | 92d |  | finish no earlier than 2007-11-02 | Wizinowich [62.5%]; Dekany [62.5%]; Gavel [62.5%]; Other [62.5%] | 200h | 9,300 |  |
| 308 | 4.1.3 | Major Project Milestones | 2.5d? | 2007-11-09 | 2007-11-13 |  | 85d |  | finish no earlier than 2007-11-13 | Wizinowich [50%]; Dekany [50%] | 20h | 1,240 |  |
| 309 | 4.1.4 | MS Project Plan | 4.5d? | 2007-12-03 | 2007-12-07 |  | 67d |  | finish no earlier than 2007-12-07 | Wizinowich [27.8%]; Dekany [27.8%]; Gavel [27.8%]; Max [27.8%] | 40h | 2,480 |  |
| 310 | 4.2 | Risk Assessment & Management Plan | 23d? | 2007-11-14 | 2007-12-14 |  | 62d | 0d | finish no earlier than 2007-12-14 |  | 40h |  |  |
| 311 | 4.3 | **Preliminary Design Phase Plan** | 140d? | 2007-02-05 | 2007-08-17 |  | 147d | 85d |  |  | 166h | 10,292 |  |
| 312 | 4.3.1 | Version 1 to Support Observatory FY08 Planning | 20d? | 2007-02-05 | 2007-03-02 |  | 267d |  | start no earlier than 2007-02-05 | Wizinowich [10%]; Dekany [6.2%]; Gavel [6.2%]; Max [3.8%] | 42h | 2,604 |  |
| 313 | 4.3.2 | Intermediate Versions | 30d? | 2007-04-09 | 2007-05-18 |  | 212d |  | start no earlier than 2007-04-09 | Wizinowich [7.5%]; Dekany [3.3%]; Gavel [3.3%]; Max [2.5%] | 40h | 2,480 |  |
| 314 | 4.3.3 | Final Version | 15d? | 2007-07-30 | 2007-08-17 |  | 147d |  | start no earlier than 2007-07-30 | Wizinowich [26.7%]; Dekany [16.7%]; Gavel [16.7%]; Max [10%] | 84h | 5,208 |  |

Notes:
- 294: SA
- 303: PW
- 304: PW
- 305: PW
- 306: PW
- 307: PW
- 308: PW
- 309: PW
- 311: PW
- 312: PW
- 313: PW
- 314: PW

| ID | WBS | Task | Duration | Start | Finish | Predecessors | Total slack | Free slack | Constraint | Resources | Work | Cost |
| --- | --- | --- | --- | --- | --- | --- | --- | --- | --- | --- | --- | --- |
| 315 | 4.4 | **Integration and Test Plans** | 187d? | 2007-03-12 | 2007-11-27 |  | 75d |  |  |  | 200h | 12,400 |
| 316 | 4.4.1 | **Subsystem Testing Plans** | 22d? | 2007-10-29 | 2007-11-27 |  | 75d | 13d |  |  | 100h | 6,200 |
| 317 | 4.4.1.1 | AO System Test Plan | 22d? | 2007-10-29 | 2007-11-27 |  | 75d |  | start no earlier than 2007-10-29 | Neyman [14.2%] | 25h | 1,550 |
| 318 | 4.4.1.2 | Laser System Test Plan | 22d? | 2007-10-29 | 2007-11-27 |  | 75d |  | start no earlier than 2007-10-29 | Neyman [14.2%] | 25h | 1,550 |
| 319 | 4.4.1.3 | Science Operations Test Plan | 22d? | 2007-10-29 | 2007-11-27 |  | 75d |  | start no earlier than 2007-10-29 | Neyman [14.2%] | 25h | 1,550 |
| 320 | 4.4.1.4 | Science Instruments Test Plan | 22d? | 2007-10-29 | 2007-11-27 |  | 75d |  | start no earlier than 2007-10-29 | Neyman [14.2%] | 25h | 1,550 |
| 321 | 4.4.2 | System Integration & Test Plans | 30d? | 2007-03-12 | 2007-04-20 |  | 232d | 170d | finish no earlier than 2007-04-20 | Neyman [41.7%] | 100h | 6,200 |
| 322 | 4.5 | Configuration Management Plan | 62.5d? | 2007-01-15 | 2007-04-11 |  | 239.5d | 177.5d | start no earlier than 2007-01-15 | Johnson [10%]; Other [10%]; Chin [5%] | 80h | 3,720 |
| 323 | 4.6 | Project Management Plan | 20d? | 2007-02-12 | 2007-03-09 |  | 262d | 200d | start no earlier than 2007-02-12 | Wizinowich [12.5%]; Dekany [12.5%]; Gavel [12.5%]; Max [12.5%] | 80h | 4,960 |
| 324 | 4.7 | SEMP Document | 13d? | 2007-12-17 | 2008-01-02 | 305, 311, 316, 321, 322, 323, 310 | 62d | 27d | finish no earlier than 2008-01-02 | Wizinowich [30.8%]; Dekany [15.4%]; Gavel [15.4%]; Max [15.4%] | 80h | 4,960 |

Notes:
- 315: CN
- 316: CN
- 317: CN
- 318: CN
- 319: CN
- 320: CN
- 321: CN
- 322: JJ
- 323: PW
- 324: PW
