# NGAO System Design Phase Schedule v14

Schedule from MS Project, 2006-06-21 to 2008-05-20, costs in $.
CARA

## Calendars

- Standard: Mon-Fri 08:00-12:00, 13:00-17:00; Sat-Sun off.

## Resources

| Resource | Group | Rate | Notes |
| --- | --- | --- | --- |
| Flicker | WMKO | 62 | AO Modeller |
| Gavel | UCSC | 62 | EC |
| Neyman | WMKO | 62 | AO |
| Dekany | COO | 81.77 | EC |
| Bouchez | COO | 81.77 | AO Scientist |
| Max | UCSC | 62 | EC, Science |
| Wizinowich | WMKO | 62 | EC |
| Britton | COO | 81.77 | AO Modeller |
| Moore | COO | 81.77 | Instrum Sci |
| Velur | COO | 81.77 | AO Scientist |
| Chin | WMKO | 62 | EE |
| Johansson | WMKO | 62 | SE, EE |
| Meguro | WMKO | 62 | ME |
| Stomski | WMKO | 62 | SE |
| Clare | WMKO | 62 | AO Modeller |
| Adkins | WMKO | 62 | Prog mgmt |
| Bell | WMKO | 62 | ME |
| Sweeney | WMKO | 62 | MD |
| Kellner | WMKO | 62 | AO Postdoc |
| van Dam | WMKO | 62 | AO Scientist |
| Johnson | WMKO | 62 | SE |
| Bauman | UCSC | 62 | OE |
| Macintosh | UCSC | 62 | Science |
| Le Mignant | WMKO | 62 | Instrum Sci |
| Postdoc | UCSC | 40 | Science postdoc |
| Other |  | 62 | Unassigned |
| Cameron | COO |  | Grad student |
| Randolph | WMKO | 62 | MD |
| Summers | WMKO | 62 | SE |
| Woillez | WMKO | 62 | KI Scientist |
| Ammons | UCSC |  | Grad student |
| Kupke | UCSC |  | AO Postdoc |
| Lockwood | UCSC | 62 | ME |
| Reinig | UCSC | 62 | EE, ECE |
| Thomas | UCSC |  | AO Postdoc |
| Ireland | COO |  | Postdoc |
| Student1 |  | 31 | Grad student |
| Student2 |  | 31 | Grad student |

## Schedule

| ID | WBS | Task | Type | Duration | Start | Finish | Predecessors | Total slack | Free slack | Constraint | Resources | Work | Cost | Text1 |
| --- | --- | --- | --- | --- | --- | --- | --- | --- | --- | --- | --- | --- | --- | --- |
| 1 | 1 | **SD Phase Management** |  | 500d? | 2006-06-21 | 2008-05-20 |  | 0d |  |  |  | 2801h | 188,627.89 |  |
| 2 | 1.1 | **Planning and Contracting** |  | 323d? | 2006-06-21 | 2007-09-14 |  | 177d |  |  |  | 220h | 14,549.42 |  |
| 3 | 1.1.1 | NGAO Proposal to SSC | milestone | 0d | 2006-06-21 | 2006-06-21 |  | 479d | 17d | start no earlier than 2006-06-21 |  |  |  |  |
| 4 | 1.1.2 | Management Structure Decision by Directors | milestone | 0d | 2006-07-14 | 2006-07-14 | 3 | 462d | 35d | start no earlier than 2006-07-14 |  |  |  |  |
| 5 | 1.1.3 | SD Phase System Engineering Management Plan |  | 21d? | 2006-09-01 | 2006-09-29 | 4 | 427d |  | finish no earlier than 2006-09-29 | Max [8.9%]; Gavel [8.9%]; Dekany [8.9%]; Wizinowich [20.8%] | 80h | 5,256.55 |  |
| 6 | 1.1.4 | SD Phase Contracts Generated |  | 23d? | 2006-09-27 | 2006-10-27 |  | 407d | 0d | start no earlier than 2006-09-27 | Adkins [16.7%]; Gavel [8.3%]; Dekany [8.3%] | 60h | 4,016.55 |  |
| 7 | 1.1.5 | Director Approval | milestone | 0d | 2006-10-09 | 2006-10-09 |  | 146d | 0d | start no earlier than 2006-10-09 |  |  |  |  |
| 8 | 1.1.6 | SD Partner Contracts Issued | milestone | 0d | 2006-10-27 | 2006-10-27 | 6, 7 | 407d |  | start no earlier than 2006-10-13 |  |  |  |  |
| 9 | 1.1.7 | Mid-year Replan |  | 10d | 2007-03-05 | 2007-03-16 |  | 307d |  | start no earlier than 2007-03-05 | Wizinowich [22.5%]; Dekany [10%]; Gavel [10%]; Max [7.5%] | 40h | 2,638.16 |  |
| 10 | 1.1.8 | FY08 Replan |  | 8d | 2007-09-05 | 2007-09-14 |  | 177d |  | start no earlier than 2007-09-05 | Wizinowich [28.1%]; Dekany [12.5%]; Gavel [12.5%]; Max [9.4%] | 40h | 2,638.16 |  |
| 11 | 1.2 | **Project Meetings** |  | 500d? | 2006-06-21 | 2008-05-20 |  | 0d |  |  |  | 1828h | 124,960.76 |  |
| 12 | 1.2.1 | Executive Committee Telecons |  | 500d | 2006-06-21 | 2008-05-20 |  | 0d |  |  | Wizinowich [2.5%]; Dekany [2.5%]; Gavel [2.5%]; Max [2.5%] | 400h | 26,777 |  |
| 13 | 1.2.2 | Science Advisory Committee Telecons |  | 390d? | 2006-10-02 | 2008-03-28 |  | 37d |  | start no earlier than 2006-10-02 | Max [1.4%] | 40h | 2,480 |  |
| 14 | 1.2.3 | **Team Meetings** |  | 345d | 2006-09-14 | 2008-01-09 |  | 94d |  |  |  | 1388h | 95,703.76 |  |
| 15 | 1.2.3.1 | Team Meeting #1 (mgmt, science & technical - Irvine) |  | 1d | 2006-09-14 | 2006-09-14 |  | 438d |  | start no earlier than 2006-09-14 | Wizinowich; Dekany; Gavel; Max; Bauman; Bouchez; Velur; Flicker; Neyman; Britton; Le Mignant | 68h | 4,611.4 |  |
| 16 | 1.2.3.2 | Team Meeting #2 (CIT) |  | 1d | 2006-11-07 | 2006-11-07 |  | 400d |  | start no earlier than 2006-11-07 | Wizinowich; Dekany; Gavel; Max; Bauman; Bouchez; Velur; Flicker; Neyman; Britton; Le Mignant | 80h | 5,513.56 |  |
| 17 | 1.2.3.3 | Team Videocon #3 |  | 1d | 2006-12-13 | 2006-12-13 |  | 374d |  | start no earlier than 2006-12-13 | Wizinowich; Dekany; Gavel; Max; Bauman; Bouchez; Velur; Flicker; Neyman; Britton; Le Mignant | 80h | 5,513.56 |  |
| 18 | 1.2.3.4 | Team Meeting #4 (Keck) |  | 1d | 2007-01-22 | 2007-01-22 |  | 346d |  | start no earlier than 2007-01-22 | Wizinowich; Dekany; Gavel; Max; Bauman; Bouchez; Velur; Flicker; Neyman; Britton; Le Mignant | 80h | 5,513.56 |  |
| 19 | 1.2.3.5 | Team Videocon #5 |  | 1d | 2007-03-07 | 2007-03-07 |  | 314d |  | start no earlier than 2007-03-07 | Wizinowich; Dekany; Gavel; Max; Bauman; Bouchez; Velur; Flicker; Neyman; Britton; Le Mignant | 80h | 5,513.56 |  |
| 20 | 1.2.3.6 | Team Meeting #6 (UCSC) |  | 1d | 2007-04-18 | 2007-04-18 |  | 284d |  | start no earlier than 2007-04-18 | Wizinowich; Dekany; Gavel; Max; Bauman; Bouchez; Velur; Flicker; Neyman; Britton; Le Mignant | 80h | 5,513.56 |  |
| 21 | 1.2.3.7 | Team Videocon #7 |  | 1d | 2007-05-30 | 2007-05-30 |  | 254d |  | finish no earlier than 2007-05-30 | Wizinowich; Dekany; Gavel; Max; Bauman; Bouchez; Velur; Flicker; Neyman; Britton; Le Mignant | 80h | 5,513.56 |  |
| 22 | 1.2.3.8 | Team Retreat #8 (UCSC) |  | 5d | 2007-07-09 | 2007-07-13 |  | 222d |  | start no earlier than 2007-07-09 | Wizinowich; Dekany; Gavel; Max; Bauman; Bouchez; Velur; Flicker; Neyman; Britton; Le Mignant | 440h | 30,443.2 |  |
| 23 | 1.2.3.9 | Team Videocon #9 |  | 1d | 2007-08-22 | 2007-08-22 |  | 194d |  | start no earlier than 2007-08-22 | Wizinowich; Dekany; Gavel; Max; Bauman; Bouchez; Velur; Flicker; Neyman; Britton; Le Mignant | 80h | 5,513.56 |  |
| 24 | 1.2.3.10 | Team Meeting #10 (CIT) |  | 1d | 2007-09-11 | 2007-09-11 |  | 180d |  | start no earlier than 2007-09-11 | Wizinowich; Dekany; Gavel; Max; Bauman; Bouchez; Velur; Flicker; Neyman; Britton; Le Mignant | 80h | 5,513.56 |  |
| 25 | 1.2.3.11 | Team Videocon #11 |  | 1d | 2007-11-05 | 2007-11-05 |  | 141d |  | start no earlier than 2007-11-05 | Wizinowich; Dekany; Gavel; Max; Bauman; Bouchez; Velur; Flicker; Neyman; Britton; Le Mignant | 80h | 5,513.56 |  |
| 26 | 1.2.3.12 | Team Meeting #12 (Keck) |  | 1d | 2007-12-12 | 2007-12-12 |  | 114d |  | start no earlier than 2007-12-12 | Wizinowich; Dekany; Gavel; Max; Bauman; Bouchez; Velur; Flicker; Neyman; Britton; Le Mignant | 80h | 5,513.56 |  |
| 27 | 1.2.3.13 | Team Videocon #13 |  | 1d | 2008-01-09 | 2008-01-09 |  | 94d |  | start no earlier than 2008-01-09 | Wizinowich; Dekany; Gavel; Max; Bauman; Bouchez; Velur; Flicker; Neyman; Britton; Le Mignant | 80h | 5,513.56 | deleted #14 |

Notes:
- 1: PW
- 2: PW
- 5: PW
- 6: SA
- 8: SA
- 9: PW
- 10: PW
- 12: PW / 1 hr per week x 4 persons for duration of SD phase is about 400 wk-hours total - RD
- 13: CM

| ID | WBS | Task | Type | Duration | Start | Finish | Predecessors | Total slack | Free slack | Constraint | Resources | Work | Cost | Text1 |
| --- | --- | --- | --- | --- | --- | --- | --- | --- | --- | --- | --- | --- | --- | --- |
| 28 | 1.3 | **Tracking and Reporting** |  | 404d? | 2006-09-16 | 2008-04-03 |  | 33d |  |  |  | 120h | 7,736.55 |  |
| 29 | 1.3.1 | Report Preparation/Presentation |  | 312.5d? | 2006-10-02 | 2007-12-12 |  | 114.5d |  | start no earlier than 2006-10-02 | Wizinowich [2%]; Dekany [2%]; Gavel [2%]; Max [2%] | 120h | 7,736.55 |  |
| 30 | 1.3.2 | Keck Science Meeting 06 (UCI) | milestone | 0d | 2006-09-16 | 2006-09-16 |  | 437d |  | finish no earlier than 2006-09-16 |  |  |  |  |
| 31 | 1.3.3 | SSC meeting (UCLA) | milestone | 0d | 2006-11-06 | 2006-11-06 |  | 402d |  | start no earlier than 2006-11-06 |  |  |  |  |
| 32 | 1.3.4 | SSC meeting (Keck) | milestone | 0d | 2007-01-24 | 2007-01-24 |  | 345d |  | start no earlier than 2007-01-24 |  |  |  |  |
| 33 | 1.3.5 | SSC meeting (CA) | milestone | 0d | 2007-04-03 | 2007-04-03 |  | 296d |  | start no earlier than 2007-04-03 |  |  |  |  |
| 34 | 1.3.6 | SSC meeting (Keck) | milestone | 0d | 2007-06-20 | 2007-06-20 |  | 240d |  | start no earlier than 2007-06-20 |  |  |  |  |
| 35 | 1.3.7 | Keck Science Meeting 07 | milestone | 0d | 2007-09-22 | 2007-09-22 |  | 172d |  | finish no earlier than 2007-09-22 |  |  |  |  |
| 36 | 1.3.8 | SSC meeting (CA) | milestone | 0d | 2007-11-06 | 2007-11-06 |  | 141d |  | start no earlier than 2007-11-06 |  |  |  |  |
| 37 | 1.3.9 | SSC meeting (Keck) | milestone | 0d | 2008-01-24 | 2008-01-24 |  | 84d |  | start no earlier than 2008-01-24 |  |  |  |  |
| 38 | 1.3.10 | SSC meeting (CA) | milestone | 0d | 2008-04-03 | 2008-04-03 |  | 33d |  | finish no earlier than 2008-04-03 |  |  |  |  |
| 39 | 1.4 | **Proposals & Fundraising** |  | 306d? | 2006-10-27 | 2007-12-31 |  | 101d |  |  |  | 160h | 10,117.7 |  |
| 40 | 1.4.1 | Dates & deliverables identified by Directors | milestone | 0d | 2006-10-27 | 2006-10-27 | 7FS+3w | 146d | 45d |  |  |  |  |  |
| 41 | 1.4.2 | Support Advancement Office |  | 261d? | 2007-01-01 | 2007-12-31 | 40 | 101d |  | start no earlier than 2007-01-01 | Wizinowich [2.9%]; Max [3.8%]; Gavel [0.5%]; Dekany [0.5%] | 160h | 10,117.7 | lead |
| 42 | 1.5 | **System Design Report & Review** |  | 141d? | 2007-09-17 | 2008-03-31 |  | 36d |  |  |  | 473h | 31,263.46 |  |
| 43 | 1.5.1 | System Design Report |  | 8d? | 2008-02-04 | 2008-02-13 | 323, 302, 133 | 36d | 0d |  | Wizinowich [31.2%]; Gavel [7.8%]; Dekany [7.8%]; Adkins [7.8%]; Max [7.8%] | 40h | 2,578.85 |  |
| 44 | 1.5.2 | **System Design Review** |  | 141d? | 2007-09-17 | 2008-03-31 |  | 36d |  |  |  | 433h | 28,684.61 | lead |
| 45 | 1.5.2.1 | Identify Reviewers |  | 65d? | 2007-09-17 | 2007-12-14 |  | 83d | 43d | start no earlier than 2007-09-17 | Adkins [1.9%]; Wizinowich [0.4%]; Max [0.2%]; Gavel [0.2%]; Dekany [0.2%] | 15h | 949.77 | lead |
| 46 | 1.5.2.2 | Review Package Distributed |  | 1d | 2008-02-14 | 2008-02-14 | 43, 45 | 40d | 0d | start no earlier than 2008-01-14 | Adkins | 8h | 496 | lead |
| 47 | 1.5.2.3 | Reviewer Comments Addressed |  | 5d? | 2008-02-29 | 2008-03-06 | 46FS+10d | 40d | 4d | finish no earlier than 2008-02-01 | Wizinowich [75%]; Dekany [60%]; Gavel [60%]; Max [65%]; Adkins [40%] | 120h | 7,914.48 | lead |
| 48 | 1.5.2.4 | System Design Review Support |  | 20d? | 2008-02-14 | 2008-03-12 | 43 | 36d | 0d | start no earlier than 2007-01-16 | Wizinowich [15%]; Dekany [15%]; Gavel [15%]; Max [15%]; Bauman [7.5%]; Bouchez [2.5%]; Velur [10%]; Flicker [10%]; Neyman [16.2%]; Le Mignant [10%]; Johansson [10%]; Adkins [10%]; Chin [5%]; Kellner [5%]; Moore [10%] | 250h | 16,686.2 | Personnel |
| 49 | 1.5.2.5 | System Design Review Meeting | milestone | 0d | 2008-03-12 | 2008-03-12 | 48, 47 | 36d | 0d | start no earlier than 2008-02-06 |  |  |  | lead |
| 50 | 1.5.2.6 | Reviewer Report Received | milestone | 0d | 2008-03-26 | 2008-03-26 | 49FS+10d | 36d | 0d | start no earlier than 2008-02-15 |  |  |  |  |
| 51 | 1.5.2.7 | Response to Reviewer Report & Distribution |  | 3d? | 2008-03-27 | 2008-03-31 | 50 | 36d |  | start no earlier than 2008-02-18 | Wizinowich [41.7%]; Dekany [33.3%]; Gavel [33.3%]; Max [41.7%]; Adkins [16.7%] | 40h | 2,638.16 | lead |

Notes:
- 28: PW
- 29: PW
- 41: PW
- 42: SA
- 43: PW
- 44: PW
- 45: SA
- 46: SA
- 47: PW
- 48: PW
- 49: SA
- 51: PW

| ID | WBS | Task | Duration | Start | Finish | Total slack | Constraint | Resources | Work | Cost | Text1 |
| --- | --- | --- | --- | --- | --- | --- | --- | --- | --- | --- | --- |
| 52 | 2 | **System Requirements** | 295d? | 2006-09-18 | 2007-11-02 | 141d |  |  | 3534h | 140,074.32 | DG suggest |
| 53 | 2.1 | **Science Requirements** | 281d? | 2006-09-18 | 2007-10-15 | 156d |  |  | 3090h | 112,230 |  |
| 54 | 2.1.1 | **Solar System Science Requirements** | 135d? | 2006-10-02 | 2007-04-06 | 292d |  |  | 650h | 20,150 |  |
| 55 | 2.1.1.1 | **Companions & Multiplicity of Small Solar System Bodies** | 75d? | 2006-10-02 | 2007-01-12 | 352d |  |  | 250h | 7,750 |  |
| 56 | 2.1.1.1.1 | Point Source Companion Sensitivity Requirements | 45d? | 2006-10-02 | 2006-12-01 | 382d | finish no earlier than 2006-12-01 | Student1 [27.8%] | 100h | 3,100 | added student |
| 57 | 2.1.1.1.2 | Spectral Sensitivity & Spectral Resolution Requirements | 45d? | 2006-10-02 | 2006-12-01 | 382d | finish no earlier than 2006-12-01 | Student1 [27.8%] | 100h | 3,100 |  |
| 58 | 2.1.1.1.3 | Observing Scenarios | 30d? | 2006-12-04 | 2007-01-12 | 352d | finish no earlier than 2007-01-12 | Student1 [10.4%] | 25h | 775 |  |
| 59 | 2.1.1.1.4 | Science Instrument Requirements | 30d? | 2006-12-04 | 2007-01-12 | 352d | start no earlier than 2006-12-04 | Student1 [10.4%] | 25h | 775 |  |
| 60 | 2.1.1.2 | **Moons of the Giant Planets** | 70d? | 2006-12-04 | 2007-03-09 | 312d |  |  | 150h | 4,650 |  |
| 61 | 2.1.1.2.1 | Performance Requirements | 40d? | 2006-12-04 | 2007-01-26 | 342d | start no earlier than 2006-12-04 | Student1 [31.2%] | 100h | 3,100 |  |
| 62 | 2.1.1.2.2 | Observing Scenarios | 30d? | 2007-01-29 | 2007-03-09 | 312d | finish no earlier than 2007-03-09 | Student1 [10.4%] | 25h | 775 |  |
| 63 | 2.1.1.2.3 | Science Instrument Requirements | 30d? | 2007-01-29 | 2007-03-09 | 312d | start no earlier than 2007-01-29 | Student1 [10.4%] | 25h | 775 |  |
| 64 | 2.1.1.3 | **Shape & Size of Asteroids** | 50d? | 2007-01-29 | 2007-04-06 | 292d |  |  | 250h | 7,750 |  |
| 65 | 2.1.1.3.1 | Spatial Resolution Requirements | 25d? | 2007-01-29 | 2007-03-02 | 317d | start no earlier than 2007-01-29 | Student1 [50%] | 100h | 3,100 |  |
| 66 | 2.1.1.3.2 | Spectral Sensitivity & Spectral Resolution Requirements | 25d? | 2007-01-29 | 2007-03-02 | 317d | start no earlier than 2007-01-29 | Student1 [50%] | 100h | 3,100 |  |
| 67 | 2.1.1.3.3 | Observing Scenarios | 25d? | 2007-03-05 | 2007-04-06 | 292d | finish no earlier than 2007-04-06 | Student1 [12.5%] | 25h | 775 |  |
| 68 | 2.1.1.3.4 | Science Instrument Requirements | 25d? | 2007-03-05 | 2007-04-06 | 292d | start no earlier than 2007-03-05 | Student1 [12.5%] | 25h | 775 |  |
| 69 | 2.1.2 | **Galactic Science Requirements** | 145d? | 2006-09-18 | 2007-04-06 | 292d |  |  | 1200h | 37,200 |  |
| 70 | 2.1.2.1 | **Galactic Center Proper Motions: Astrometry** | 85d? | 2006-09-18 | 2007-01-12 | 352d |  |  | 200h | 6,200 |  |
| 71 | 2.1.2.1.1 | Astrometry requirements | 50d? | 2006-09-18 | 2006-11-24 | 387d | finish no earlier than 2006-11-24 | Student2 [37.5%] | 150h | 4,650 |  |
| 72 | 2.1.2.1.2 | Observing Scenarios | 35d? | 2006-11-27 | 2007-01-12 | 352d | finish no earlier than 2007-01-12 | Student2 [8.9%] | 25h | 775 |  |
| 73 | 2.1.2.1.3 | Science Instrument Requirements | 35d? | 2006-11-27 | 2007-01-12 | 352d | start no earlier than 2006-11-27 | Student2 [8.9%] | 25h | 775 |  |
| 74 | 2.1.2.2 | **Galactic Center Radial Velocities & Stellar Populations: Integral Field Spectroscopy** | 75d? | 2006-11-27 | 2007-03-09 | 312d |  |  | 200h | 6,200 |  |
| 75 | 2.1.2.2.1 | Performance Requirements | 45d? | 2006-11-27 | 2007-01-26 | 342d | finish no earlier than 2007-01-26 | Student2 [41.7%] | 150h | 4,650 |  |
| 76 | 2.1.2.2.2 | Observing Scenarios | 30d? | 2007-01-29 | 2007-03-09 | 312d | start no earlier than 2007-01-29 | Student2 [10.4%] | 25h | 775 |  |
| 77 | 2.1.2.2.3 | Science Instrument Requirements | 30d? | 2007-01-29 | 2007-03-09 | 312d | start no earlier than 2007-01-29 | Student2 [10.4%] | 25h | 775 |  |

Notes:
- 52: PW
- 53: CM
- 54: FM
- 69: ML
- 70: AG
- 74: AG

| ID | WBS | Task | Duration | Start | Finish | Total slack | Constraint | Resources | Work | Cost | Text1 |
| --- | --- | --- | --- | --- | --- | --- | --- | --- | --- | --- | --- |
| 78 | 2.1.2.3 | **Galactic Center Nature of Sgr A*: 3-5 um Color & 2 um Polarimetry Variability** | 50d? | 2007-01-29 | 2007-04-06 | 292d |  |  | 200h | 6,200 |  |
| 79 | 2.1.2.3.1 | Performance Requirements | 25d? | 2007-01-29 | 2007-03-02 | 317d | finish no earlier than 2007-03-02 | Student2 [75%] | 150h | 4,650 |  |
| 80 | 2.1.2.3.2 | Observing Scenarios | 25d? | 2007-03-05 | 2007-04-06 | 292d | start no earlier than 2007-03-05 | Student2 [12.5%] | 25h | 775 |  |
| 81 | 2.1.2.3.3 | Science Instrument Requirements | 25d? | 2007-03-05 | 2007-04-06 | 292d | finish no earlier than 2007-04-06 | Student2 [12.5%] | 25h | 775 |  |
| 82 | 2.1.2.4 | **Planets around Low Mass Stars & Brown Dwarfs: Companion Sensitivity** | 85d? | 2006-09-18 | 2007-01-12 | 352d |  |  | 200h | 6,200 |  |
| 83 | 2.1.2.4.1 | Companion Sensitivity Performance Requirements | 50d? | 2006-09-18 | 2006-11-24 | 387d | finish no earlier than 2006-11-24 | Student2 [37.5%] | 150h | 4,650 |  |
| 84 | 2.1.2.4.2 | Observing Scenarios | 35d? | 2006-11-27 | 2007-01-12 | 352d | start no earlier than 2006-11-27 | Student2 [8.9%] | 25h | 775 |  |
| 85 | 2.1.2.4.3 | Science Instrument Requirements | 35d? | 2006-11-27 | 2007-01-12 | 352d | start no earlier than 2006-11-27 | Student2 [8.9%] | 25h | 775 |  |
| 86 | 2.1.2.5 | **Debris Disks, Protostellar Envelopes & Outflows: Contrast** | 50d? | 2007-01-29 | 2007-04-06 | 292d |  |  | 200h | 6,200 |  |
| 87 | 2.1.2.5.1 | Contrast Performance Requirements | 25d? | 2007-01-29 | 2007-03-02 | 317d | finish no earlier than 2007-03-02 | Student2 [75%] | 150h | 4,650 |  |
| 88 | 2.1.2.5.2 | Observing Scenarios | 25d? | 2007-03-05 | 2007-04-06 | 292d | start no earlier than 2007-03-05 | Student2 [12.5%] | 25h | 775 |  |
| 89 | 2.1.2.5.3 | Science Instrument Requirements | 25d? | 2007-03-05 | 2007-04-06 | 292d | start no earlier than 2007-03-05 | Student2 [12.5%] | 25h | 775 |  |
| 90 | 2.1.2.6 | **Debris Disks, Protostellar Envelopes & Outflows: Polarimetry** | 75d? | 2006-11-27 | 2007-03-09 | 312d |  |  | 200h | 6,200 |  |
| 91 | 2.1.2.6.1 | Polarimetry Performance Requirements | 45d? | 2006-11-27 | 2007-01-26 | 342d | finish no earlier than 2007-01-26 | Student2 [41.7%] | 150h | 4,650 |  |
| 92 | 2.1.2.6.2 | Observing Scenarios | 30d? | 2007-01-29 | 2007-03-09 | 312d | start no earlier than 2007-01-29 | Student2 [10.4%] | 25h | 775 |  |
| 93 | 2.1.2.6.3 | Science Instrument Requirements | 30d? | 2007-01-29 | 2007-03-09 | 312d | start no earlier than 2007-01-29 | Student2 [10.4%] | 25h | 775 |  |
| 94 | 2.1.3 | **Extragalactic Science Requirements** | 160d? | 2006-09-18 | 2007-04-27 | 277d |  |  | 1000h | 40,000 |  |
| 95 | 2.1.3.1 | **Resolved Stellar Populations in Crowded Fields** | 100d? | 2006-09-18 | 2007-02-02 | 337d |  |  | 300h | 12,000 |  |
| 96 | 2.1.3.1.1 | Performance Requirements | 60d? | 2006-09-18 | 2006-12-08 | 377d | finish no earlier than 2006-12-08 | Postdoc [52.1%] | 250h | 10,000 | added postdoc |
| 97 | 2.1.3.1.2 | Observing Scenarios | 40d? | 2006-12-11 | 2007-02-02 | 337d | finish no earlier than 2007-02-02 | Postdoc [7.8%] | 25h | 1,000 |  |
| 98 | 2.1.3.1.3 | Science Instrument Requirements | 40d? | 2006-12-11 | 2007-02-02 | 337d | start no earlier than 2006-12-11 | Postdoc [7.8%] | 25h | 1,000 |  |
| 99 | 2.1.3.2 | **High Redshift Galaxies** | 100d? | 2006-09-18 | 2007-02-02 | 337d |  |  | 300h | 12,000 |  |
| 100 | 2.1.3.2.1 | Encircled Energy (& d-IFU) Performance Requirements | 60d? | 2006-09-18 | 2006-12-08 | 377d | finish no earlier than 2006-12-08 | Postdoc [41.7%] | 200h | 8,000 |  |
| 101 | 2.1.3.2.2 | Observing Scenarios | 40d? | 2006-12-11 | 2007-02-02 | 337d | start no earlier than 2006-12-11 | Postdoc [15.6%] | 50h | 2,000 |  |
| 102 | 2.1.3.2.3 | Science Instrument Requirements | 40d? | 2006-12-11 | 2007-02-02 | 337d | start no earlier than 2006-12-11 | Postdoc [15.6%] | 50h | 2,000 |  |

Notes:
- 78: AG
- 82: ML
- 86: LH
- 94: CM

| ID | WBS | Task | Duration | Start | Finish | Predecessors | Total slack | Free slack | Constraint | Resources | Work | Cost | Text1 |
| --- | --- | --- | --- | --- | --- | --- | --- | --- | --- | --- | --- | --- | --- |
| 103 | 2.1.3.3 | **Nearby Galaxies** | 100d? | 2006-12-11 | 2007-04-27 |  | 277d |  |  |  | 200h | 8,000 |  |
| 104 | 2.1.3.3.1 | Encircled Energy & PSF Performance Requirements | 60d? | 2006-12-11 | 2007-03-02 |  | 317d |  | finish no earlier than 2007-03-02 | Postdoc [31.2%] | 150h | 6,000 |  |
| 105 | 2.1.3.3.2 | Observing Scenarios | 40d? | 2007-03-05 | 2007-04-27 |  | 277d |  | finish no earlier than 2007-04-27 | Postdoc [7.8%] | 25h | 1,000 |  |
| 106 | 2.1.3.3.3 | Science Instrument Requirements | 40d? | 2007-03-05 | 2007-04-27 |  | 277d |  | start no earlier than 2007-03-05 | Postdoc [7.8%] | 25h | 1,000 |  |
| 107 | 2.1.3.4 | **Gravitational Lensing** | 100d? | 2006-12-11 | 2007-04-27 |  | 277d |  |  |  | 200h | 8,000 |  |
| 108 | 2.1.3.4.1 | Encircled Energy & PSF Performance Requirements | 60d? | 2006-12-11 | 2007-03-02 |  | 317d |  | start no earlier than 2006-12-11 | Postdoc [31.2%] | 150h | 6,000 |  |
| 109 | 2.1.3.4.2 | Observing Scenarios | 40d? | 2007-03-05 | 2007-04-27 |  | 277d |  | start no earlier than 2007-03-05 | Postdoc [7.8%] | 25h | 1,000 |  |
| 110 | 2.1.3.4.3 | Science Instrument Requirements | 40d? | 2007-03-05 | 2007-04-27 |  | 277d |  | start no earlier than 2007-03-05 | Postdoc [7.8%] | 25h | 1,000 |  |
| 111 | 2.1.4 | **Science Requirements Summary** | 271d? | 2006-10-02 | 2007-10-15 |  | 146d |  |  |  | 240h | 14,880 |  |
| 112 | 2.1.4.1 | Science Requirements Summary Rev 1 | 14d? | 2006-10-02 | 2006-10-19 |  | 403d | 26d | finish no earlier than 2006-10-19 | Max [17.9%]; Wizinowich [17.9%] | 40h | 2,480 |  |
| 113 | 2.1.4.2 | Science Requirements Summary Rev 2 | 13.89d? | 2007-02-13 | 2007-03-02 |  | 307d | 4d | finish no earlier than 2007-03-02 | Max [18%]; Wizinowich [18%]; Other | 120h | 7,440 |  |
| 114 | 2.1.4.3 | Science Requirements Summary Rev 3 | 13.89d? | 2007-06-05 | 2007-06-22 |  | 227d | 4d | finish no earlier than 2007-06-22 | Max [18%]; Wizinowich [18%] | 40h | 2,480 |  |
| 115 | 2.1.4.4 | Science Requirements Summary Final | 13.89d? | 2007-09-26 | 2007-10-15 |  | 105d | 4d | finish no earlier than 2007-10-15 | Max [18%]; Wizinowich [18%] | 40h | 2,480 |  |
| 116 | 2.2 | **Observatory Requirements** | 245d? | 2006-10-02 | 2007-09-07 |  | 131d |  |  |  | 234h | 14,824.32 |  |
| 117 | 2.2.1 | Development Requirements | 40d? | 2006-10-02 | 2006-11-24 |  | 131d | 0d | start no earlier than 2006-10-02 | Neyman [2.5%]; Wizinowich [2.5%] | 16h | 992 |  |
| 118 | 2.2.2 | Observatory Interface Requirements | 20d? | 2006-10-02 | 2006-10-27 |  | 151d | 20d | start no earlier than 2006-10-02 | Neyman [5%]; Wizinowich [5%]; Adkins [5%] | 24h | 1,488 |  |
| 119 | 2.2.3 | Science Operations Requirements | 40d? | 2006-10-02 | 2006-11-24 |  | 131d | 0d | finish no earlier than 2006-11-24 | Le Mignant [10%]; Wizinowich [5%]; Bouchez [5%] | 64h | 4,284.32 | pulled in |
| 120 | 2.2.4 | Observatory Requirements Rev 2 | 15d? | 2007-01-22 | 2007-02-09 | 117FS+8w, 118FS+8w, 119FS+8w | 131d | 0d |  | Neyman [20%]; Other [41.7%]; Le Mignant [13.3%] | 90h | 5,580 |  |
| 121 | 2.2.5 | Observatory Requirements Rev 3 | 30d? | 2007-04-09 | 2007-05-18 | 120FS+8w | 131d | 0d |  | Neyman [8.3%] | 20h | 1,240 |  |
| 122 | 2.2.6 | Observatory Requirements Rev 4 | 40d? | 2007-07-16 | 2007-09-07 | 121FS+8w | 131d | 30d |  | Neyman [6.2%] | 20h | 1,240 |  |
| 123 | 2.3 | **System Requirements Document** | 280d? | 2006-10-09 | 2007-11-02 |  | 142d |  |  |  | 210h | 13,020 |  |
| 124 | 2.3.1 | **Tracability Matrix** | 270d? | 2006-10-09 | 2007-10-20 |  | 142d |  |  |  | 130h | 8,060 |  |
| 125 | 2.3.1.1 | Tracability Matrix Rev 1 | 10d? | 2006-10-09 | 2006-10-20 |  | 402d | 25d | finish no earlier than 2006-10-20 | Neyman [12.5%] | 10h | 620 | lead |
| 126 | 2.3.1.2 | Tracability Matrix Rev 2 | 12d? | 2007-02-12 | 2007-02-27 |  | 310d | 7d | start no earlier than 2007-02-12 | Neyman [25%]; Wizinowich [25%]; Adkins [25%]; Flicker [25%] | 80h | 4,960 | lead |
| 127 | 2.3.1.3 | Tracability Matrix Rev 3 | 10d? | 2007-06-15 | 2007-06-28 |  | 223d | 0d | finish no earlier than 2007-06-28 | Neyman [25%] | 20h | 1,240 | lead |
| 128 | 2.3.1.4 | Tracability Matrix Rev 4 | 9d? | 2007-10-09 | 2007-10-20 |  | 101d | 0d | finish no earlier than 2007-10-20 | Neyman [27.8%] | 20h | 1,240 | lead |

Notes:
- 111: CM
- 116: CN
- 117: CN
- 118: CN
- 119: DLM
- 120: CN
- 121: CN
- 122: CN
- 124: CN
- 125: CN
- 126: CN
- 127: CN
- 128: CN

| ID | WBS | Task | Duration | Start | Finish | Predecessors | Total slack | Free slack | Constraint | Resources | Work | Cost | Text1 |
| --- | --- | --- | --- | --- | --- | --- | --- | --- | --- | --- | --- | --- | --- |
| 129 | 2.3.2 | **System Requirements Document** | 245d | 2006-11-27 | 2007-11-02 |  | 142d |  |  |  | 80h | 4,960 |  |
| 130 | 2.3.2.1 | SRD Rev 1 | 10d | 2006-11-27 | 2006-12-08 | 112, 125, 117, 118, 119 | 377d |  | start no earlier than 2006-11-27 | Wizinowich [25%] | 20h | 1,240 | pulled in by 119 |
| 131 | 2.3.2.2 | SRD Rev 2 | 10d | 2007-03-09 | 2007-03-22 | 113, 126, 120 | 303d |  | start no earlier than 2007-03-09 | Neyman [25%] | 20h | 1,240 |  |
| 132 | 2.3.2.3 | SRD Rev 3 | 10d | 2007-06-29 | 2007-07-12 | 114, 127, 121 | 223d |  | start no earlier than 2007-06-29 | Neyman [25%] | 20h | 1,240 |  |
| 133 | 2.3.2.4 | SRD Final SD Phase Version | 10d | 2007-10-22 | 2007-11-02 | 115, 128, 122 | 101d | 65d |  | Neyman [25%] | 20h | 1,240 |  |
| 134 | 3 | **System Design** | 385d? | 2006-08-14 | 2008-02-01 |  | 77d |  |  |  | 10226h | 646,916.63 |  |
| 135 | 3.1 | **Systems Engineering** | 360d? | 2006-08-14 | 2007-12-28 |  | 102d |  |  |  | 5646h | 353,269.33 |  |
| 136 | 3.1.1 | **Performance Budgets** | 292d? | 2006-08-14 | 2007-09-25 |  | 170d |  |  |  | 2486h | 147,580.68 |  |
| 137 | 3.1.1.1 | **Model Assumptions** | 230d? | 2006-08-14 | 2007-06-29 |  | 213d |  |  |  | 260h | 16,120 |  |
| 138 | 3.1.1.1.1 | **TMT site monitoring data mining** | 230d? | 2006-08-14 | 2007-06-29 |  | 232d |  |  |  | 80h | 4,960 |  |
| 139 | 3.1.1.1.1.1 | Tools in place & 1st release | 24d? | 2006-08-14 | 2006-09-14 |  | 233d | 1d | finish no earlier than 2006-09-14 | Flicker [20.8%] | 40h | 2,480 |  |
| 140 | 3.1.1.1.1.2 | Release updated data (every two months) | 205d? | 2006-09-18 | 2007-06-29 | 139 | 232d |  | finish no earlier than 2007-06-29 | Flicker [2.4%] | 40h | 2,480 |  |
| 141 | 3.1.1.1.2 | Telescope dynamic performance data | 44d? | 2006-10-02 | 2006-11-30 |  | 178d | 1d | start no earlier than 2006-10-02 | Neyman [17%]; Flicker [17%] | 120h | 7,440 |  |
| 142 | 3.1.1.1.3 | Telescope static wavefront errors | 44d? | 2006-10-02 | 2006-11-30 |  | 178d | 1d | finish no earlier than 2006-11-30 | Neyman [5.7%] | 20h | 1,240 |  |
| 143 | 3.1.1.1.4 | Sodium return vs laser format | 22d? | 2006-11-01 | 2006-11-30 |  | 191d | 18d | start no earlier than 2006-11-01 | Gavel [11.4%]; Neyman [11.4%] | 40h | 2,480 |  |
| 144 | 3.1.1.2 | **Model/Tool Validation** | 90d? | 2006-08-14 | 2006-12-15 |  | 180d | 7d |  |  | 334h | 11,025.24 |  |
| 145 | 3.1.1.2.1 | Agreement between Tomography Codes | 35d? | 2006-08-14 | 2006-09-29 |  | 235d |  | start no earlier than 2006-08-14 | Flicker [5.4%]; Gavel [3.6%]; Neyman [5.4%] | 40h | 2,480 |  |
| 146 | 3.1.1.2.2 | Agreement between Sky Coverage Codes | 23d? | 2006-09-18 | 2006-10-18 |  | 222d |  | start no earlier than 2006-09-18 | Dekany [6.5%]; Gavel [6.5%]; Clare [8.7%] | 40h | 2,717.24 |  |
| 147 | 3.1.1.2.3 | Anchor to Keck II LGS AO PSFs | 21d? | 2006-10-02 | 2006-10-30 |  | 214d |  | finish no earlier than 2006-10-30 | Neyman [23.8%] | 40h | 2,480 |  |
| 148 | 3.1.1.2.4 | Anchor to On-sky MGSU Experiments | 3.67d? | 2006-11-10 | 2006-11-15 |  | 202d |  | finish no earlier than 2006-11-15 | Flicker [34.1%] | 10h | 620 |  |
| 149 | 3.1.1.2.5 | Anchor to LAO Lab Experiments | 30d? | 2006-11-06 | 2006-12-15 |  | 180d |  | start no earlier than 2006-11-06 | Gavel [1.7%]; Flicker [16.7%]; Kupke [33.3%]; Ammons [33.3%] | 204h | 2,728 |  |
| 150 | 3.1.1.3 | Throughput | 80d? | 2006-09-11 | 2006-12-29 |  | 206d | 55d | finish no earlier than 2006-12-29 | Bouchez [5%] | 32h | 2,616.64 |  |
| 151 | 3.1.1.4 | **Background** | 71.5d? | 2006-10-02 | 2007-01-09 |  | 199.5d | 48.5d |  |  | 50h | 4,088.5 |  |
| 152 | 3.1.1.4.1 | Document Proposal Analysis | 9d? | 2006-10-02 | 2006-10-12 |  | 262d |  | start no earlier than 2006-10-02 | Bouchez [13.9%] | 10h | 817.7 |  |
| 153 | 3.1.1.4.2 | Develop Background Performance Budget | 62.5d? | 2006-10-02 | 2007-01-09 |  | 199.5d |  | start no earlier than 2006-10-02 | Bouchez [8%] | 40h | 3,270.8 |  |

Notes:
- 130: PW
- 131: CN
- 132: CN
- 133: CN
- 134: PW
- 135: RD
- 136: RD
- 137: CN
- 138: RF
- 139: RF
- 140: RF
- 141: CN
- 142: CN
- 143: DG
- 144: CN
- 145: DG
- 146: RD
- 147: CN
- 148: RF
- 149: DG
- 150: AB
- 151: AB
- 152: AB
- 153: AB

| ID | WBS | Task | Duration | Start | Finish | Predecessors | Total slack | Free slack | Constraint | Resources | Work | Cost | Text1 |
| --- | --- | --- | --- | --- | --- | --- | --- | --- | --- | --- | --- | --- | --- |
| 154 | 3.1.1.5 | **Wavefront Error vs Sky Coverage** | 87d? | 2006-10-02 | 2007-01-30 |  | 173d | 0d |  |  | 110h | 8,401.6 |  |
| 155 | 3.1.1.5.1 | Document WFE Budget Rev 1 | 50d? | 2006-10-02 | 2006-12-08 |  | 210d |  | start no earlier than 2006-10-02 | Dekany [10%] | 40h | 3,270.8 |  |
| 156 | 3.1.1.5.2 | Document WFE Budget Rev 2 | 25d? | 2006-12-27 | 2007-01-30 | 139, 143, 144, 183 | 173d |  | finish no earlier than 2007-01-30 | Dekany [20%]; Flicker [17%] | 70h | 5,130.8 |  |
| 157 | 3.1.1.6 | Encircled Energy vs Sky Coverage | 50d? | 2006-10-23 | 2006-12-29 |  | 195d | 22d | start no earlier than 2006-10-23 | Dekany [17.5%]; Gavel [17.5%] | 110h | 7,610.8 |  |
| 158 | 3.1.1.7 | Photometric Accuracy | 75d? | 2006-10-16 | 2007-01-26 |  | 175d | 2d | start no earlier than 2006-10-16 | Britton [20%]; Neyman [10%]; Flicker [10%] | 240h | 17,252.4 |  |
| 159 | 3.1.1.8 | Astrometric Accuracy | 55d? | 2006-11-13 | 2007-01-26 |  | 186d | 35d | start no earlier than 2006-11-13 | Neyman [9.1%]; Britton [13.6%]; Flicker [9.1%]; Cameron [13.6%]; Wizinowich [9.1%] | 240h | 12,346.2 |  |
| 160 | 3.1.1.9 | Polarimetric Accuracy | 25d? | 2007-02-05 | 2007-03-09 |  | 156d | 5d | start no earlier than 2007-02-05 | Ireland [20%] | 40h |  |  |
| 161 | 3.1.1.10 | Companion Sensitivity | 55d? | 2006-11-13 | 2007-01-26 |  | 175d | 2d | start no earlier than 2006-11-13 | Macintosh [18.2%]; Neyman [18.2%]; Other [18.2%]; Flicker [18.2%] | 320h | 19,840 |  |
| 162 | 3.1.1.11 | Observing Efficiency | 30d? | 2007-02-05 | 2007-03-16 |  | 151d | 0d | start no earlier than 2007-02-05 | Le Mignant [8.3%]; Other [58.3%] | 160h | 9,920 |  |
| 163 | 3.1.1.12 | Observing Uptime | 30d? | 2007-02-05 | 2007-03-16 |  | 151d | 0d | start no earlier than 2007-02-05 | Chin [16.7%]; Johansson [16.7%] | 80h | 4,960 | lead |
| 164 | 3.1.1.13 | **Performance Budgets Summary** | 58d? | 2007-01-31 | 2007-04-20 |  | 151d |  |  |  | 160h | 11,106.2 |  |
| 165 | 3.1.1.13.1 | Performance Budgets Summary Ver 1 | 20d? | 2007-01-31 | 2007-02-27 | 154, 157, 158, 161 | 173d | 0d | start no earlier than 2007-01-15 | Dekany [25%]; Neyman [37.5%] | 100h | 6,990.8 |  |
| 166 | 3.1.1.13.2 | Performance Budgets Summary Ver 2 | 25d? | 2007-03-19 | 2007-04-20 | 154, 157, 158, 159, 160, 161, 162, 163, 150, 151 | 151d | 25d |  | Dekany [10%]; Neyman [20%] | 60h | 4,115.4 |  |
| 167 | 3.1.1.14 | **Science Products** | 52d? | 2007-07-16 | 2007-09-25 |  | 170d |  |  |  | 350h | 22,293.1 |  |
| 168 | 3.1.1.14.1 | All-In Science Simulations | 20d? | 2007-07-16 | 2007-08-10 | 166 | 183.25d | 0d | start no earlier than 2007-07-16 | Neyman [50%]; Flicker [50%] | 160h | 9,920 |  |
| 169 | 3.1.1.14.2 | **Additional Science Characterization Results** | 32d? | 2007-08-13 | 2007-09-25 |  | 170d |  |  |  | 190h | 12,373.1 |  |
| 170 | 3.1.1.14.2.1 | Point Source Sensitivities | 18.75d? | 2007-08-13 | 2007-09-06 | 168 | 183.25d |  | start no earlier than 2007-04-02 | Bouchez [20%] | 30h | 2,453.1 |  |
| 171 | 3.1.1.14.2.2 | PSF Uniformity & Stability | 15d? | 2007-08-13 | 2007-08-31 | 168 | 187d |  | start no earlier than 2007-04-02 | Neyman [66.7%] | 80h | 4,960 |  |
| 172 | 3.1.1.14.2.3 | Other | 15d? | 2007-09-05 | 2007-09-25 | 168 | 170d |  | start no earlier than 2007-09-05 | Other [66.7%] | 80h | 4,960 | resource |
| 173 | 3.1.2 | **Trade Studies** | 160d? | 2006-10-16 | 2007-05-25 |  | 115.5d |  |  |  | 1900h | 124,998.55 |  |
| 174 | 3.1.2.1 | **System Architecture Trade Studies** | 120d? | 2006-10-16 | 2007-03-30 |  | 166d | 40d |  |  | 730h | 42,672.4 |  |
| 175 | 3.1.2.1.1 | MOAO & MCAO TS | 25d? | 2006-11-13 | 2006-12-15 |  | 241d |  | finish no earlier than 2006-12-15 |  | 80h |  |  |
| 176 | 3.1.2.1.2 | NGAO versus Keck AO upgrades TS (meeting 5) | 20d? | 2007-02-05 | 2007-03-02 |  | 186d |  | start no earlier than 2007-02-05 | Neyman [37.5%]; Wizinowich [25%] | 100h | 6,200 |  |
| 177 | 3.1.2.1.3 | Adaptive Secondary Mirror option TS (m5) | 20d? | 2007-03-05 | 2007-03-30 |  | 166d |  | start no earlier than 2007-03-05 | Other [15%]; Wizinowich [10%] | 40h | 2,480 | lead,moved |
| 178 | 3.1.2.1.4 | K & L-band Science TS (m5) | 20d? | 2007-02-05 | 2007-03-02 |  | 186d |  | start no earlier than 2007-02-05 | Bouchez [25%] | 40h | 3,270.8 | AB back |
| 179 | 3.1.2.1.5 | Keck Interferometer Support TS (m5) | 100d? | 2006-10-16 | 2007-03-02 |  | 186d |  | start no earlier than 2006-10-16 | Neyman [22.5%]; Wizinowich [2.5%] | 160h | 9,920 |  |
| 180 | 3.1.2.1.6 | Instrument Balance TS | 20d? | 2006-11-13 | 2006-12-08 |  | 246d |  | start no earlier than 2006-11-13 | Adkins [6.2%] | 10h | 620 |  |
| 181 | 3.1.2.1.7 | GLAO for non-NGAO Instruments TS (m5) | 20d? | 2007-02-05 | 2007-03-02 |  | 186d |  | start no earlier than 2007-02-05 | Flicker [12.5%] | 20h | 1,240 |  |
| 182 | 3.1.2.1.8 | Science Instrument Re-use Cost/Benefit TS (m3) | 20d? | 2006-11-13 | 2006-12-08 |  | 246d |  | start no earlier than 2006-11-13 | Adkins [25%]; Moore [50%] | 120h | 9,021.6 |  |
| 183 | 3.1.2.1.9 | Telescope Wavefront Errors TS | 13d? | 2006-12-04 | 2006-12-20 | 141, 142 | 177d | 4d | finish no earlier than 2006-12-20 | Neyman [38.5%]; Flicker [38.5%] | 80h | 4,960 |  |
| 184 | 3.1.2.1.10 | Observing Model TS | 45d? | 2006-11-13 | 2007-01-12 |  | 221d |  | finish no earlier than 2007-01-12 | Le Mignant [22.2%] | 80h | 4,960 |  |

Notes:
- 154: RD
- 155: RD
- 156: RD
- 157: DG
- 158: MB
- 159: CN
- 160: MI
- 161: BM
- 162: DLM
- 163: EJ
- 165: RD
- 166: RD
- 168: CN
- 170: AB
- 171: CN
- 173: RD
- 175: DG
- 176: PW
- 177: PW
- 178: AB
- 179: CN
- 180: SA
- 181: RF
- 182: SA
- 183: CN
- 184: DLM

| ID | WBS | Task | Duration | Start | Finish | Predecessors | Total slack | Free slack | Constraint | Resources | Work | Cost | Text1 |
| --- | --- | --- | --- | --- | --- | --- | --- | --- | --- | --- | --- | --- | --- |
| 185 | 3.1.2.2 | **Adaptive Optics System Trade Studies** | 150d? | 2006-10-30 | 2007-05-25 |  | 105.5d | 0d |  |  | 950h | 66,709.15 |  |
| 186 | 3.1.2.2.1 | AO Enclosure Temperature TS (m6) | 74d? | 2007-01-02 | 2007-04-13 |  | 156d |  | start no earlier than 2007-01-02 | Bouchez [5.1%]; Meguro [6.8%]; Other [5.1%] | 100h | 6,793.1 |  |
| 187 | 3.1.2.2.2 | Optical Relay TS (m6) | 74d? | 2007-01-02 | 2007-04-13 |  | 91.75d | 0d | finish no earlier than 2007-04-13 | Bauman [5.1%]; Dekany [5.1%] | 60h | 4,313.1 |  |
| 188 | 3.1.2.2.3 | Field Rotation Strategy TS (m6) | 74d? | 2007-01-02 | 2007-04-13 |  | 97.25d | 0d | start no earlier than 2007-01-02 | Bauman [10.1%]; Meguro [3.4%] | 80h | 4,960 |  |
| 189 | 3.1.2.2.4 | Dichroics & Beamsplitters TS (m6) | 74d? | 2007-01-02 | 2007-04-13 |  | 124.75d | 0d | start no earlier than 2007-01-02 | Velur [10.1%] | 60h | 4,906.2 |  |
| 190 | 3.1.2.2.5 | Rayleigh Rejection TS (m3) | 30d? | 2006-10-30 | 2006-12-08 |  | 246d |  | start no earlier than 2006-10-30 | Kellner [16.7%] | 40h | 2,480 |  |
| 191 | 3.1.2.2.6 | LGS WFS Type TS (m4) | 35d? | 2006-12-04 | 2007-01-19 |  | 108d | 60d | start no earlier than 2006-12-04 | Velur [10.7%] | 30h | 2,453.1 |  |
| 192 | 3.1.2.2.7 | LGS WFS number of subapertures TS (m4) | 35d? | 2006-12-04 | 2007-01-19 |  | 108d | 60d | start no earlier than 2006-12-04 | Velur [7.1%] | 20h | 1,635.4 |  |
| 193 | 3.1.2.2.8 | Slow WFS TS (m7) | 25d? | 2007-04-23 | 2007-05-25 |  | 48d | 0d | start no earlier than 2007-04-23 | Velur [40%] | 80h | 6,541.6 |  |
| 194 | 3.1.2.2.9 | LOWFS Architecture TS | 62.5d? | 2006-12-04 | 2007-02-28 |  | 80.5d | 32.5d | start no earlier than 2006-12-04 | Kellner [71.4%]; Velur [20%] | 200h | 14,377 |  |
| 195 | 3.1.2.2.10 | Number & Type of LOWFS TS (m4) | 40d? | 2006-12-04 | 2007-01-26 |  | 103d | 55d | start no earlier than 2006-12-04 | Kellner [21.4%]; Velur [9.4%] | 60h | 4,313.1 |  |
| 196 | 3.1.2.2.11 | Centroid Anisoplanatism TS (m7) | 25d? | 2007-04-23 | 2007-05-25 |  | 126d |  | start no earlier than 2007-04-23 | Kellner [20%] | 40h | 2,480 |  |
| 197 | 3.1.2.2.12 | Deformable Mirror Stroke Requirement TS (m6) | 74d? | 2007-01-02 | 2007-04-13 |  | 156d |  | start no earlier than 2007-01-02 | Flicker [8.4%] | 50h | 3,100 |  |
| 198 | 3.1.2.2.13 | Stand-alone vs DM on T/T Stage TS (m3) | 30d? | 2006-10-30 | 2006-12-08 |  | 246d |  | start no earlier than 2006-10-30 | Bauman [25%] | 60h | 3,720 |  |
| 199 | 3.1.2.2.14 | Correcting Fast T/T with DM TS | 30d? | 2006-10-30 | 2006-12-08 |  | 246d |  | finish no earlier than 2006-12-08 | Bauman [8.3%]; Flicker [8.3%] | 40h | 2,480 |  |
| 200 | 3.1.2.2.15 | Focus Compensation TS (m6) | 74d? | 2007-01-22 | 2007-05-03 |  | 142d |  | start no earlier than 2007-01-22 | Kellner [2.5%]; Velur [2.5%] | 30h | 2,156.55 | SK,VV |
| 201 | 3.1.2.3 | **Laser Facility Trade Studies** | 101d? | 2006-10-16 | 2007-03-05 |  | 157d | 0d |  |  | 220h | 15,617 |  |
| 202 | 3.1.2.3.1 | Laser Pulse Format TS (m6) | 20d? | 2007-01-02 | 2007-01-29 |  | 157d | 0d | start no earlier than 2007-01-02 | Velur [50%] | 80h | 6,541.6 |  |
| 203 | 3.1.2.3.2 | Free Space vs Fiber TS (m7) | 25d? | 2007-01-30 | 2007-03-05 | 202 | 157d | 0d |  | Neyman [50%] | 100h | 6,200 |  |
| 204 | 3.1.2.3.3 | LGS Asterism Geometry & Size TS (m2) | 5d? | 2006-10-23 | 2006-10-27 |  | 248d | 91d | finish no earlier than 2006-10-27 | Flicker [50%] | 20h | 1,240 |  |
| 205 | 3.1.2.3.4 | Variable vs fixed LGS Asterism Cost/Benefit TS (m2) | 10d? | 2006-10-16 | 2006-10-27 |  | 248d |  | finish no earlier than 2006-10-27 | Velur [25%] | 20h | 1,635.4 |  |
| 206 | 3.1.3 | **System Architecture** | 218d? | 2007-02-28 | 2007-12-28 |  | 102d |  |  |  | 1260h | 80,690.1 |  |
| 207 | 3.1.3.1 | System Architecture Ver 1 | 36d? | 2007-02-28 | 2007-04-18 | 165 | 173d | 0d | start no earlier than 2006-11-01 | Dekany [10.4%]; Gavel [10.4%]; Wizinowich [6.9%] | 80h | 5,553.1 | lead |
| 208 | 3.1.3.2 | System Architecture Ver 2 | 20d? | 2007-05-28 | 2007-06-22 | 166, 174, 185, 201 | 126d | 90d |  | Dekany [12.5%]; Gavel [12.5%]; Wizinowich [12.5%] | 60h | 4,115.4 | lead |

Notes:
- 186: AB
- 187: RD
- 188: BB
- 189: VV
- 190: VV
- 191: VV
- 192: VV
- 193: VV
- 194: SK
- 195: SK
- 196: SK
- 197: RF
- 198: BB
- 199: BB
- 200: SK
- 202: VV
- 203: CN
- 204: RF
- 205: VV
- 206: RD
- 207: RD
- 208: RD

| ID | WBS | Task | Duration | Start | Finish | Predecessors | Total slack | Free slack | Constraint | Resources | Work | Cost | Text1 |
| --- | --- | --- | --- | --- | --- | --- | --- | --- | --- | --- | --- | --- | --- |
| 209 | 3.1.3.3 | **Functional Requirements** | 162d? | 2007-04-19 | 2007-11-30 |  | 36d | 0d |  |  | 1000h | 63,581.6 |  |
| 210 | 3.1.3.3.1 | AO System Functional Requirements Ver 1 | 17.25d? | 2007-04-19 | 2007-05-14 | 207 | 180.75d |  | finish no earlier than 2007-02-02 | Neyman [54.3%]; Chin [18.1%]; Stomski [18.1%]; Meguro [18.1%]; Bauman [18.1%]; Johansson [18.1%] | 200h | 12,400 |  |
| 211 | 3.1.3.3.2 | AO System Functional Requirements Ver 2 | 25d? | 2007-10-29 | 2007-11-30 | 208 | 36d |  | start no earlier than 2007-10-29 | Neyman [12.5%]; Chin [7.5%]; Stomski [7.5%]; Meguro [7.5%]; Bauman [7.5%]; Johansson [7.5%] | 100h | 6,200 |  |
| 212 | 3.1.3.3.3 | Laser System Functional Requirements Ver 1 | 20d? | 2007-04-19 | 2007-05-16 | 207 | 178d |  | finish no earlier than 2007-03-02 | Chin [34.4%]; Velur [34.4%]; Stomski [15.6%] | 135h | 9,457.35 |  |
| 213 | 3.1.3.3.4 | Laser System Functional Requirements Ver 2 | 25d? | 2007-10-29 | 2007-11-30 | 208 | 36d |  | start no earlier than 2007-10-29 | Chin [12.5%]; Velur [12.5%]; Stomski [7.5%] | 65h | 4,524.25 | ch start |
| 214 | 3.1.3.3.5 | Science Operations Functional Requirements Ver 1 | 24d? | 2007-04-19 | 2007-05-22 | 207 | 174d |  | finish no earlier than 2007-02-02 | Le Mignant [20.8%]; Other [31.2%] | 100h | 6,200 |  |
| 215 | 3.1.3.3.6 | Science Operations Functional Requirements Ver 2 | 25d? | 2007-10-29 | 2007-11-30 | 208 | 36d |  | start no earlier than 2007-10-29 | Le Mignant [20%]; Other [30%] | 100h | 6,200 |  |
| 216 | 3.1.3.3.7 | Science Instruments Functional Requirements Ver 1 | 24d? | 2007-04-19 | 2007-05-22 | 207 | 174d |  | start no earlier than 2007-01-02 | Adkins [20.8%]; Other [41.7%] | 120h | 7,440 |  |
| 217 | 3.1.3.3.8 | Science Instruments Functional Requirements Ver 2 | 25d? | 2007-10-29 | 2007-11-30 | 208 | 36d |  | start no earlier than 2007-10-29 | Adkins [20%]; Other [70%] | 180h | 11,160 |  |
| 218 | 3.1.3.4 | Technology Drivers Summary | 3.63d? | 2007-05-28 | 2007-05-31 | 207, 166, 174, 185, 201 | 187.37d | 0d |  | Neyman [82.7%]; Gavel [55.1%] | 40h | 2,480 |  |
| 219 | 3.1.3.5 | Technical Risk Analysis Ver 1 | 23d? | 2007-05-31 | 2007-07-03 | 218 | 230.37d |  | start no earlier than 2007-03-19 | Neyman [13%]; Gavel [8.7%] | 40h | 2,480 |  |
| 220 | 3.1.3.6 | Technical Risk Analysis Ver 2 | 20d? | 2007-12-03 | 2007-12-28 | 209 | 36d | 0d | finish no earlier than 2007-12-28 | Neyman [15%]; Gavel [10%] | 40h | 2,480 | ch end; pred |
| 221 | 3.2 | **AO System** | 223d? | 2007-02-05 | 2007-12-12 |  | 48d | 12d |  |  | 1780h | 114,116.3 |  |
| 222 | 3.2.1 | AO System Architecture | 45d? | 2007-04-19 | 2007-06-20 | 207 | 173d |  | start no earlier than 2007-02-05 | Neyman [33.3%]; Other [35.4%] | 240h | 14,880 | DG volunteer |
| 223 | 3.2.2 | AO Enclosure | 70d? | 2007-05-14 | 2007-08-17 | 226SS+4w | 131d |  |  | Meguro [17.9%] | 100h | 6,200 | Meguro |
| 224 | 3.2.3 | **Opto-mechanical** | 203d? | 2007-03-05 | 2007-12-12 |  | 48d |  |  |  | 700h | 47,156.3 | lead? |
| 225 | 3.2.3.1 | Field Rotation | 82.5d? | 2007-04-16 | 2007-08-08 | 188 | 97.25d | 5.5d | finish no earlier than 2007-06-29 | Bauman [4.5%]; Lockwood [2.3%] | 45h | 2,790 | JM -> CL |
| 226 | 3.2.3.2 | Optical Relay | 88d? | 2007-04-16 | 2007-08-15 | 187 | 91.75d | 0d | start no earlier than 2007-03-05 | Bauman [5.7%]; Lockwood [3.4%]; Dekany [2%] | 60h | 3,917.7 | JM -> CL |
| 227 | 3.2.3.3 | Optical Switchyard | 55d? | 2007-04-16 | 2007-06-29 | 189 | 124.75d | 33d | finish no earlier than 2007-06-29 | Bauman [5.7%]; Lockwood [5.7%] | 50h | 3,100 | JM -> CL |
| 228 | 3.2.3.4 | Optical Support Structure | 41.25d? | 2007-08-16 | 2007-10-12 | 225, 226, 227 | 91.75d |  | start no earlier than 2007-04-16 | Lockwood [9.1%]; Bauman [4.5%] | 45h | 2,790 | JM -> CL |
| 229 | 3.2.3.5 | **Wavefront Sensors** | 173d? | 2007-04-16 | 2007-12-12 |  | 48d |  |  |  | 240h | 17,054.7 | lead |
| 230 | 3.2.3.5.1 | High Order LGS Wavefront Sensors | 173d? | 2007-04-16 | 2007-12-12 | 191, 192 | 48d |  | start no earlier than 2007-04-16 | Velur [4.3%]; Meguro [1.4%] | 80h | 6,146.2 |  |
| 231 | 3.2.3.5.2 | High Order NGS Wavefront Sensor | 173d? | 2007-04-16 | 2007-12-12 |  | 48d |  | start no earlier than 2007-04-16 | Velur [2.2%]; Meguro [0.7%] | 40h | 3,073.1 |  |
| 232 | 3.2.3.5.3 | Low Order NGS Wavefront Sensors | 173d? | 2007-04-16 | 2007-12-12 | 194, 195 | 48d |  | finish no earlier than 2007-12-12 | Kellner [2.9%]; Meguro [1.4%]; Velur [1.4%] | 80h | 5,355.4 | added VV |
| 233 | 3.2.3.5.4 | Calibration Wavefront Sensor | 143d? | 2007-05-28 | 2007-12-12 | 193 | 48d |  | start no earlier than 2007-04-16 | Kellner [3.5%] | 40h | 2,480 |  |

Notes:
- 210: CN
- 211: CN
- 212: JC
- 213: JC
- 214: DLM
- 215: DLM
- 216: SA
- 217: SA
- 218: DG
- 219: DG
- 220: DG
- 221: DG
- 222: DG
- 223: JM
- 224: BB
- 225: BB
- 226: BB
- 227: BB
- 228: BB
- 229: VV
- 230: VV
- 231: VV
- 232: SK
- 233: SK

| ID | WBS | Task | Duration | Start | Finish | Predecessors | Total slack | Free slack | Constraint | Resources | Work | Cost | Text1 |
| --- | --- | --- | --- | --- | --- | --- | --- | --- | --- | --- | --- | --- | --- |
| 234 | 3.2.3.6 | **Wavefront Correctors** | 85d? | 2007-03-05 | 2007-06-29 |  | 166d |  |  |  | 140h | 9,273.1 | lead |
| 235 | 3.2.3.6.1 | Tip/Tilt Corrector | 85d? | 2007-03-05 | 2007-06-29 |  | 166d |  | start no earlier than 2007-03-05 | Flicker [1.5%]; Bauman [1.5%] | 20h | 1,240 | added BB |
| 236 | 3.2.3.6.2 | Deformable Mirror | 85d? | 2007-03-05 | 2007-06-29 |  | 166d |  | start no earlier than 2007-03-05 | Flicker [5.9%]; Bauman [11.8%]; Dekany [15%] | 120h | 8,033.1 | lead |
| 237 | 3.2.3.7 | **Acquisition Cameras** | 125d? | 2007-03-05 | 2007-08-24 |  | 126d |  |  |  | 40h | 3,270.8 | lead |
| 238 | 3.2.3.7.1 | NGS Acquisition Camera | 125d? | 2007-03-05 | 2007-08-24 |  | 126d |  | start no earlier than 2007-03-05 | Bouchez [2%] | 20h | 1,635.4 |  |
| 239 | 3.2.3.7.2 | LGS Acquisition Camera | 125d? | 2007-03-05 | 2007-08-24 |  | 126d |  | start no earlier than 2007-03-05 | Bouchez [2%] | 20h | 1,635.4 |  |
| 240 | 3.2.3.8 | Atmospheric Dispersion Correction | 85d? | 2007-03-05 | 2007-06-29 |  | 166d |  | start no earlier than 2007-03-05 | Kellner [2.9%] | 20h | 1,240 |  |
| 241 | 3.2.3.9 | Alignment, Calibration, Diagnostics, Metrology and Monitoring | 85d? | 2007-03-05 | 2007-06-29 |  | 166d |  | finish no earlier than 2007-06-29 | Neyman [4.4%]; Flicker [4.4%] | 60h | 3,720 |  |
| 242 | 3.2.4 | **Non-real-time Control** | 125d? | 2007-05-01 | 2007-10-22 |  | 85d |  |  |  | 400h | 24,800 | lead |
| 243 | 3.2.4.1 | Non-RTC Software | 51.2d? | 2007-05-17 | 2007-07-27 |  | 146d |  | finish no earlier than 2007-07-27 | Johansson [19.5%]; Stomski [19.5%]; Johnson [9.8%] | 200h | 12,400 |  |
| 244 | 3.2.4.2 | Non-RTC Electronics | 125d? | 2007-05-01 | 2007-10-22 |  | 85d |  | start no earlier than 2007-05-01 | Chin [10%]; Reinig [10%] | 200h | 12,400 | added MR |
| 245 | 3.2.5 | **Real-time Control** | 110d? | 2007-02-05 | 2007-07-06 |  | 161d |  |  |  | 340h | 21,080 |  |
| 246 | 3.2.5.1 | RTC Architecture Analysis and Design Study | 43d? | 2007-02-05 | 2007-04-04 |  | 161d | 0d | start no earlier than 2007-02-05 | Gavel [5.8%]; Johansson [11.6%]; Flicker [11.6%]; Reinig [23.3%] | 180h | 11,160 | Added MR |
| 247 | 3.2.5.2 | RTC Software Module Definition | 67d? | 2007-04-05 | 2007-07-06 | 246 | 161d |  |  | Johansson [11.2%]; Reinig [3.7%] | 80h | 4,960 | Added MR |
| 248 | 3.2.5.3 | RTC Hardware Module Definition | 67d? | 2007-04-05 | 2007-07-06 | 246 | 161d |  |  | Johansson [3.7%]; Reinig [11.2%] | 80h | 4,960 | Added MR |
| 249 | 3.3 | **Laser Facility** | 109d? | 2007-03-06 | 2007-08-03 |  | 141d | 105d |  |  | 750h | 52,035.6 | Discuss; JC? |
| 250 | 3.3.1 | Laser System Architecture | 50d? | 2007-03-06 | 2007-05-14 | 154, 157, 201 | 157d | 0d |  | Velur [20%] | 80h | 6,541.6 |  |
| 251 | 3.3.2 | Laser Enclosure | 43d? | 2007-05-15 | 2007-07-12 | 250 | 157d |  |  | Meguro [23.3%] | 80h | 4,960 | JB->JM |
| 252 | 3.3.3 | Laser | 35d? | 2007-05-15 | 2007-07-02 | 250 | 165d |  | start no earlier than 2007-03-05 | Velur [35.7%] | 100h | 8,177 | VV resource |
| 253 | 3.3.4 | **Laser Launch Facility** | 40d? | 2007-03-06 | 2007-04-30 |  | 210d |  |  |  | 300h | 20,577 | lead |
| 254 | 3.3.4.1 | Laser Beam Transport | 40d? | 2007-03-06 | 2007-04-30 | 202, 203 | 210d |  |  | Neyman [10.9%]; Kellner [6.2%]; Chin [1.6%] | 60h | 3,720 |  |
| 255 | 3.3.4.2 | Laser Pointing & Diagnostics | 40d? | 2007-03-06 | 2007-04-30 | 202, 203 | 210d |  |  | Velur [21.9%]; Kellner [21.9%]; Chin [6.2%] | 120h | 8,428.5 | CN-> VV |
| 256 | 3.3.4.3 | Laser Launch Telescope | 28.12d? | 2007-03-06 | 2007-04-13 | 204, 202, 203 | 221.88d |  |  | Velur [22.2%]; Kellner [22.2%]; Chin [11.1%] | 120h | 8,428.5 | CN-> VV |
| 257 | 3.3.5 | **Laser Safety Systems** | 20d? | 2007-07-09 | 2007-08-03 |  | 141d |  |  |  | 40h | 2,480 | lead |
| 258 | 3.3.5.1 | Personnel and Equipment Safety Systems | 20d? | 2007-07-09 | 2007-08-03 |  | 141d |  | start no earlier than 2007-07-09 | Chin [12.5%] | 20h | 1,240 |  |
| 259 | 3.3.5.2 | Aircraft, Satellite & Laser Traffic Control Safety Systems | 20d? | 2007-07-09 | 2007-08-03 |  | 141d |  | start no earlier than 2007-07-09 | Chin [12.5%] | 20h | 1,240 |  |

Notes:
- 234: BB
- 235: BB
- 236: BB
- 237: AB
- 238: AB
- 239: AB
- 240: SK
- 241: CN
- 242: JC
- 243: EJ
- 244: JC
- 245: DG
- 246: DG
- 247: EJ
- 248: MR
- 250: VV
- 251: JM
- 252: VV
- 253: VV
- 254: CN
- 255: VV
- 256: VV
- 257: JC
- 258: JC
- 259: JC

| ID | WBS | Task | Duration | Start | Finish | Total slack | Free slack | Constraint | Resources | Work | Cost | Text1 |
| --- | --- | --- | --- | --- | --- | --- | --- | --- | --- | --- | --- | --- |
| 260 | 3.3.6 | **Laser System Control** | 85d? | 2007-04-09 | 2007-08-03 | 141d |  |  |  | 150h | 9,300 | lead |
| 261 | 3.3.6.1 | Laser System Software | 85d? | 2007-04-09 | 2007-08-03 | 141d |  | start no earlier than 2007-04-09 | Johansson [5.9%]; Stomski [5.9%] | 80h | 4,960 |  |
| 262 | 3.3.6.2 | Laser System Electronics | 85d? | 2007-04-09 | 2007-08-03 | 141d |  | start no earlier than 2007-04-09 | Chin [10.3%] | 70h | 4,340 |  |
| 263 | 3.4 | **Science Operations** | 154d? | 2007-01-02 | 2007-08-03 | 141d | 105d |  |  | 670h | 41,540 |  |
| 264 | 3.4.1 | **Astronomical Observations Operations** | 108d? | 2007-03-01 | 2007-07-30 | 145d |  |  |  | 220h | 13,640 |  |
| 265 | 3.4.1.1 | **Pre-Observing Interfaces** | 22d? | 2007-05-01 | 2007-05-30 | 188d |  |  |  | 60h | 3,720 |  |
| 266 | 3.4.1.1.1 | AO Guide Star Interface | 22d? | 2007-05-01 | 2007-05-30 | 188d |  | finish no earlier than 2007-05-30 | Other [11.4%] | 20h | 1,240 | resources |
| 267 | 3.4.1.1.2 | Science Observations Simulation Tools | 22d? | 2007-05-01 | 2007-05-30 | 188d |  | start no earlier than 2007-05-01 | Other [22.7%] | 40h | 2,480 |  |
| 268 | 3.4.1.2 | **Observing Interfaces** | 43d? | 2007-03-01 | 2007-04-30 | 210d |  |  |  | 80h | 4,960 |  |
| 269 | 3.4.1.2.1 | Acquisition | 43d? | 2007-03-01 | 2007-04-30 | 210d |  | finish no earlier than 2007-04-30 | Other [5.8%] | 20h | 1,240 |  |
| 270 | 3.4.1.2.2 | Observing Sequences | 43d? | 2007-03-01 | 2007-04-30 | 210d |  | start no earlier than 2007-03-01 | Other [5.8%] | 20h | 1,240 |  |
| 271 | 3.4.1.2.3 | Instrument, AO & Telescope Observer Interfaces | 43d? | 2007-03-01 | 2007-04-30 | 210d |  | start no earlier than 2007-03-01 | Other [5.8%] | 20h | 1,240 |  |
| 272 | 3.4.1.2.4 | Science Data Quality Monitoring | 43d? | 2007-03-01 | 2007-04-30 | 210d |  | start no earlier than 2007-03-01 | Other [5.8%] | 20h | 1,240 |  |
| 273 | 3.4.1.3 | **Post-Observing Interfaces** | 42d? | 2007-06-01 | 2007-07-30 | 145d |  |  |  | 80h | 4,960 |  |
| 274 | 3.4.1.3.1 | Generic Data Products | 42d? | 2007-06-01 | 2007-07-30 | 145d |  | finish no earlier than 2007-07-30 | Other [6%] | 20h | 1,240 |  |
| 275 | 3.4.1.3.2 | Science Data Quality Assessment | 42d? | 2007-06-01 | 2007-07-30 | 145d |  | start no earlier than 2007-06-01 | Other [6%] | 20h | 1,240 |  |
| 276 | 3.4.1.3.3 | Science Data Archiving | 42d? | 2007-06-01 | 2007-07-30 | 145d |  | start no earlier than 2007-06-01 | Other [11.9%] | 40h | 2,480 |  |
| 277 | 3.4.2 | **AO-Instrument Operations** | 154d? | 2007-01-02 | 2007-08-03 | 141d |  |  |  | 450h | 27,900 |  |
| 278 | 3.4.2.1 | **AO-Instrument Operations Architecture** | 154d? | 2007-01-02 | 2007-08-03 | 141d |  |  |  | 270h | 16,740 |  |
| 279 | 3.4.2.1.1 | AO-Instrument Observing Modes | 24d? | 2007-01-02 | 2007-02-02 | 271d |  | start no earlier than 2007-01-02 | Le Mignant [20.8%]; Other [20.8%] | 80h | 4,960 |  |
| 280 | 3.4.2.1.2 | AO-Instrument Operations Support | 83d? | 2007-02-05 | 2007-05-30 | 188d |  | finish no earlier than 2007-05-30 | Other [3%] | 20h | 1,240 |  |
| 281 | 3.4.2.1.3 | AO-Instrument Configuration & Setup | 83d? | 2007-02-05 | 2007-05-30 | 188d |  | start no earlier than 2007-02-05 | Other [3%] | 20h | 1,240 |  |
| 282 | 3.4.2.1.4 | AO-Instrument Calibrations | 83d? | 2007-02-05 | 2007-05-30 | 188d |  | start no earlier than 2007-02-05 | Other [3%] | 20h | 1,240 |  |
| 283 | 3.4.2.1.5 | AO-Instrument Nighttime Operation Modes | 83d? | 2007-02-05 | 2007-05-30 | 188d |  | start no earlier than 2007-02-05 | Other [3%] | 20h | 1,240 |  |
| 284 | 3.4.2.1.6 | AO-Instrument Science Acquisition & Control | 83d? | 2007-02-05 | 2007-05-30 | 188d |  | start no earlier than 2007-02-05 | Other [3%] | 20h | 1,240 |  |
| 285 | 3.4.2.1.7 | AO-Instrument Health Monitoring & Automated Recovery | 83d? | 2007-02-05 | 2007-05-30 | 188d |  | start no earlier than 2007-02-05 | Other [3%] | 20h | 1,240 |  |
| 286 | 3.4.2.1.8 | AO-Instrument Laser Traffic Control | 20d? | 2007-07-09 | 2007-08-03 | 141d |  | start no earlier than 2007-07-09 | Summers [6.2%] | 10h | 620 |  |
| 287 | 3.4.2.1.9 | AO-Instrument User Interfaces | 20d? | 2007-06-04 | 2007-06-29 | 166d |  | finish no earlier than 2007-06-29 | Other [25%] | 40h | 2,480 |  |
| 288 | 3.4.2.1.10 | AO-Instrument Maintenance Plan | 20d? | 2007-07-02 | 2007-07-27 | 146d |  | finish no earlier than 2007-07-27 | Other [12.5%] | 20h | 1,240 |  |

Notes:
- 260: JC
- 261: EJ
- 262: JC
- 263: DLM
- 264: DLM
- 277: DLM
- 278: DLM
- 279: DLM
- 286: DS

| ID | WBS | Task | Duration | Start | Finish | Predecessors | Total slack | Free slack | Constraint | Resources | Work | Cost | Text1 |
| --- | --- | --- | --- | --- | --- | --- | --- | --- | --- | --- | --- | --- | --- |
| 289 | 3.4.2.2 | **AO-Instrument Operations Optimization** | 45d? | 2007-03-05 | 2007-05-04 |  | 206d |  |  |  | 180h | 11,160 |  |
| 290 | 3.4.2.2.1 | AO-Instrument Performance Prediction | 30d? | 2007-03-05 | 2007-04-13 |  | 221d |  | start no earlier than 2007-03-05 | Flicker [25%]; Other [8.3%] | 80h | 4,960 |  |
| 291 | 3.4.2.2.2 | AO-Instrument Real-Time Optimization | 30d? | 2007-03-05 | 2007-04-13 |  | 221d |  | start no earlier than 2007-03-05 | Flicker [25%]; Other [8.3%] | 80h | 4,960 |  |
| 292 | 3.4.2.2.3 | AO-Instrument Environment Monitoring | 15d? | 2007-04-16 | 2007-05-04 |  | 206d |  | finish no earlier than 2007-05-04 | Other [16.7%] | 20h | 1,240 |  |
| 293 | 3.5 | **Science Instruments** | 251d? | 2006-10-02 | 2007-09-17 |  | 110d | 74d |  |  | 1300h | 80,600 |  |
| 294 | 3.5.1 | OSIRIS | 66.67d? | 2006-12-01 | 2007-03-05 |  | 250.33d |  | start no earlier than 2006-12-01 | Adkins [3%]; Other [24.4%] | 100h | 6,200 |  |
| 295 | 3.5.2 | Interferometer | 130d? | 2006-10-02 | 2007-03-30 |  | 231d |  | start no earlier than 2006-10-02 | Adkins [1.5%]; Neyman [7.7%]; Other [10%] | 100h | 6,200 |  |
| 296 | 3.5.3 | OHANA | 50d? | 2007-02-01 | 2007-04-11 |  | 223d |  | start no earlier than 2007-02-01 | Adkins [2%]; Other [11.2%]; Woillez [15%] | 50h | 3,100 |  |
| 297 | 3.5.4 | Near-IR Imager | 150d? | 2006-10-02 | 2007-04-27 |  | 211d |  | start no earlier than 2006-10-02 | Adkins [2%]; Other [31.6%] | 200h | 12,400 |  |
| 298 | 3.5.5 | Visible Imager | 150d? | 2006-10-02 | 2007-04-27 |  | 211d |  | start no earlier than 2006-10-02 | Adkins [2%]; Other [31.6%] | 200h | 12,400 |  |
| 299 | 3.5.6 | Visible IFU | 100d? | 2007-01-02 | 2007-05-21 |  | 195d |  | start no earlier than 2007-01-02 | Adkins [2%]; Other [16.4%] | 100h | 6,200 |  |
| 300 | 3.5.7 | Deployable Near-IR IFU | 105d? | 2007-02-01 | 2007-06-27 |  | 168d |  | start no earlier than 2007-02-01 | Adkins [7.1%]; Other [35.7%]; Neyman [16.7%] | 500h | 31,000 | adjusted resour |
| 301 | 3.5.8 | Mid-IR IFU | 100d? | 2007-05-01 | 2007-09-17 |  | 110d |  | start no earlier than 2007-05-01 | Adkins [1%]; Other [23.9%] | 50h | 3,100 |  |
| 302 | 3.6 | System Design Manual | 24d? | 2007-12-31 | 2008-02-01 | 209, 220, 293, 164, 263, 218, 249, 221 | 36d | 0d | finish no earlier than 2008-01-18 | Wizinowich [20.8%]; Dekany [10.4%]; Gavel [10.4%] | 80h | 5,355.4 | pulled in |
| 303 | 4 | **Systems Engineering Management Plan (SEMP)** | 253d? | 2007-01-15 | 2008-01-02 |  | 58d |  |  |  | 986h | 64,374.28 |  |
| 304 | 4.1 | **Project Plan** | 59.25d? | 2007-09-17 | 2007-12-07 |  | 63d | 5d |  |  | 340h | 22,859.3 |  |
| 305 | 4.1.1 | Task Definition | 4.25d? | 2007-09-17 | 2007-09-21 |  | 118d |  | finish no earlier than 2007-09-21 | Wizinowich [58.8%]; Dekany [58.8%]; Gavel [58.8%]; Max [58.8%] | 80h | 5,355.4 |  |
| 306 | 4.1.2 | Cost Estimation | 10d? | 2007-10-22 | 2007-11-02 |  | 88d |  | finish no earlier than 2007-11-02 | Wizinowich [62.5%]; Dekany [62.5%]; Gavel [62.5%]; Other [62.5%] | 200h | 13,388.5 |  |
| 307 | 4.1.3 | Major Project Milestones | 2.5d? | 2007-11-09 | 2007-11-13 |  | 81d |  | finish no earlier than 2007-11-13 | Wizinowich [50%]; Dekany [50%] | 20h | 1,437.7 |  |
| 308 | 4.1.4 | MS Project Plan | 4.5d? | 2007-12-03 | 2007-12-07 |  | 63d |  | finish no earlier than 2007-12-07 | Wizinowich [27.8%]; Dekany [27.8%]; Gavel [27.8%]; Max [27.8%] | 40h | 2,677.7 |  |
| 309 | 4.2 | Risk Assessment & Management Plan | 23d? | 2007-11-14 | 2007-12-14 |  | 58d | 0d | finish no earlier than 2007-12-14 | Other [21.7%] | 40h | 2,480 |  |
| 310 | 4.3 | **Preliminary Design Phase Plan** | 140d? | 2007-02-05 | 2007-08-17 |  | 143d | 85d |  |  | 166h | 11,043.26 |  |
| 311 | 4.3.1 | Version 1 to Support Observatory FY08 Planning | 20d? | 2007-02-05 | 2007-03-02 |  | 263d |  | start no earlier than 2007-02-05 | Wizinowich [10%]; Dekany [6.2%]; Gavel [6.2%]; Max [3.8%] | 42h | 2,801.7 |  |
| 312 | 4.3.2 | Intermediate Versions | 30d? | 2007-04-09 | 2007-05-18 |  | 208d |  | start no earlier than 2007-04-09 | Wizinowich [7.5%]; Dekany [3.3%]; Gavel [3.3%]; Max [2.5%] | 40h | 2,638.16 |  |
| 313 | 4.3.3 | Final Version | 15d? | 2007-07-30 | 2007-08-17 |  | 143d |  | start no earlier than 2007-07-30 | Wizinowich [26.7%]; Dekany [16.7%]; Gavel [16.7%]; Max [10%] | 84h | 5,603.4 |  |

Notes:
- 293: SA
- 302: PW
- 303: PW
- 304: PW
- 305: PW
- 306: PW
- 307: PW
- 308: PW
- 310: PW
- 311: PW
- 312: PW
- 313: PW

| ID | WBS | Task | Duration | Start | Finish | Predecessors | Total slack | Free slack | Constraint | Resources | Work | Cost |
| --- | --- | --- | --- | --- | --- | --- | --- | --- | --- | --- | --- | --- |
| 314 | 4.4 | **Integration and Test Plans** | 187d? | 2007-03-12 | 2007-11-27 |  | 71d |  |  |  | 200h | 12,400 |
| 315 | 4.4.1 | **Subsystem Testing Plans** | 22d? | 2007-10-29 | 2007-11-27 |  | 71d | 13d |  |  | 100h | 6,200 |
| 316 | 4.4.1.1 | AO System Test Plan | 22d? | 2007-10-29 | 2007-11-27 |  | 71d |  | start no earlier than 2007-10-29 | Neyman [14.2%] | 25h | 1,550 |
| 317 | 4.4.1.2 | Laser System Test Plan | 22d? | 2007-10-29 | 2007-11-27 |  | 71d |  | start no earlier than 2007-10-29 | Neyman [14.2%] | 25h | 1,550 |
| 318 | 4.4.1.3 | Science Operations Test Plan | 22d? | 2007-10-29 | 2007-11-27 |  | 71d |  | start no earlier than 2007-10-29 | Neyman [14.2%] | 25h | 1,550 |
| 319 | 4.4.1.4 | Science Instruments Test Plan | 22d? | 2007-10-29 | 2007-11-27 |  | 71d |  | start no earlier than 2007-10-29 | Neyman [14.2%] | 25h | 1,550 |
| 320 | 4.4.2 | System Integration & Test Plans | 30d? | 2007-03-12 | 2007-04-20 |  | 228d | 170d | finish no earlier than 2007-04-20 | Neyman [41.7%] | 100h | 6,200 |
| 321 | 4.5 | Configuration Management Plan | 62.5d? | 2007-01-15 | 2007-04-11 |  | 235.5d | 177.5d | start no earlier than 2007-01-15 | Johnson [10%]; Other [10%]; Chin [5%] | 80h | 4,960 |
| 322 | 4.6 | Project Management Plan | 20d? | 2007-02-12 | 2007-03-09 |  | 258d | 200d | start no earlier than 2007-02-12 | Wizinowich [12.5%]; Dekany [12.5%]; Gavel [12.5%]; Max [12.5%] | 80h | 5,355.4 |
| 323 | 4.7 | SEMP Document | 13d? | 2007-12-17 | 2008-01-02 | 304, 310, 315, 320, 321, 322, 309 | 58d | 22d | finish no earlier than 2008-01-02 | Wizinowich [30.8%]; Dekany [15.4%]; Gavel [15.4%]; Max [15.4%] | 80h | 5,276.32 |

Notes:
- 314: CN
- 315: CN
- 316: CN
- 317: CN
- 318: CN
- 319: CN
- 320: CN
- 321: JJ
- 322: PW
- 323: PW
