# NGAO System Design Phase Schedule v16

Schedule from MS Project, 2006-06-21 to 2008-04-03, costs in $.
CARA

## Calendars

- Standard: Mon-Fri 08:00-12:00, 13:00-17:00; Sat-Sun off.

## Resources

| Resource | Group | Rate | Notes |
| --- | --- | --- | --- |
| Flicker | WMKO | 57.31 | AO Modeller |
| Gavel | UCSC | 70 | EC |
| Neyman | WMKO | 57.31 | AO |
| Dekany | COO | 88.89 | EC |
| Bouchez | COO | 88.89 | AO Scientist |
| Max | UCSC | 70 | EC, Science |
| Wizinowich | WMKO | 57.31 | EC |
| Britton | COO | 88.89 | AO Modeller |
| Moore | COO | 88.89 | Instrum Sci |
| Velur | COO | 88.89 | AO Scientist |
| Chin | WMKO | 57.31 | EE |
| Johansson | WMKO | 57.31 | SE, EE |
| Meguro | WMKO | 57.31 | ME |
| Stomski | WMKO | 57.31 | SE |
| Clare | WMKO | 62 | AO Modeller |
| Adkins | WMKO | 57.31 | Instruments |
| Bell | WMKO | 57.31 | ME |
| Sweeney | WMKO | 57.31 | MD |
| Kellner | WMKO | 57.31 | AO Postdoc |
| van Dam | WMKO | 57.31 | AO Scientist |
| Johnson | WMKO | 57.31 | SE |
| Bauman | UCSC | 70 | OE |
| Macintosh | UCSC | 70 | Science |
| Le Mignant | WMKO | 57.31 | Instrum Sci |
| Postdoc | UCSC | 40 | Science postdoc |
| Other |  | 62 | Unassigned |
| Cameron | COO |  | Grad student |
| Randolph | WMKO | 57.31 | MD |
| Summers | WMKO | 57.31 | SE |
| Woillez | WMKO | 57.31 | KI Scientist |
| Ammons | UCSC |  | Grad student |
| Kupke | UCSC |  | AO Postdoc |
| Lockwood | UCSC | 70 | ME |
| Reinig | UCSC | 70 | EE, ECE |
| Ireland | COO |  | Postdoc |
| Student1 |  | 31 | Grad student |
| Student2 |  | 31 | Grad student |
| Adkins(IPM) | WMKO |  | IPM |

## Schedule

| ID | WBS | Task | Type | Duration | Start | Finish | Predecessors | Total slack | Free slack | Constraint | Resources | Work | Cost | Text1 |
| --- | --- | --- | --- | --- | --- | --- | --- | --- | --- | --- | --- | --- | --- | --- |
| 1 | 1 | **SD Phase Management** |  | 467d? | 2006-06-21 | 2008-04-03 |  | 0d |  |  |  | 2175h | 148,093.21 |  |
| 2 | 1.1 | **Planning and Contracting** |  | 315.26d? | 2006-06-21 | 2007-09-05 |  | 151.74d |  |  |  | 230h | 13,980.35 |  |
| 3 | 1.1.1 | NGAO Proposal to SSC | milestone | 0d | 2006-06-21 | 2006-06-21 |  | 479d | 17d | start no earlier than 2006-06-21 |  |  |  |  |
| 4 | 1.1.2 | Management Structure Decision by Directors | milestone | 0d | 2006-07-14 | 2006-07-14 | 3 | 462d | 35d | start no earlier than 2006-07-14 |  |  |  |  |
| 5 | 1.1.3 | SD Phase System Engineering Management Plan |  | 21d? | 2006-09-01 | 2006-09-29 | 4 | 394d |  | finish no earlier than 2006-09-29 | Max [8.9%]; Gavel [8.9%]; Dekany [8.9%]; Wizinowich [20.8%] | 80h | 5,439.2 |  |
| 6 | 1.1.4 | SD Phase Contracts Generated |  | 23d? | 2006-09-27 | 2006-10-27 |  | 407d | 0d | start no earlier than 2006-09-27 | Adkins(IPM) [16.7%]; Gavel [8.3%]; Dekany [8.3%] | 60h | 2,383.35 |  |
| 7 | 1.1.5 | Director Approval | milestone | 0d | 2006-10-09 | 2006-10-09 |  | 407d | 0d | start no earlier than 2006-10-09 |  |  |  |  |
| 8 | 1.1.6 | SD Partner Contracts Issued | milestone | 0d | 2006-10-27 | 2006-10-27 | 6, 7 | 407d |  | start no earlier than 2006-10-13 |  |  |  |  |
| 9 | 1.1.7 | Mid-year Replan |  | 10d | 2007-03-05 | 2007-03-16 |  | 307d |  | start no earlier than 2007-03-05 | Wizinowich [22.5%]; Dekany [10%]; Gavel [10%]; Max [7.5%] | 40h | 2,722.7 |  |
| 10 | 1.1.8 | FY08 Replan |  | 13.33d | 2007-08-16 | 2007-09-05 | 305 | 184.74d |  |  | Wizinowich [28.1%]; Dekany [12.5%]; Gavel [12.5%]; Max [9.4%] | 50h | 3,435.1 | have new WBS; to help align FY08 work |
| 11 | 1.2 | **Project Meetings** |  | 467d? | 2006-06-21 | 2008-04-03 |  | 0d |  |  |  | 1352h | 97,179.68 |  |
| 12 | 1.2.1 | Executive Committee Telecons |  | 467d | 2006-06-21 | 2008-04-03 |  | 0d |  |  | Wizinowich [2.4%]; Dekany [2.4%]; Gavel [2.4%]; Max [2.4%] | 360h | 25,758 | ch end & time |
| 13 | 1.2.2 | Science Advisory Committee Telecons |  | 390d? | 2006-10-02 | 2008-03-28 |  | 37d |  | start no earlier than 2006-10-02 | Max [1.4%] | 40h | 2,800 |  |
| 14 | 1.2.3 | **Team Meetings** |  | 344.5d | 2006-09-14 | 2008-01-09 |  | 61.5d |  |  |  | 952h | 68,621.68 |  |
| 15 | 1.2.3.1 | Team Meeting #1 (mgmt, science & technical - Irvine) |  | 1d | 2006-09-14 | 2006-09-14 |  | 405d |  | start no earlier than 2006-09-14 | Wizinowich; Dekany; Gavel; Max; Bauman; Bouchez; Velur; Flicker; Neyman; Britton; Le Mignant | 68h | 4,782.48 |  |
| 16 | 1.2.3.2 | Team Meeting #2 (CIT) |  | 1d | 2006-11-07 | 2006-11-07 |  | 367d |  | start no earlier than 2006-11-07 | Wizinowich; Dekany; Gavel; Max; Bauman; Bouchez; Velur; Flicker; Neyman; Britton; Le Mignant | 80h | 5,773.6 |  |
| 17 | 1.2.3.3 | Team Videocon #3 |  | 0.5d | 2006-12-13 | 2006-12-13 |  | 341.5d |  | start no earlier than 2006-12-13 | Wizinowich; Dekany; Gavel; Max; Bauman; Bouchez; Velur; Flicker; Neyman; Britton; Le Mignant | 44h | 3,179.2 |  |
| 18 | 1.2.3.4 | Team Meeting #4 (Keck) |  | 1d | 2007-01-22 | 2007-01-22 |  | 313d |  | start no earlier than 2007-01-22 | Wizinowich; Dekany; Gavel; Max; Bauman; Bouchez; Velur; Flicker; Neyman; Britton; Le Mignant | 80h | 5,773.6 |  |
| 19 | 1.2.3.5 | Team Videocon #5 |  | 0.5d | 2007-03-07 | 2007-03-07 |  | 281.5d |  | start no earlier than 2007-03-07 | Wizinowich; Dekany; Gavel; Max; Bauman; Bouchez; Velur; Flicker; Neyman; Britton; Le Mignant | 44h | 3,179.2 |  |
| 20 | 1.2.3.6 | Team Meeting #6 (UCSC) |  | 1d | 2007-04-18 | 2007-04-18 |  | 251d |  | start no earlier than 2007-04-18 | Wizinowich; Dekany; Gavel; Max; Bauman; Bouchez; Velur; Flicker; Neyman; Britton; Le Mignant | 80h | 5,773.6 |  |
| 21 | 1.2.3.7 | Team Videocon #7 |  | 0.5d | 2007-05-30 | 2007-05-30 |  | 221d |  | finish no earlier than 2007-05-30 | Wizinowich; Dekany; Gavel; Max; Bauman; Bouchez; Velur; Flicker; Neyman; Britton; Le Mignant | 44h | 3,179.2 |  |
| 22 | 1.2.3.8 | Team Retreat #8 (UCSC) |  | 2.5d | 2007-07-09 | 2007-07-11 |  | 40.67d | 0d | start no earlier than 2007-07-09 | Wizinowich; Dekany; Gavel; Max; Bauman; Bouchez; Velur; Flicker; Neyman; Britton; Le Mignant | 220h | 15,896 |  |
| 23 | 1.2.3.9 | Team Videocon #9 |  | 0.5d | 2007-08-22 | 2007-08-22 |  | 161.5d |  | start no earlier than 2007-08-22 | Wizinowich; Dekany; Gavel; Max; Bauman; Bouchez; Velur; Flicker; Neyman; Britton; Le Mignant | 44h | 3,179.2 |  |
| 24 | 1.2.3.10 | Team Meeting #10 (CIT) |  | 1d | 2007-09-11 | 2007-09-11 |  | 147d |  | start no earlier than 2007-09-11 | Wizinowich; Dekany; Gavel; Max; Bauman; Bouchez; Velur; Flicker; Neyman; Britton; Le Mignant | 80h | 5,773.6 |  |
| 25 | 1.2.3.11 | Team Videocon #11 |  | 0.5d | 2007-11-05 | 2007-11-05 |  | 108.5d |  | start no earlier than 2007-11-05 | Wizinowich; Dekany; Gavel; Max; Bauman; Bouchez; Velur; Flicker; Neyman; Britton; Le Mignant | 44h | 3,179.2 |  |
| 26 | 1.2.3.12 | Team Meeting #12 (Keck) |  | 1d | 2007-12-12 | 2007-12-12 |  | 81d |  | start no earlier than 2007-12-12 | Wizinowich; Dekany; Gavel; Max; Bauman; Bouchez; Velur; Flicker; Neyman; Britton; Le Mignant | 80h | 5,773.6 |  |
| 27 | 1.2.3.13 | Team Videocon #13 |  | 0.5d | 2008-01-09 | 2008-01-09 |  | 61.5d |  | start no earlier than 2008-01-09 | Wizinowich; Dekany; Gavel; Max; Bauman; Bouchez; Velur; Flicker; Neyman; Britton; Le Mignant | 44h | 3,179.2 |  |

Notes:
- 1: PW
- 2: PW
- 5: PW
- 6: SA
- 8: SA
- 9: PW
- 10: PW
- 12: PW / 1 hr per week x 4 persons for duration of SD phase is about 400 wk-hours total - RD
- 13: CM

| ID | WBS | Task | Type | Duration | Start | Finish | Predecessors | Total slack | Free slack | Constraint | Resources | Work | Cost | Text1 |
| --- | --- | --- | --- | --- | --- | --- | --- | --- | --- | --- | --- | --- | --- | --- |
| 28 | 1.3 | **Tracking and Reporting** |  | 404d? | 2006-09-16 | 2008-04-03 |  | 0d |  |  |  | 120h | 8,048.85 |  |
| 29 | 1.3.1 | Report Preparation/Presentation |  | 312.5d? | 2006-10-02 | 2007-12-12 |  | 114.5d |  | start no earlier than 2006-10-02 | Wizinowich [2%]; Dekany [2%]; Gavel [2%]; Max [2%] | 120h | 8,048.85 |  |
| 30 | 1.3.2 | Keck Science Meeting 06 (UCI) | milestone | 0d | 2006-09-16 | 2006-09-16 |  | 437d |  | finish no earlier than 2006-09-16 |  |  |  |  |
| 31 | 1.3.3 | SSC meeting (UCLA) | milestone | 0d | 2006-11-06 | 2006-11-06 |  | 402d |  | start no earlier than 2006-11-06 |  |  |  |  |
| 32 | 1.3.4 | SSC meeting (Keck) | milestone | 0d | 2007-01-24 | 2007-01-24 |  | 345d |  | start no earlier than 2007-01-24 |  |  |  |  |
| 33 | 1.3.5 | SSC meeting (CA) | milestone | 0d | 2007-04-03 | 2007-04-03 |  | 296d |  | start no earlier than 2007-04-03 |  |  |  |  |
| 34 | 1.3.6 | SSC meeting (Keck) | milestone | 0d | 2007-06-20 | 2007-06-20 |  | 240d |  | start no earlier than 2007-06-20 |  |  |  |  |
| 35 | 1.3.7 | Keck Science Meeting 07 | milestone | 0d | 2007-09-22 | 2007-09-22 |  | 172d |  | finish no earlier than 2007-09-22 |  |  |  |  |
| 36 | 1.3.8 | SSC meeting (CA) | milestone | 0d | 2007-11-06 | 2007-11-06 |  | 141d |  | start no earlier than 2007-11-06 |  |  |  |  |
| 37 | 1.3.9 | SSC meeting (Keck) | milestone | 0d | 2008-01-24 | 2008-01-24 |  | 84d |  | start no earlier than 2008-01-24 |  |  |  |  |
| 38 | 1.3.10 | SSC meeting (CA) | milestone | 0d | 2008-04-03 | 2008-04-03 |  | 0d |  | finish no earlier than 2008-04-03 |  |  |  |  |
| 39 | 1.4 | **Proposals & Fundraising** |  | 45d? | 2006-10-27 | 2007-01-01 |  | 329d |  |  |  |  |  |  |
| 40 | 1.4.1 | Dates & deliverables identified by Directors | milestone | 0d | 2006-10-27 | 2006-10-27 | 7FS+3w | 407d | 45d |  |  |  |  |  |
| 41 | 1.4.2 | Support Advancement Office | milestone | 0d? | 2007-01-01 | 2007-01-01 | 40 | 362d |  | start no earlier than 2007-01-01 | Wizinowich [2.9%]; Max [3.8%]; Gavel [0.5%]; Dekany [0.5%] |  |  | lead gone |
| 42 | 1.5 | **System Design Report & Review** |  | 131d? | 2007-09-17 | 2008-03-17 |  | 13d |  |  |  | 473h | 28,884.33 |  |
| 43 | 1.5.1 | System Design Report |  | 8d? | 2008-01-21 | 2008-01-30 | 323, 302, 133 | 46d | 0d |  | Wizinowich [31.2%]; Gavel [7.8%]; Dekany [7.8%]; Adkins [7.8%]; Max [7.8%] | 40h | 2,577.2 |  |
| 44 | 1.5.2 | **System Design Review** |  | 131d? | 2007-09-17 | 2008-03-17 |  | 13d |  |  |  | 433h | 26,307.13 |  |
| 45 | 1.5.2.1 | Identify Reviewers |  | 65d? | 2007-09-17 | 2007-12-14 |  | 83d | 33d | start no earlier than 2007-09-17 | Adkins(IPM) [1.9%]; Wizinowich [0.4%]; Max [0.2%]; Gavel [0.2%]; Dekany [0.2%] | 15h | 343.51 |  |
| 46 | 1.5.2.2 | Review Package Distributed |  | 1d | 2008-01-31 | 2008-01-31 | 43, 45 | 50d | 0d | start no earlier than 2008-01-14 | Adkins(IPM) | 8h |  |  |
| 47 | 1.5.2.3 | Reviewer Comments Addressed |  | 5d? | 2008-02-15 | 2008-02-21 | 46FS+10d | 50d | 4d | finish no earlier than 2008-02-01 | Wizinowich [75%]; Dekany [60%]; Gavel [60%]; Max [65%]; Adkins(IPM) [40%] | 120h | 7,352.66 |  |
| 48 | 1.5.2.4 | System Design Review Support |  | 20d? | 2008-01-31 | 2008-02-27 | 43 | 13d | 0d | start no earlier than 2007-01-16 | Wizinowich [15%]; Dekany [15%]; Gavel [15%]; Max [15%]; Bauman [7.5%]; Bouchez [2.5%]; Velur [10%]; Flicker [10%]; Neyman [16.2%]; Le Mignant [10%]; Johansson [10%]; Adkins(IPM) [10%]; Chin [5%]; Kellner [5%]; Moore [10%] | 250h | 16,066.74 |  |
| 49 | 1.5.2.5 | System Design Review Meeting | milestone | 0d | 2008-02-27 | 2008-02-27 | 48, 47 | 46d | 0d | start no earlier than 2008-02-06 |  |  |  |  |
| 50 | 1.5.2.6 | Reviewer Report Received | milestone | 0d | 2008-03-12 | 2008-03-12 | 49FS+10d | 46d | 0d | start no earlier than 2008-02-15 |  |  |  |  |
| 51 | 1.5.2.7 | Response to Reviewer Report & Distribution |  | 3d? | 2008-03-13 | 2008-03-17 | 50 | 46d |  | start no earlier than 2008-02-18 | Wizinowich [41.7%]; Dekany [33.3%]; Gavel [33.3%]; Max [41.7%]; Adkins(IPM) [16.7%] | 40h | 2,544.22 |  |

Notes:
- 28: PW
- 29: PW
- 42: SA
- 43: PW
- 44: PW
- 45: SA
- 46: SA
- 47: PW
- 48: PW
- 49: SA
- 51: PW

| ID | WBS | Task | Duration | Start | Finish | Total slack | Constraint | Resources | Work | Cost | Text1 |
| --- | --- | --- | --- | --- | --- | --- | --- | --- | --- | --- | --- |
| 52 | 2 | **System Requirements** | 285d? | 2006-10-02 | 2007-11-02 | 98d |  |  | 3524h | 138,512.62 |  |
| 53 | 2.1 | **Science Requirements** | 271d? | 2006-10-02 | 2007-10-15 | 123d |  |  | 3090h | 113,134.8 |  |
| 54 | 2.1.1 | **Solar System Science Requirements** | 135d? | 2006-10-02 | 2007-04-06 | 259d |  |  | 650h | 20,150 |  |
| 55 | 2.1.1.1 | **Companions & Multiplicity of Small Solar System Bodies** | 75d? | 2006-10-02 | 2007-01-12 | 319d |  |  | 250h | 7,750 |  |
| 56 | 2.1.1.1.1 | Point Source Companion Sensitivity Requirements | 45d? | 2006-10-02 | 2006-12-01 | 382d | finish no earlier than 2006-12-01 | Student1 [27.8%] | 100h | 3,100 |  |
| 57 | 2.1.1.1.2 | Spectral Sensitivity & Spectral Resolution Requirements | 45d? | 2006-10-02 | 2006-12-01 | 382d | finish no earlier than 2006-12-01 | Student1 [27.8%] | 100h | 3,100 |  |
| 58 | 2.1.1.1.3 | Observing Scenarios | 30d? | 2006-12-04 | 2007-01-12 | 352d | finish no earlier than 2007-01-12 | Student1 [10.4%] | 25h | 775 |  |
| 59 | 2.1.1.1.4 | Science Instrument Requirements | 30d? | 2006-12-04 | 2007-01-12 | 352d | start no earlier than 2006-12-04 | Student1 [10.4%] | 25h | 775 |  |
| 60 | 2.1.1.2 | **Moons of the Giant Planets** | 70d? | 2006-12-04 | 2007-03-09 | 279d |  |  | 150h | 4,650 |  |
| 61 | 2.1.1.2.1 | Performance Requirements | 40d? | 2006-12-04 | 2007-01-26 | 342d | start no earlier than 2006-12-04 | Student1 [31.2%] | 100h | 3,100 |  |
| 62 | 2.1.1.2.2 | Observing Scenarios | 30d? | 2007-01-29 | 2007-03-09 | 312d | finish no earlier than 2007-03-09 | Student1 [10.4%] | 25h | 775 |  |
| 63 | 2.1.1.2.3 | Science Instrument Requirements | 30d? | 2007-01-29 | 2007-03-09 | 312d | start no earlier than 2007-01-29 | Student1 [10.4%] | 25h | 775 |  |
| 64 | 2.1.1.3 | **Shape & Size of Asteroids** | 50d? | 2007-01-29 | 2007-04-06 | 259d |  |  | 250h | 7,750 |  |
| 65 | 2.1.1.3.1 | Spatial Resolution Requirements | 25d? | 2007-01-29 | 2007-03-02 | 317d | start no earlier than 2007-01-29 | Student1 [50%] | 100h | 3,100 |  |
| 66 | 2.1.1.3.2 | Spectral Sensitivity & Spectral Resolution Requirements | 25d? | 2007-01-29 | 2007-03-02 | 317d | start no earlier than 2007-01-29 | Student1 [50%] | 100h | 3,100 |  |
| 67 | 2.1.1.3.3 | Observing Scenarios | 25d? | 2007-03-05 | 2007-04-06 | 292d | finish no earlier than 2007-04-06 | Student1 [12.5%] | 25h | 775 |  |
| 68 | 2.1.1.3.4 | Science Instrument Requirements | 25d? | 2007-03-05 | 2007-04-06 | 292d | start no earlier than 2007-03-05 | Student1 [12.5%] | 25h | 775 |  |
| 69 | 2.1.2 | **Galactic Science Requirements** | 135d? | 2006-10-02 | 2007-04-06 | 259d |  |  | 1200h | 37,200 |  |
| 70 | 2.1.2.1 | **Galactic Center Proper Motions: Astrometry** | 75d? | 2006-10-02 | 2007-01-12 | 319d |  |  | 200h | 6,200 |  |
| 71 | 2.1.2.1.1 | Astrometry requirements | 50d? | 2006-10-02 | 2006-12-08 | 344d | start no earlier than 2006-10-02 | Student2 [37.5%] | 150h | 4,650 | mv into FY07 |
| 72 | 2.1.2.1.2 | Observing Scenarios | 35d? | 2006-11-27 | 2007-01-12 | 319d | finish no earlier than 2007-01-12 | Student2 [8.9%] | 25h | 775 |  |
| 73 | 2.1.2.1.3 | Science Instrument Requirements | 35d? | 2006-11-27 | 2007-01-12 | 319d | start no earlier than 2006-11-27 | Student2 [8.9%] | 25h | 775 |  |
| 74 | 2.1.2.2 | **Galactic Center Radial Velocities & Stellar Populations: Integral Field Spectroscopy** | 75d? | 2006-11-27 | 2007-03-09 | 279d |  |  | 200h | 6,200 |  |
| 75 | 2.1.2.2.1 | Performance Requirements | 45d? | 2006-11-27 | 2007-01-26 | 309d | finish no earlier than 2007-01-26 | Student2 [41.7%] | 150h | 4,650 |  |
| 76 | 2.1.2.2.2 | Observing Scenarios | 30d? | 2007-01-29 | 2007-03-09 | 279d | start no earlier than 2007-01-29 | Student2 [10.4%] | 25h | 775 |  |
| 77 | 2.1.2.2.3 | Science Instrument Requirements | 30d? | 2007-01-29 | 2007-03-09 | 279d | start no earlier than 2007-01-29 | Student2 [10.4%] | 25h | 775 |  |

Notes:
- 52: PW
- 53: CM
- 54: FM
- 69: ML
- 70: AG
- 74: AG

| ID | WBS | Task | Duration | Start | Finish | Total slack | Constraint | Resources | Work | Cost | Text1 |
| --- | --- | --- | --- | --- | --- | --- | --- | --- | --- | --- | --- |
| 78 | 2.1.2.3 | **Galactic Center Nature of Sgr A*: 3-5 um Color & 2 um Polarimetry Variability** | 50d? | 2007-01-29 | 2007-04-06 | 259d |  |  | 200h | 6,200 |  |
| 79 | 2.1.2.3.1 | Performance Requirements | 25d? | 2007-01-29 | 2007-03-02 | 284d | finish no earlier than 2007-03-02 | Student2 [75%] | 150h | 4,650 |  |
| 80 | 2.1.2.3.2 | Observing Scenarios | 25d? | 2007-03-05 | 2007-04-06 | 259d | start no earlier than 2007-03-05 | Student2 [12.5%] | 25h | 775 |  |
| 81 | 2.1.2.3.3 | Science Instrument Requirements | 25d? | 2007-03-05 | 2007-04-06 | 259d | finish no earlier than 2007-04-06 | Student2 [12.5%] | 25h | 775 |  |
| 82 | 2.1.2.4 | **Planets around Low Mass Stars & Brown Dwarfs: Companion Sensitivity** | 75d? | 2006-10-02 | 2007-01-12 | 319d |  |  | 200h | 6,200 |  |
| 83 | 2.1.2.4.1 | Companion Sensitivity Performance Requirements | 50d? | 2006-10-02 | 2006-12-08 | 344d | start no earlier than 2006-10-02 | Student2 [37.5%] | 150h | 4,650 | mv into FY07 |
| 84 | 2.1.2.4.2 | Observing Scenarios | 35d? | 2006-11-27 | 2007-01-12 | 319d | start no earlier than 2006-11-27 | Student2 [8.9%] | 25h | 775 |  |
| 85 | 2.1.2.4.3 | Science Instrument Requirements | 35d? | 2006-11-27 | 2007-01-12 | 319d | start no earlier than 2006-11-27 | Student2 [8.9%] | 25h | 775 |  |
| 86 | 2.1.2.5 | **Debris Disks, Protostellar Envelopes & Outflows: Contrast** | 50d? | 2007-01-29 | 2007-04-06 | 259d |  |  | 200h | 6,200 |  |
| 87 | 2.1.2.5.1 | Contrast Performance Requirements | 25d? | 2007-01-29 | 2007-03-02 | 284d | finish no earlier than 2007-03-02 | Student2 [75%] | 150h | 4,650 |  |
| 88 | 2.1.2.5.2 | Observing Scenarios | 25d? | 2007-03-05 | 2007-04-06 | 259d | start no earlier than 2007-03-05 | Student2 [12.5%] | 25h | 775 |  |
| 89 | 2.1.2.5.3 | Science Instrument Requirements | 25d? | 2007-03-05 | 2007-04-06 | 259d | start no earlier than 2007-03-05 | Student2 [12.5%] | 25h | 775 |  |
| 90 | 2.1.2.6 | **Debris Disks, Protostellar Envelopes & Outflows: Polarimetry** | 75d? | 2006-11-27 | 2007-03-09 | 279d |  |  | 200h | 6,200 |  |
| 91 | 2.1.2.6.1 | Polarimetry Performance Requirements | 45d? | 2006-11-27 | 2007-01-26 | 309d | finish no earlier than 2007-01-26 | Student2 [41.7%] | 150h | 4,650 |  |
| 92 | 2.1.2.6.2 | Observing Scenarios | 30d? | 2007-01-29 | 2007-03-09 | 279d | start no earlier than 2007-01-29 | Student2 [10.4%] | 25h | 775 |  |
| 93 | 2.1.2.6.3 | Science Instrument Requirements | 30d? | 2007-01-29 | 2007-03-09 | 279d | start no earlier than 2007-01-29 | Student2 [10.4%] | 25h | 775 |  |
| 94 | 2.1.3 | **Extragalactic Science Requirements** | 150d? | 2006-10-02 | 2007-04-27 | 244d |  |  | 1000h | 40,000 |  |
| 95 | 2.1.3.1 | **Resolved Stellar Populations in Crowded Fields** | 90d? | 2006-10-02 | 2007-02-02 | 304d |  |  | 300h | 12,000 |  |
| 96 | 2.1.3.1.1 | Performance Requirements | 60d? | 2006-10-02 | 2006-12-22 | 334d | start no earlier than 2006-10-02 | Postdoc [52.1%] | 250h | 10,000 | mv into FY07 |
| 97 | 2.1.3.1.2 | Observing Scenarios | 40d? | 2006-12-11 | 2007-02-02 | 337d | finish no earlier than 2007-02-02 | Postdoc [7.8%] | 25h | 1,000 |  |
| 98 | 2.1.3.1.3 | Science Instrument Requirements | 40d? | 2006-12-11 | 2007-02-02 | 337d | start no earlier than 2006-12-11 | Postdoc [7.8%] | 25h | 1,000 |  |
| 99 | 2.1.3.2 | **High Redshift Galaxies** | 90d? | 2006-10-02 | 2007-02-02 | 304d |  |  | 300h | 12,000 |  |
| 100 | 2.1.3.2.1 | Encircled Energy (& d-IFU) Performance Requirements | 60d? | 2006-10-02 | 2006-12-22 | 334d | start no earlier than 2006-10-02 | Postdoc [41.7%] | 200h | 8,000 | mv into FY07 |
| 101 | 2.1.3.2.2 | Observing Scenarios | 40d? | 2006-12-11 | 2007-02-02 | 337d | start no earlier than 2006-12-11 | Postdoc [15.6%] | 50h | 2,000 |  |
| 102 | 2.1.3.2.3 | Science Instrument Requirements | 40d? | 2006-12-11 | 2007-02-02 | 337d | start no earlier than 2006-12-11 | Postdoc [15.6%] | 50h | 2,000 |  |

Notes:
- 78: AG
- 82: ML
- 86: LH
- 94: CM

| ID | WBS | Task | Duration | Start | Finish | Predecessors | Total slack | Free slack | Constraint | Resources | Work | Cost | Text1 |
| --- | --- | --- | --- | --- | --- | --- | --- | --- | --- | --- | --- | --- | --- |
| 103 | 2.1.3.3 | **Nearby Galaxies** | 100d? | 2006-12-11 | 2007-04-27 |  | 244d |  |  |  | 200h | 8,000 |  |
| 104 | 2.1.3.3.1 | Encircled Energy & PSF Performance Requirements | 60d? | 2006-12-11 | 2007-03-02 |  | 317d |  | finish no earlier than 2007-03-02 | Postdoc [31.2%] | 150h | 6,000 |  |
| 105 | 2.1.3.3.2 | Observing Scenarios | 40d? | 2007-03-05 | 2007-04-27 |  | 277d |  | finish no earlier than 2007-04-27 | Postdoc [7.8%] | 25h | 1,000 |  |
| 106 | 2.1.3.3.3 | Science Instrument Requirements | 40d? | 2007-03-05 | 2007-04-27 |  | 277d |  | start no earlier than 2007-03-05 | Postdoc [7.8%] | 25h | 1,000 |  |
| 107 | 2.1.3.4 | **Gravitational Lensing** | 100d? | 2006-12-11 | 2007-04-27 |  | 244d |  |  |  | 200h | 8,000 |  |
| 108 | 2.1.3.4.1 | Encircled Energy & PSF Performance Requirements | 60d? | 2006-12-11 | 2007-03-02 |  | 317d |  | start no earlier than 2006-12-11 | Postdoc [31.2%] | 150h | 6,000 |  |
| 109 | 2.1.3.4.2 | Observing Scenarios | 40d? | 2007-03-05 | 2007-04-27 |  | 277d |  | start no earlier than 2007-03-05 | Postdoc [7.8%] | 25h | 1,000 |  |
| 110 | 2.1.3.4.3 | Science Instrument Requirements | 40d? | 2007-03-05 | 2007-04-27 |  | 277d |  | start no earlier than 2007-03-05 | Postdoc [7.8%] | 25h | 1,000 |  |
| 111 | 2.1.4 | **Science Requirements Summary** | 271d? | 2006-10-02 | 2007-10-15 |  | 113d |  |  |  | 240h | 15,784.8 |  |
| 112 | 2.1.4.1 | Science Requirements Summary Rev 1 | 14d? | 2006-10-02 | 2006-10-19 |  | 403d | 26d | finish no earlier than 2006-10-19 | Max [17.9%]; Wizinowich [17.9%] | 40h | 2,546.2 |  |
| 113 | 2.1.4.2 | Science Requirements Summary Rev 2 | 14d? | 2007-02-13 | 2007-03-02 |  | 307d | 4d | start no earlier than 2007-02-13 | Max [89.3%]; Wizinowich [17.9%] | 120h | 8,146.2 | assignment |
| 114 | 2.1.4.3 | Science Requirements Summary Rev 3 | 13.89d? | 2007-06-05 | 2007-06-22 |  | 227d | 4d | finish no earlier than 2007-06-22 | Max [18%]; Wizinowich [18%] | 40h | 2,546.2 |  |
| 115 | 2.1.4.4 | Science Requirements Summary Final | 13.89d? | 2007-09-26 | 2007-10-15 |  | 105d | 4d | finish no earlier than 2007-10-15 | Max [18%]; Wizinowich [18%] | 40h | 2,546.2 |  |
| 116 | 2.2 | **Observatory Requirements** | 245d? | 2006-10-02 | 2007-09-07 |  | 98d |  |  |  | 224h | 13,342.72 |  |
| 117 | 2.2.1 | Development Requirements | 40d? | 2006-10-02 | 2006-11-24 |  | 131d | 0d | start no earlier than 2006-10-02 | Neyman [2.5%]; Wizinowich [2.5%] | 16h | 916.96 |  |
| 118 | 2.2.2 | Observatory Interface Requirements | 20d? | 2006-10-02 | 2006-10-27 |  | 151d | 20d | start no earlier than 2006-10-02 | Neyman [5%]; Wizinowich [5%]; Adkins [5%] | 24h | 1,375.44 |  |
| 119 | 2.2.3 | Science Operations Requirements | 40d? | 2006-10-02 | 2006-11-24 |  | 98d | 0d | finish no earlier than 2006-11-24 | Le Mignant [10%]; Wizinowich [5%]; Bouchez [5%] | 64h | 4,173.12 |  |
| 120 | 2.2.4 | Observatory Requirements Rev 2 | 15d? | 2007-01-22 | 2007-02-09 | 117FS+8w, 118FS+8w, 119FS+8w | 131d | 0d |  | Neyman [20%]; Meguro [8.3%]; Le Mignant [13.3%]; Adkins [8.3%]; Johansson [8.3%]; Chin [8.3%] | 80h | 4,584.8 | assignments |
| 121 | 2.2.5 | Observatory Requirements Rev 3 | 30d? | 2007-04-09 | 2007-05-18 | 120FS+8w | 131d | 0d |  | Neyman [8.3%] | 20h | 1,146.2 |  |
| 122 | 2.2.6 | Observatory Requirements Rev 4 | 40d? | 2007-07-16 | 2007-09-07 | 121FS+8w | 131d | 30d |  | Neyman [6.2%] | 20h | 1,146.2 |  |
| 123 | 2.3 | **System Requirements Document** | 280d? | 2006-10-09 | 2007-11-02 |  | 109d |  |  |  | 210h | 12,035.1 |  |
| 124 | 2.3.1 | **Tracability Matrix** | 270d? | 2006-10-09 | 2007-10-20 |  | 109d |  |  |  | 130h | 7,450.3 |  |
| 125 | 2.3.1.1 | Tracability Matrix Rev 1 | 10d? | 2006-10-09 | 2006-10-20 |  | 402d | 25d | finish no earlier than 2006-10-20 | Neyman [12.5%] | 10h | 573.1 |  |
| 126 | 2.3.1.2 | Tracability Matrix Rev 2 | 12d? | 2007-02-12 | 2007-02-27 |  | 310d | 7d | start no earlier than 2007-02-12 | Neyman [25%]; Wizinowich [25%]; Adkins [25%]; Flicker [25%] | 80h | 4,584.8 |  |
| 127 | 2.3.1.3 | Tracability Matrix Rev 3 | 10d? | 2007-06-15 | 2007-06-28 |  | 223d | 0d | finish no earlier than 2007-06-28 | Neyman [25%] | 20h | 1,146.2 |  |
| 128 | 2.3.1.4 | Tracability Matrix Rev 4 | 9d? | 2007-10-09 | 2007-10-20 |  | 101d | 0d | finish no earlier than 2007-10-20 | Neyman [27.8%] | 20h | 1,146.2 |  |

Notes:
- 111: CM
- 116: CN
- 117: CN
- 118: CN
- 119: DLM
- 120: CN
- 121: CN
- 122: CN
- 124: CN
- 125: CN
- 126: CN
- 127: CN
- 128: CN

| ID | WBS | Task | Duration | Start | Finish | Predecessors | Total slack | Free slack | Constraint | Resources | Work | Cost | Text1 |
| --- | --- | --- | --- | --- | --- | --- | --- | --- | --- | --- | --- | --- | --- |
| 129 | 2.3.2 | **System Requirements Document** | 245d | 2006-11-27 | 2007-11-02 |  | 109d |  |  |  | 80h | 4,584.8 |  |
| 130 | 2.3.2.1 | SRD Rev 1 | 10d | 2006-11-27 | 2006-12-08 | 112, 125, 117, 118, 119 | 377d |  | start no earlier than 2006-11-27 | Wizinowich [25%] | 20h | 1,146.2 |  |
| 131 | 2.3.2.2 | SRD Rev 2 | 10d | 2007-03-09 | 2007-03-22 | 113, 126, 120 | 303d |  | start no earlier than 2007-03-09 | Neyman [25%] | 20h | 1,146.2 |  |
| 132 | 2.3.2.3 | SRD Rev 3 | 10d | 2007-06-29 | 2007-07-12 | 114, 127, 121 | 223d |  | start no earlier than 2007-06-29 | Neyman [25%] | 20h | 1,146.2 |  |
| 133 | 2.3.2.4 | SRD Final SD Phase Version | 10d | 2007-10-22 | 2007-11-02 | 115, 128, 122 | 101d | 69.83d |  | Neyman [25%] | 20h | 1,146.2 |  |
| 134 | 3 | **System Design** | 375d? | 2006-08-14 | 2008-01-18 |  | 54d |  |  |  | 9976h | 627,538 |  |
| 135 | 3.1 | **Systems Engineering** | 360d? | 2006-08-14 | 2007-12-28 |  | 69d |  |  |  | 5396h | 341,577.14 |  |
| 136 | 3.1.1 | **Performance Budgets** | 292d? | 2006-08-14 | 2007-09-25 |  | 129.5d |  |  |  | 2346h | 131,147.46 |  |
| 137 | 3.1.1.1 | **Model Assumptions** | 230d? | 2006-08-14 | 2007-06-29 |  | 191.5d |  |  |  | 260h | 15,154.4 |  |
| 138 | 3.1.1.1.1 | **TMT site monitoring data mining** | 230d? | 2006-08-14 | 2007-06-29 |  | 199d |  |  |  | 80h | 4,584.8 |  |
| 139 | 3.1.1.1.1.1 | Tools in place & 1st release | 24d? | 2006-08-14 | 2006-09-14 |  | 212.17d | 1d | finish no earlier than 2006-09-14 | Flicker [20.8%] | 40h | 2,292.4 |  |
| 140 | 3.1.1.1.1.2 | Release updated data (every two months) | 205d? | 2006-09-18 | 2007-06-29 | 139 | 199d |  | finish no earlier than 2007-06-29 | Flicker [2.4%] | 40h | 2,292.4 |  |
| 141 | 3.1.1.1.2 | Telescope dynamic performance data | 44d? | 2006-10-02 | 2006-11-30 |  | 144.17d | 1d | start no earlier than 2006-10-02 | Neyman [17%]; Flicker [17%] | 120h | 6,877.2 |  |
| 142 | 3.1.1.1.3 | Telescope static wavefront errors | 44d? | 2006-10-02 | 2006-11-30 |  | 144.17d | 1d | finish no earlier than 2006-11-30 | Neyman [5.7%] | 20h | 1,146.2 |  |
| 143 | 3.1.1.1.4 | Sodium return vs laser format | 22d? | 2006-11-01 | 2006-11-30 |  | 202.5d | 18d | start no earlier than 2006-11-01 | Gavel [11.4%]; Neyman [11.4%] | 40h | 2,546.2 |  |
| 144 | 3.1.1.2 | **Model/Tool Validation** | 90d? | 2006-08-14 | 2006-12-15 |  | 158.5d | 7d |  |  | 334h | 10,755.88 |  |
| 145 | 3.1.1.2.1 | Agreement between Tomography Codes | 35d? | 2006-08-14 | 2006-09-29 |  | 246.5d |  | start no earlier than 2006-08-14 | Flicker [5.4%]; Gavel [3.6%]; Neyman [5.4%] | 40h | 2,419.3 |  |
| 146 | 3.1.1.2.2 | Agreement between Sky Coverage Codes | 15d? | 2006-10-16 | 2006-11-03 |  | 188.5d |  | start no earlier than 2006-10-16 | Dekany [10%]; Gavel [10%]; Clare [13.3%] | 40h | 2,898.68 | mv into FY07 |
| 147 | 3.1.1.2.3 | Anchor to Keck II LGS AO PSFs | 21d? | 2006-10-02 | 2006-10-30 |  | 180.17d |  | finish no earlier than 2006-10-30 | Neyman [23.8%] | 40h | 2,292.4 |  |
| 148 | 3.1.1.2.4 | Anchor to On-sky MGSU Experiments | 3.67d? | 2006-11-10 | 2006-11-15 |  | 168.17d |  | finish no earlier than 2006-11-15 | Flicker [34.1%] | 10h | 573.1 |  |
| 149 | 3.1.1.2.5 | Anchor to LAO Lab Experiments | 30d? | 2006-11-06 | 2006-12-15 |  | 191.5d |  | start no earlier than 2006-11-06 | Gavel [1.7%]; Flicker [16.7%]; Kupke [33.3%]; Ammons [33.3%] | 204h | 2,572.4 |  |
| 150 | 3.1.1.3 | Throughput | 65d? | 2006-10-02 | 2006-12-29 |  | 194.5d | 130d | start no earlier than 2006-10-02 | Bouchez [6.2%] | 32h | 2,844.48 | mv into FY07 |
| 151 | 3.1.1.4 | **Background** | 71.5d? | 2006-10-02 | 2007-01-09 |  | 188d | 123.5d |  |  | 50h | 4,444.5 |  |
| 152 | 3.1.1.4.1 | Document Proposal Analysis | 9d? | 2006-10-02 | 2006-10-12 |  | 250.5d |  | start no earlier than 2006-10-02 | Bouchez [13.9%] | 10h | 888.9 |  |
| 153 | 3.1.1.4.2 | Develop Background Performance Budget | 62.5d? | 2006-10-02 | 2007-01-09 |  | 188d |  | start no earlier than 2006-10-02 | Bouchez [8%] | 40h | 3,555.6 |  |

Notes:
- 130: PW
- 131: CN
- 132: CN
- 133: CN
- 134: PW
- 135: RD
- 136: RD
- 137: CN
- 138: RF
- 139: RF
- 140: RF
- 141: CN
- 142: CN
- 143: DG
- 144: CN
- 145: DG
- 146: RD
- 147: CN
- 148: RF
- 149: DG
- 150: AB
- 151: AB
- 152: AB
- 153: AB

| ID | WBS | Task | Duration | Start | Finish | Predecessors | Total slack | Free slack | Constraint | Resources | Work | Cost | Text1 |
| --- | --- | --- | --- | --- | --- | --- | --- | --- | --- | --- | --- | --- | --- |
| 154 | 3.1.1.5 | **Wavefront Error vs Sky Coverage** | 87d? | 2006-10-02 | 2007-01-30 |  | 151.5d | 0d |  |  | 110h | 8,830.5 |  |
| 155 | 3.1.1.5.1 | Document WFE Budget Rev 1 | 50d? | 2006-10-02 | 2006-12-08 |  | 176.17d |  | start no earlier than 2006-10-02 | Dekany [10%] | 40h | 3,555.6 |  |
| 156 | 3.1.1.5.2 | Document WFE Budget Rev 2 | 25d? | 2006-12-27 | 2007-01-30 | 139, 143, 144, 183 | 151.5d |  | finish no earlier than 2007-01-30 | Dekany [20%]; Flicker [17%] | 70h | 5,274.9 |  |
| 157 | 3.1.1.6 | Encircled Energy vs Sky Coverage | 50d? | 2006-10-23 | 2006-12-29 |  | 206.5d | 22d | start no earlier than 2006-10-23 | Dekany [17.5%]; Gavel [17.5%] | 110h | 8,455.6 |  |
| 158 | 3.1.1.7 | Photometric Accuracy | 75d? | 2006-10-16 | 2007-01-26 |  | 141.17d | 2d | start no earlier than 2006-10-16 | Britton [20%]; Neyman [10%]; Flicker [10%] | 240h | 17,544 |  |
| 159 | 3.1.1.8 | Astrometric Accuracy | 165d? | 2006-11-13 | 2007-06-29 |  | 31.17d | 0d | start no earlier than 2006-11-13 | Britton [13.6%]; Cameron [13.6%] | 240h | 5,333.4 |  |
| 160 | 3.1.1.9 | Polarimetric Accuracy | 25d? | 2007-02-05 | 2007-03-09 |  | 111.17d | 80d | start no earlier than 2007-02-05 | Ireland [20%] | 40h |  |  |
| 161 | 3.1.1.10 | Companion Sensitivity | 41.25d? | 2006-11-13 | 2007-01-09 |  | 200.25d | 15.75d | start no earlier than 2006-11-13 | Macintosh [30.3%]; Neyman [24.2%]; Flicker [18.2%] | 240h | 15,023.4 | assignment |
| 162 | 3.1.1.11 | Observing Efficiency | 30d? | 2007-02-05 | 2007-03-16 |  | 106.17d | 75d | start no earlier than 2007-02-05 | Le Mignant [8.3%]; Other [33.3%] | 100h | 6,106.2 | 160->100 |
| 163 | 3.1.1.12 | Observing Uptime | 30d? | 2007-02-05 | 2007-03-16 |  | 106.17d | 75d | start no earlier than 2007-02-05 | Chin [16.7%]; Johansson [16.7%] | 80h | 4,584.8 |  |
| 164 | 3.1.1.13 | **Performance Budgets Summary** | 123d? | 2007-01-31 | 2007-07-20 |  | 64.5d |  |  |  | 160h | 11,064.4 |  |
| 165 | 3.1.1.13.1 | Performance Budgets Summary Ver 1 | 20d? | 2007-01-31 | 2007-02-27 | 154, 157, 158, 161 | 184.5d | 0d | start no earlier than 2007-01-15 | Dekany [25%]; Neyman [37.5%] | 100h | 6,994.2 |  |
| 166 | 3.1.1.13.2 | Performance Budgets Summary Ver 2 | 15d? | 2007-07-02 | 2007-07-20 | 154, 157, 158, 159, 160, 161, 162, 163, 150, 151 | 97.5d | 0d |  | Dekany [16.7%]; Neyman [33.3%] | 60h | 4,070.2 |  |
| 167 | 3.1.1.14 | **Science Products** | 47d? | 2007-07-23 | 2007-09-25 |  | 137d |  |  |  | 350h | 21,005.9 |  |
| 168 | 3.1.1.14.1 | All-In Science Simulations | 20d? | 2007-07-23 | 2007-08-17 | 166 | 178.25d | 0d | start no earlier than 2007-07-16 | Neyman [50%]; Flicker [50%] | 160h | 9,169.6 |  |
| 169 | 3.1.1.14.2 | **Additional Science Characterization Results** | 27d? | 2007-08-20 | 2007-09-25 |  | 137d |  |  |  | 190h | 11,836.3 |  |
| 170 | 3.1.1.14.2.1 | Point Source Sensitivities | 18.75d? | 2007-08-20 | 2007-09-13 | 168 | 145.25d |  | start no earlier than 2007-04-02 | Bouchez [20%] | 30h | 2,666.7 |  |
| 171 | 3.1.1.14.2.2 | PSF Uniformity & Stability | 15d? | 2007-08-20 | 2007-09-07 | 168 | 182d |  | start no earlier than 2007-04-02 | Neyman [66.7%] | 80h | 4,584.8 |  |
| 172 | 3.1.1.14.2.3 | Other | 15d? | 2007-09-05 | 2007-09-25 | 168 | 170d |  | start no earlier than 2007-09-05 | Flicker [66.7%] | 80h | 4,584.8 | assignment |
| 173 | 3.1.2 | **Trade Studies** | 160d? | 2006-10-16 | 2007-05-25 |  | 104.5d |  |  |  | 1790h | 124,852.06 |  |
| 174 | 3.1.2.1 | **System Architecture Trade Studies** | 120d? | 2006-10-16 | 2007-03-30 |  | 144.5d | 80d |  |  | 690h | 44,653.26 |  |
| 175 | 3.1.2.1.1 | MOAO & MCAO TS | 25d? | 2006-11-13 | 2006-12-15 |  | 252.5d |  | finish no earlier than 2006-12-15 | Gavel [40%] | 80h | 5,600 | assigned |
| 176 | 3.1.2.1.2 | NGAO versus Keck AO upgrades TS (meeting 5) | 20d? | 2007-02-05 | 2007-03-02 |  | 141.17d |  | start no earlier than 2007-02-05 | Neyman [37.5%]; Wizinowich [25%] | 100h | 5,731 |  |
| 177 | 3.1.2.1.3 | Adaptive Secondary Mirror option TS (m5) | 20d? | 2007-03-05 | 2007-03-30 |  | 177.5d |  | start no earlier than 2007-03-05 | Bauman [15%]; Wizinowich [10%] | 40h | 2,596.96 | assignment |
| 178 | 3.1.2.1.4 | K & L-band Science TS (m5) | 20d? | 2007-02-05 | 2007-03-02 |  | 164.5d |  | start no earlier than 2007-02-05 | Bouchez [25%] | 40h | 3,555.6 |  |
| 179 | 3.1.2.1.5 | Keck Interferometer Support TS (m5) | 100d? | 2006-10-16 | 2007-03-02 |  | 141.17d |  | start no earlier than 2006-10-16 | Neyman [22.5%]; Wizinowich [2.5%] | 120h | 6,877.2 |  |
| 180 | 3.1.2.1.6 | Instrument Balance TS | 20d? | 2006-11-13 | 2006-12-08 |  | 201.17d |  | start no earlier than 2006-11-13 | Adkins [6.2%] | 10h | 573.1 |  |
| 181 | 3.1.2.1.7 | GLAO for non-NGAO Instruments TS (m5) | 20d? | 2007-02-05 | 2007-03-02 |  | 141.17d |  | start no earlier than 2007-02-05 | Flicker [12.5%] | 20h | 1,146.2 |  |
| 182 | 3.1.2.1.8 | Science Instrument Re-use Cost/Benefit TS (m3) | 20d? | 2006-11-13 | 2006-12-08 |  | 201.17d |  | start no earlier than 2006-11-13 | Adkins [25%]; Moore [50%] | 120h | 9,403.6 |  |
| 183 | 3.1.2.1.9 | Telescope Wavefront Errors TS | 13d? | 2006-12-04 | 2006-12-20 | 141, 142 | 155.5d | 4d | finish no earlier than 2006-12-20 | Neyman [38.5%]; Flicker [38.5%] | 80h | 4,584.8 |  |
| 184 | 3.1.2.1.10 | Observing Model TS | 45d? | 2006-11-13 | 2007-01-12 |  | 176.17d |  | finish no earlier than 2007-01-12 | Le Mignant [22.2%] | 80h | 4,584.8 |  |

Notes:
- 154: RD
- 155: RD
- 156: RD
- 157: DG
- 158: MB
- 159: CN
- 160: MI
- 161: BM
- 162: DLM
- 163: EJ
- 165: RD
- 166: RD
- 168: CN
- 170: AB
- 171: CN
- 172: RF
- 173: RD
- 175: DG
- 176: PW
- 177: PW
- 178: AB
- 179: CN
- 180: SA
- 181: RF
- 182: SA
- 183: CN
- 184: DLM

| ID | WBS | Task | Duration | Start | Finish | Predecessors | Total slack | Free slack | Constraint | Resources | Work | Cost |
| --- | --- | --- | --- | --- | --- | --- | --- | --- | --- | --- | --- | --- |
| 185 | 3.1.2.2 | **Adaptive Optics System Trade Studies** | 150d? | 2006-10-30 | 2007-05-25 |  | 96.5d | 40d |  |  | 880h | 64,432.6 |
| 186 | 3.1.2.2.1 | AO Enclosure Temperature TS (m6) | 74d? | 2007-01-02 | 2007-04-13 |  | 134.5d |  | start no earlier than 2007-01-02 | Bouchez [5.1%]; Meguro [6.8%] | 70h | 4,959.1 |
| 187 | 3.1.2.2.2 | Optical Relay TS (m6) | 74d? | 2007-01-02 | 2007-04-13 |  | 103.25d | 0d | finish no earlier than 2007-04-13 | Bauman [5.1%]; Dekany [5.1%] | 60h | 4,766.7 |
| 188 | 3.1.2.2.3 | Field Rotation Strategy TS (m6) | 74d? | 2007-01-02 | 2007-04-13 |  | 108.75d | 0d | start no earlier than 2007-01-02 | Bauman [10.1%]; Meguro [3.4%] | 80h | 5,346.2 |
| 189 | 3.1.2.2.4 | Dichroics & Beamsplitters TS (m6) | 74d? | 2007-01-02 | 2007-04-13 |  | 111.17d | 0d | start no earlier than 2007-01-02 | Velur [10.1%] | 60h | 5,333.4 |
| 190 | 3.1.2.2.5 | Rayleigh Rejection TS (m3) | 30d? | 2006-10-30 | 2006-12-08 |  | 201.17d |  | start no earlier than 2006-10-30 | Kellner [16.7%] | 40h | 2,292.4 |
| 191 | 3.1.2.2.6 | LGS WFS Type TS (m4) | 35d? | 2006-12-04 | 2007-01-19 |  | 119.5d | 60d | start no earlier than 2006-12-04 | Velur [10.7%] | 30h | 2,666.7 |
| 192 | 3.1.2.2.7 | LGS WFS number of subapertures TS (m4) | 35d? | 2006-12-04 | 2007-01-19 |  | 119.5d | 60d | start no earlier than 2006-12-04 | Velur [7.1%] | 20h | 1,777.8 |
| 193 | 3.1.2.2.8 | Slow WFS TS (m7) | 25d? | 2007-04-23 | 2007-05-25 |  | 59.5d | 0d | start no earlier than 2007-04-23 | Velur [40%] | 80h | 7,111.2 |
| 194 | 3.1.2.2.9 | LOWFS Architecture TS | 50d? | 2006-12-04 | 2007-02-09 |  | 104.5d | 45d | start no earlier than 2006-12-04 | Kellner [71.4%]; Velur [20%] | 160h | 11,696 |
| 195 | 3.1.2.2.10 | Number & Type of LOWFS TS (m4) | 40d? | 2006-12-04 | 2007-01-26 |  | 114.5d | 55d | start no earlier than 2006-12-04 | Kellner [21.4%]; Velur [9.4%] | 60h | 4,386 |
| 196 | 3.1.2.2.11 | Centroid Anisoplanatism TS (m7) | 25d? | 2007-04-23 | 2007-05-25 |  | 81.17d |  | start no earlier than 2007-04-23 | Kellner [20%] | 40h | 2,292.4 |
| 197 | 3.1.2.2.12 | Deformable Mirror Stroke Requirement TS (m6) | 74d? | 2007-01-02 | 2007-04-13 |  | 111.17d |  | start no earlier than 2007-01-02 | Flicker [8.4%] | 50h | 2,865.5 |
| 198 | 3.1.2.2.13 | Stand-alone vs DM on T/T Stage TS (m3) | 30d? | 2006-10-30 | 2006-12-08 |  | 257.5d |  | start no earlier than 2006-10-30 | Bauman [25%] | 60h | 4,200 |
| 199 | 3.1.2.2.14 | Correcting Fast T/T with DM TS | 30d? | 2006-10-30 | 2006-12-08 |  | 257.5d |  | finish no earlier than 2006-12-08 | Bauman [8.3%]; Flicker [8.3%] | 40h | 2,546.2 |
| 200 | 3.1.2.2.15 | Focus Compensation TS (m6) | 74d? | 2007-01-22 | 2007-05-03 |  | 97.17d |  | start no earlier than 2007-01-22 | Kellner [2.5%]; Velur [2.5%] | 30h | 2,193 |
| 201 | 3.1.2.3 | **Laser Facility Trade Studies** | 101d? | 2006-10-16 | 2007-03-05 |  | 135.5d | 0d |  |  | 220h | 15,766.2 |
| 202 | 3.1.2.3.1 | Laser Pulse Format TS (m6) | 20d? | 2007-01-02 | 2007-01-29 |  | 140.17d | 0d | start no earlier than 2007-01-02 | Velur [50%] | 80h | 7,111.2 |
| 203 | 3.1.2.3.2 | Free Space vs Fiber TS (m7) | 25d? | 2007-01-30 | 2007-03-05 | 202 | 140.17d | 0d |  | Neyman [50%] | 100h | 5,731 |
| 204 | 3.1.2.3.3 | LGS Asterism Geometry & Size TS (m2) | 5d? | 2006-10-23 | 2006-10-27 |  | 231.17d | 91d | finish no earlier than 2006-10-27 | Flicker [50%] | 20h | 1,146.2 |
| 205 | 3.1.2.3.4 | Variable vs fixed LGS Asterism Cost/Benefit TS (m2) | 10d? | 2006-10-16 | 2006-10-27 |  | 231.17d |  | finish no earlier than 2006-10-27 | Velur [25%] | 20h | 1,777.8 |
| 206 | 3.1.3 | **System Architecture** | 218d? | 2007-02-28 | 2007-12-28 |  | 69d |  |  |  | 1260h | 85,577.62 |
| 207 | 3.1.3.1 | System Architecture Ver 1 | 36d? | 2007-02-28 | 2007-04-18 | 165 | 184.5d | 0d | start no earlier than 2006-11-01 | Dekany [10.4%]; Gavel [10.4%]; Wizinowich [6.9%] | 80h | 5,912.9 |
| 208 | 3.1.3.2 | System Architecture Ver 2 | 20d? | 2007-07-23 | 2007-08-17 | 166, 174, 185, 201 | 97.5d | 50d |  | Dekany [12.5%]; Gavel [12.5%]; Wizinowich [12.5%] | 60h | 4,324 |

Notes:
- 186: AB
- 187: RD
- 188: BB
- 189: VV
- 190: VV
- 191: VV
- 192: VV
- 193: VV
- 194: SK
- 195: SK
- 196: SK
- 197: RF
- 198: BB
- 199: BB
- 200: SK
- 202: VV
- 203: CN
- 204: RF
- 205: VV
- 206: RD
- 207: RD
- 208: RD

| ID | WBS | Task | Duration | Start | Finish | Predecessors | Total slack | Free slack | Constraint | Resources | Work | Cost | Text1 |
| --- | --- | --- | --- | --- | --- | --- | --- | --- | --- | --- | --- | --- | --- |
| 209 | 3.1.3.3 | **Functional Requirements** | 162d? | 2007-04-19 | 2007-11-30 |  | 14.5d | 0d |  |  | 1000h | 67,854.4 |  |
| 210 | 3.1.3.3.1 | AO System Functional Requirements Ver 1 | 17.25d? | 2007-04-19 | 2007-05-14 | 207 | 192.25d |  | finish no earlier than 2007-02-02 | Neyman [54.3%]; Chin [18.1%]; Stomski [18.1%]; Meguro [18.1%]; Bauman [18.1%]; Johansson [18.1%] | 200h | 11,779.25 |  |
| 211 | 3.1.3.3.2 | AO System Functional Requirements Ver 2 | 25d? | 2007-10-29 | 2007-11-30 | 208 | 47.5d |  | start no earlier than 2007-10-29 | Neyman [12.5%]; Chin [7.5%]; Stomski [7.5%]; Meguro [7.5%]; Bauman [7.5%]; Johansson [7.5%] | 100h | 5,921.35 |  |
| 212 | 3.1.3.3.3 | Laser System Functional Requirements Ver 1 | 20d? | 2007-04-19 | 2007-05-16 | 207 | 189.5d |  | finish no earlier than 2007-03-02 | Chin [34.4%]; Velur [34.4%]; Stomski [15.6%] | 135h | 9,473.75 |  |
| 213 | 3.1.3.3.4 | Laser System Functional Requirements Ver 2 | 25d? | 2007-10-29 | 2007-11-30 | 208 | 47.5d |  | start no earlier than 2007-10-29 | Chin [12.5%]; Velur [12.5%]; Stomski [7.5%] | 65h | 4,514.65 |  |
| 214 | 3.1.3.3.5 | Science Operations Functional Requirements Ver 1 | 24d? | 2007-04-19 | 2007-05-22 | 207 | 185.5d |  | finish no earlier than 2007-02-02 | Le Mignant [20.8%]; Other [31.2%] | 100h | 6,012.4 |  |
| 215 | 3.1.3.3.6 | Science Operations Functional Requirements Ver 2 | 25d? | 2007-10-29 | 2007-11-30 | 208 | 47.5d |  | start no earlier than 2007-10-29 | Le Mignant [20%]; Other [30%] | 100h | 6,012.4 |  |
| 216 | 3.1.3.3.7 | Science Instruments Functional Requirements Ver 1 | 24d? | 2007-04-19 | 2007-05-22 | 207 | 185.5d |  | start no earlier than 2007-01-02 | Adkins [20.8%]; Moore [41.7%] | 120h | 9,403.6 | Moore |
| 217 | 3.1.3.3.8 | Science Instruments Functional Requirements Ver 2 | 25d? | 2007-10-29 | 2007-11-30 | 208 | 47.5d |  | start no earlier than 2007-10-29 | Adkins [20%]; Moore [70%] | 180h | 14,737 | Moore |
| 218 | 3.1.3.4 | Technology Drivers Summary | 3.63d? | 2007-07-23 | 2007-07-26 | 207, 166, 174, 185, 201 | 158.87d | 0d |  | Neyman [82.7%]; Gavel [55.1%] | 40h | 2,495.44 |  |
| 219 | 3.1.3.5 | Technical Risk Analysis Ver 1 | 23d? | 2007-07-26 | 2007-08-28 | 218 | 190.37d |  | start no earlier than 2007-03-19 | Neyman [13%]; Gavel [8.7%] | 40h | 2,495.44 |  |
| 220 | 3.1.3.6 | Technical Risk Analysis Ver 2 | 20d? | 2007-12-03 | 2007-12-28 | 209 | 47.5d | 1.5d | finish no earlier than 2007-12-28 | Neyman [15%]; Gavel [10%] | 40h | 2,495.44 |  |
| 221 | 3.2 | **AO System** | 223d? | 2007-02-05 | 2007-12-12 |  | 26.5d | 13.5d |  |  | 1780h | 115,300.5 |  |
| 222 | 3.2.1 | AO System Architecture | 45d? | 2007-04-19 | 2007-06-20 | 207 | 184.5d |  | start no earlier than 2007-02-05 | Neyman [33.3%]; Other [35.4%] | 240h | 14,317.2 | let's discuss |
| 223 | 3.2.2 | AO Enclosure | 70d? | 2007-05-14 | 2007-08-17 | 226SS+4w | 142.5d |  |  | Meguro [17.9%] | 100h | 5,731 |  |
| 224 | 3.2.3 | **Opto-mechanical** | 203d? | 2007-03-05 | 2007-12-12 |  | 26.5d |  |  |  | 700h | 49,289.7 |  |
| 225 | 3.2.3.1 | Field Rotation | 82.5d? | 2007-04-16 | 2007-08-08 | 188 | 108.75d | 5.5d | finish no earlier than 2007-06-29 | Bauman [4.5%]; Lockwood [2.3%] | 45h | 3,150 |  |
| 226 | 3.2.3.2 | Optical Relay | 88d? | 2007-04-16 | 2007-08-15 | 187 | 103.25d | 0d | start no earlier than 2007-03-05 | Bauman [5.7%]; Lockwood [3.4%]; Dekany [2%] | 60h | 4,388.9 |  |
| 227 | 3.2.3.3 | Optical Switchyard | 55d? | 2007-04-16 | 2007-06-29 | 189 | 136.25d | 33d | finish no earlier than 2007-06-29 | Bauman [5.7%]; Lockwood [5.7%] | 50h | 3,500 |  |
| 228 | 3.2.3.4 | Optical Support Structure | 41.25d? | 2007-08-16 | 2007-10-12 | 225, 226, 227 | 103.25d |  | start no earlier than 2007-04-16 | Lockwood [9.1%]; Bauman [4.5%] | 45h | 3,150 |  |
| 229 | 3.2.3.5 | **Wavefront Sensors** | 173d? | 2007-04-16 | 2007-12-12 |  | 26.5d |  |  |  | 240h | 17,228.2 |  |
| 230 | 3.2.3.5.1 | High Order LGS Wavefront Sensors | 173d? | 2007-04-16 | 2007-12-12 | 191, 192 | 59.5d |  | start no earlier than 2007-04-16 | Velur [4.3%]; Meguro [1.4%] | 80h | 6,479.6 |  |
| 231 | 3.2.3.5.2 | High Order NGS Wavefront Sensor | 173d? | 2007-04-16 | 2007-12-12 |  | 59.5d |  | start no earlier than 2007-04-16 | Velur [2.2%]; Meguro [0.7%] | 40h | 3,239.8 |  |
| 232 | 3.2.3.5.3 | Low Order NGS Wavefront Sensors | 173d? | 2007-04-16 | 2007-12-12 | 194, 195 | 26.5d |  | finish no earlier than 2007-12-12 | Kellner [2.9%]; Meguro [1.4%]; Velur [1.4%] | 80h | 5,216.4 |  |
| 233 | 3.2.3.5.4 | Calibration Wavefront Sensor | 143d? | 2007-05-28 | 2007-12-12 | 193 | 59.5d |  | start no earlier than 2007-04-16 | Kellner [3.5%] | 40h | 2,292.4 |  |

Notes:
- 210: CN
- 211: CN
- 212: JC
- 213: JC
- 214: DLM
- 215: DLM
- 216: SA
- 217: SA
- 218: DG
- 219: DG
- 220: DG
- 221: DG
- 223: JM
- 224: BB
- 225: BB
- 226: BB
- 227: BB
- 228: BB
- 229: VV
- 230: VV
- 231: VV
- 232: SK
- 233: SK

| ID | WBS | Task | Duration | Start | Finish | Predecessors | Total slack | Free slack | Constraint | Resources | Work | Cost | Text1 |
| --- | --- | --- | --- | --- | --- | --- | --- | --- | --- | --- | --- | --- | --- |
| 234 | 3.2.3.6 | **Wavefront Correctors** | 85d? | 2007-03-05 | 2007-06-29 |  | 144.5d |  |  |  | 140h | 9,732.2 |  |
| 235 | 3.2.3.6.1 | Tip/Tilt Corrector | 85d? | 2007-03-05 | 2007-06-29 |  | 177.5d |  | start no earlier than 2007-03-05 | Flicker [1.5%]; Bauman [1.5%] | 20h | 1,273.1 |  |
| 236 | 3.2.3.6.2 | Deformable Mirror | 85d? | 2007-03-05 | 2007-06-29 |  | 177.5d |  | start no earlier than 2007-03-05 | Flicker [5.9%]; Bauman [11.8%]; Dekany [15%] | 120h | 8,459.1 |  |
| 237 | 3.2.3.7 | **Acquisition Cameras** | 125d? | 2007-03-05 | 2007-08-24 |  | 104.5d |  |  |  | 40h | 3,555.6 |  |
| 238 | 3.2.3.7.1 | NGS Acquisition Camera | 125d? | 2007-03-05 | 2007-08-24 |  | 104.5d |  | start no earlier than 2007-03-05 | Bouchez [2%] | 20h | 1,777.8 |  |
| 239 | 3.2.3.7.2 | LGS Acquisition Camera | 125d? | 2007-03-05 | 2007-08-24 |  | 104.5d |  | start no earlier than 2007-03-05 | Bouchez [2%] | 20h | 1,777.8 |  |
| 240 | 3.2.3.8 | Atmospheric Dispersion Correction | 85d? | 2007-03-05 | 2007-06-29 |  | 177.5d |  | start no earlier than 2007-03-05 | Kellner [2.9%] | 20h | 1,146.2 |  |
| 241 | 3.2.3.9 | Alignment, Calibration, Diagnostics, Metrology and Monitoring | 85d? | 2007-03-05 | 2007-06-29 |  | 177.5d |  | finish no earlier than 2007-06-29 | Neyman [4.4%]; Flicker [4.4%] | 60h | 3,438.6 |  |
| 242 | 3.2.4 | **Non-real-time Control** | 125d? | 2007-05-01 | 2007-10-22 |  | 63.5d |  |  |  | 400h | 24,193 |  |
| 243 | 3.2.4.1 | Non-RTC Software | 51.2d? | 2007-05-17 | 2007-07-27 |  | 157.5d |  | finish no earlier than 2007-07-27 | Johansson [19.5%]; Stomski [19.5%]; Johnson [9.8%] | 200h | 11,462 |  |
| 244 | 3.2.4.2 | Non-RTC Electronics | 125d? | 2007-05-01 | 2007-10-22 |  | 96.5d |  | start no earlier than 2007-05-01 | Chin [10%]; Reinig [10%] | 200h | 12,731 |  |
| 245 | 3.2.5 | **Real-time Control** | 110d? | 2007-02-05 | 2007-07-06 |  | 139.5d |  |  |  | 340h | 21,769.6 |  |
| 246 | 3.2.5.1 | RTC Architecture Analysis and Design Study | 43d? | 2007-02-05 | 2007-04-04 |  | 172.5d | 0d | start no earlier than 2007-02-05 | Gavel [5.8%]; Johansson [11.6%]; Flicker [11.6%]; Reinig [23.3%] | 180h | 11,584.8 |  |
| 247 | 3.2.5.2 | RTC Software Module Definition | 67d? | 2007-04-05 | 2007-07-06 | 246 | 172.5d |  |  | Johansson [11.2%]; Reinig [3.7%] | 80h | 4,838.6 |  |
| 248 | 3.2.5.3 | RTC Hardware Module Definition | 67d? | 2007-04-05 | 2007-07-06 | 246 | 172.5d |  |  | Johansson [3.7%]; Reinig [11.2%] | 80h | 5,346.2 |  |
| 249 | 3.3 | **Laser Facility** | 109d? | 2007-03-06 | 2007-08-03 |  | 119.5d | 106.5d |  |  | 750h | 52,456.5 | Discuss; JC? |
| 250 | 3.3.1 | Laser System Architecture | 50d? | 2007-03-06 | 2007-05-14 | 154, 157, 201 | 168.5d | 0d |  | Velur [20%] | 80h | 7,111.2 |  |
| 251 | 3.3.2 | Laser Enclosure | 43d? | 2007-05-15 | 2007-07-12 | 250 | 168.5d |  |  | Meguro [23.3%] | 80h | 4,584.8 |  |
| 252 | 3.3.3 | Laser | 35d? | 2007-05-15 | 2007-07-02 | 250 | 176.5d |  | start no earlier than 2007-03-05 | Velur [35.7%] | 100h | 8,889 |  |
| 253 | 3.3.4 | **Laser Launch Facility** | 40d? | 2007-03-06 | 2007-04-30 |  | 188.5d |  |  |  | 300h | 20,982.6 | ch name back |
| 254 | 3.3.4.1 | Laser Beam Transport | 40d? | 2007-03-06 | 2007-04-30 | 202, 203 | 221.5d |  |  | Neyman [10.9%]; Kellner [6.2%]; Chin [1.6%] | 60h | 3,438.6 |  |
| 255 | 3.3.4.2 | Laser Pointing & Diagnostics | 40d? | 2007-03-06 | 2007-04-30 | 202, 203 | 221.5d |  |  | Velur [21.9%]; Kellner [21.9%]; Chin [6.2%]; Moore [22%] | 120h | 9,087.8 | add AM |
| 256 | 3.3.4.3 | Laser Launch Telescope | 28.12d? | 2007-03-06 | 2007-04-13 | 204, 202, 203 | 233.38d |  |  | Velur [22.2%]; Kellner [22.2%]; Chin [11.1%] | 120h | 8,456.2 |  |
| 257 | 3.3.5 | **Laser Safety Systems** | 20d? | 2007-07-09 | 2007-08-03 |  | 119.5d |  |  |  | 40h | 2,292.4 |  |
| 258 | 3.3.5.1 | Personnel and Equipment Safety Systems | 20d? | 2007-07-09 | 2007-08-03 |  | 152.5d |  | start no earlier than 2007-07-09 | Chin [12.5%] | 20h | 1,146.2 |  |
| 259 | 3.3.5.2 | Aircraft, Satellite & Laser Traffic Control Safety Systems | 20d? | 2007-07-09 | 2007-08-03 |  | 152.5d |  | start no earlier than 2007-07-09 | Chin [12.5%] | 20h | 1,146.2 |  |

Notes:
- 234: BB
- 235: BB
- 236: BB
- 237: AB
- 238: AB
- 239: AB
- 240: SK
- 241: CN
- 242: JC
- 243: EJ
- 244: JC
- 245: DG
- 246: DG
- 247: EJ
- 248: MR
- 250: VV
- 251: JM
- 252: VV
- 253: VV
- 254: CN
- 255: VV
- 256: VV
- 257: JC
- 258: JC
- 259: JC

| ID | WBS | Task | Duration | Start | Finish | Total slack | Free slack | Constraint | Resources | Work | Cost | Text1 |
| --- | --- | --- | --- | --- | --- | --- | --- | --- | --- | --- | --- | --- |
| 260 | 3.3.6 | **Laser System Control** | 85d? | 2007-04-09 | 2007-08-03 | 119.5d |  |  |  | 150h | 8,596.5 |  |
| 261 | 3.3.6.1 | Laser System Software | 85d? | 2007-04-09 | 2007-08-03 | 152.5d |  | start no earlier than 2007-04-09 | Johansson [5.9%]; Stomski [5.9%] | 80h | 4,584.8 |  |
| 262 | 3.3.6.2 | Laser System Electronics | 85d? | 2007-04-09 | 2007-08-03 | 152.5d |  | start no earlier than 2007-04-09 | Chin [10.3%] | 70h | 4,011.7 |  |
| 263 | 3.4 | **Science Operations** | 154d? | 2007-01-02 | 2007-08-03 | 119.5d | 106.5d |  |  | 670h | 33,897.1 |  |
| 264 | 3.4.1 | **Astronomical Observations Operations** | 108d? | 2007-03-01 | 2007-07-30 | 123.5d |  |  |  | 220h | 9,146.2 |  |
| 265 | 3.4.1.1 | **Pre-Observing Interfaces** | 22d? | 2007-05-01 | 2007-05-30 | 166.5d |  |  |  | 60h | 2,400 |  |
| 266 | 3.4.1.1.1 | AO Guide Star Interface | 22d? | 2007-05-01 | 2007-05-30 | 166.5d |  | finish no earlier than 2007-05-30 | Postdoc [11.4%] | 20h | 800 | assigned |
| 267 | 3.4.1.1.2 | Science Observations Simulation Tools | 22d? | 2007-05-01 | 2007-05-30 | 166.5d |  | start no earlier than 2007-05-01 | Postdoc [22.7%] | 40h | 1,600 | assigned |
| 268 | 3.4.1.2 | **Observing Interfaces** | 43d? | 2007-03-01 | 2007-04-30 | 188.5d |  |  |  | 80h | 3,546.2 |  |
| 269 | 3.4.1.2.1 | Acquisition | 43d? | 2007-03-01 | 2007-04-30 | 188.5d |  | finish no earlier than 2007-04-30 | Postdoc [5.8%] | 20h | 800 | assigned |
| 270 | 3.4.1.2.2 | Observing Sequences | 43d? | 2007-03-01 | 2007-04-30 | 188.5d |  | start no earlier than 2007-03-01 | Postdoc [5.8%] | 20h | 800 | assigned |
| 271 | 3.4.1.2.3 | Instrument, AO & Telescope Observer Interfaces | 43d? | 2007-03-01 | 2007-04-30 | 188.5d |  | start no earlier than 2007-03-01 | Johansson [5.8%] | 20h | 1,146.2 | assigned |
| 272 | 3.4.1.2.4 | Science Data Quality Monitoring | 43d? | 2007-03-01 | 2007-04-30 | 188.5d |  | start no earlier than 2007-03-01 | Postdoc [5.8%] | 20h | 800 | assigned |
| 273 | 3.4.1.3 | **Post-Observing Interfaces** | 42d? | 2007-06-01 | 2007-07-30 | 123.5d |  |  |  | 80h | 3,200 |  |
| 274 | 3.4.1.3.1 | Generic Data Products | 42d? | 2007-06-01 | 2007-07-30 | 123.5d |  | finish no earlier than 2007-07-30 | Postdoc [6%] | 20h | 800 | assigned |
| 275 | 3.4.1.3.2 | Science Data Quality Assessment | 42d? | 2007-06-01 | 2007-07-30 | 123.5d |  | start no earlier than 2007-06-01 | Postdoc [6%] | 20h | 800 | assigned |
| 276 | 3.4.1.3.3 | Science Data Archiving | 42d? | 2007-06-01 | 2007-07-30 | 123.5d |  | start no earlier than 2007-06-01 | Postdoc [11.9%] | 40h | 1,600 | assigned |
| 277 | 3.4.2 | **AO-Instrument Operations** | 154d? | 2007-01-02 | 2007-08-03 | 119.5d |  |  |  | 450h | 24,750.9 |  |
| 278 | 3.4.2.1 | **AO-Instrument Operations Architecture** | 154d? | 2007-01-02 | 2007-08-03 | 119.5d |  |  |  | 270h | 14,435.1 |  |
| 279 | 3.4.2.1.1 | AO-Instrument Observing Modes | 24d? | 2007-01-02 | 2007-02-02 | 249.5d |  | start no earlier than 2007-01-02 | Le Mignant [20.8%]; Postdoc [20.8%] | 80h | 3,892.4 | assigned |
| 280 | 3.4.2.1.2 | AO-Instrument Operations Support | 83d? | 2007-02-05 | 2007-05-30 | 166.5d |  | finish no earlier than 2007-05-30 | Le Mignant [3%] | 20h | 1,146.2 | assigned |
| 281 | 3.4.2.1.3 | AO-Instrument Configuration & Setup | 83d? | 2007-02-05 | 2007-05-30 | 166.5d |  | start no earlier than 2007-02-05 | Le Mignant [3%] | 20h | 1,146.2 | assigned |
| 282 | 3.4.2.1.4 | AO-Instrument Calibrations | 83d? | 2007-02-05 | 2007-05-30 | 166.5d |  | start no earlier than 2007-02-05 | van Dam [3%] | 20h | 1,146.2 | assigned |
| 283 | 3.4.2.1.5 | AO-Instrument Nighttime Operation Modes | 83d? | 2007-02-05 | 2007-05-30 | 166.5d |  | start no earlier than 2007-02-05 | Le Mignant [3%] | 20h | 1,146.2 | assigned |
| 284 | 3.4.2.1.6 | AO-Instrument Science Acquisition & Control | 83d? | 2007-02-05 | 2007-05-30 | 166.5d |  | start no earlier than 2007-02-05 | Postdoc [3%] | 20h | 800 | assigned |
| 285 | 3.4.2.1.7 | AO-Instrument Health Monitoring & Automated Recovery | 83d? | 2007-02-05 | 2007-05-30 | 166.5d |  | start no earlier than 2007-02-05 | Johansson [3%] | 20h | 1,146.2 | assigned |
| 286 | 3.4.2.1.8 | AO-Instrument Laser Traffic Control | 20d? | 2007-07-09 | 2007-08-03 | 152.5d |  | start no earlier than 2007-07-09 | Summers [6.2%] | 10h | 573.1 |  |
| 287 | 3.4.2.1.9 | AO-Instrument User Interfaces | 20d? | 2007-06-04 | 2007-06-29 | 144.5d |  | finish no earlier than 2007-06-29 | Johansson [25%] | 40h | 2,292.4 | assigned |
| 288 | 3.4.2.1.10 | AO-Instrument Maintenance Plan | 20d? | 2007-07-02 | 2007-07-27 | 124.5d |  | finish no earlier than 2007-07-27 | Chin [12.5%] | 20h | 1,146.2 | assigned |

Notes:
- 260: JC
- 261: EJ
- 262: JC
- 263: DLM
- 264: DLM
- 277: DLM
- 278: DLM
- 279: DLM
- 286: DS

| ID | WBS | Task | Duration | Start | Finish | Predecessors | Total slack | Free slack | Constraint | Resources | Work | Cost | Text1 |
| --- | --- | --- | --- | --- | --- | --- | --- | --- | --- | --- | --- | --- | --- |
| 289 | 3.4.2.2 | **AO-Instrument Operations Optimization** | 45d? | 2007-03-05 | 2007-05-04 |  | 184.5d |  |  |  | 180h | 10,315.8 |  |
| 290 | 3.4.2.2.1 | AO-Instrument Performance Prediction | 30d? | 2007-03-05 | 2007-04-13 |  | 199.5d |  | start no earlier than 2007-03-05 | Flicker [25%]; van Dam [8.3%] | 80h | 4,584.8 | assigned |
| 291 | 3.4.2.2.2 | AO-Instrument Real-Time Optimization | 30d? | 2007-03-05 | 2007-04-13 |  | 199.5d |  | start no earlier than 2007-03-05 | Flicker [25%]; van Dam [8.3%] | 80h | 4,584.8 | assigned |
| 292 | 3.4.2.2.3 | AO-Instrument Environment Monitoring | 15d? | 2007-04-16 | 2007-05-04 |  | 184.5d |  | finish no earlier than 2007-05-04 | Chin [16.7%] | 20h | 1,146.2 | assigned |
| 293 | 3.5 | **Science Instruments** | 251d? | 2006-10-02 | 2007-09-17 |  | 88.5d | 75.5d |  |  | 1300h | 78,836.56 |  |
| 294 | 3.5.1 | OSIRIS | 66.67d? | 2006-12-01 | 2007-03-05 |  | 261.83d |  | start no earlier than 2006-12-01 | Adkins [3%]; Other [24.4%] | 100h | 6,124.96 |  |
| 295 | 3.5.2 | Interferometer | 130d? | 2006-10-02 | 2007-03-30 |  | 242.5d |  | start no earlier than 2006-10-02 | Adkins [1.5%]; Neyman [7.7%]; Other [10%] | 100h | 5,937.36 |  |
| 296 | 3.5.3 | OHANA | 50d? | 2007-02-01 | 2007-04-11 |  | 234.5d |  | start no earlier than 2007-02-01 | Adkins [2%]; Other [11.2%]; Woillez [15%] | 50h | 2,949.92 |  |
| 297 | 3.5.4 | Near-IR Imager | 150d? | 2006-10-02 | 2007-04-27 |  | 222.5d |  | start no earlier than 2006-10-02 | Adkins [2%]; Other [31.6%] | 200h | 12,287.44 |  |
| 298 | 3.5.5 | Visible Imager | 150d? | 2006-10-02 | 2007-04-27 |  | 222.5d |  | start no earlier than 2006-10-02 | Adkins [2%]; Other [31.6%] | 200h | 12,287.44 |  |
| 299 | 3.5.6 | Visible IFU | 100d? | 2007-01-02 | 2007-05-21 |  | 206.5d |  | start no earlier than 2007-01-02 | Adkins [2%]; Other [16.4%] | 100h | 6,124.96 |  |
| 300 | 3.5.7 | Deployable Near-IR IFU | 105d? | 2007-02-01 | 2007-06-27 |  | 179.5d |  | start no earlier than 2007-02-01 | Adkins [7.1%]; Other [35.7%]; Neyman [16.7%] | 500h | 30,062 |  |
| 301 | 3.5.8 | Mid-IR IFU | 100d? | 2007-05-01 | 2007-09-17 |  | 121.5d |  | start no earlier than 2007-05-01 | Adkins [1%]; Other [23.9%] | 50h | 3,062.48 |  |
| 302 | 3.6 | System Design Manual | 12.5d? | 2008-01-01 | 2008-01-18 | 209, 220, 293, 164, 263, 218, 249, 221 | 13d | 0d | finish no earlier than 2008-01-18 | Wizinowich [42%]; Dekany [20%]; Gavel [20%] | 80h | 5,470.2 |  |
| 303 | 4 | **Systems Engineering Management Plan (SEMP)** | 202.33d? | 2007-03-05 | 2007-12-12 |  | 40.67d |  |  |  | 1200h | 81,164.3 |  |
| 304 | 4.1 | **Project Plan** | 60.57d? | 2007-07-18 | 2007-10-11 |  | 40.67d | 31.26d |  |  | 540h | 38,157.5 |  |
| 305 | 4.1.1 | WBS and Task Definition | 21.43d? | 2007-07-18 | 2007-08-16 | 22FS+5d | 73.67d | 0d |  | Wizinowich [35%]; Dekany [35%]; Gavel [35%]; Max [35%] | 200h | 14,372 | moved earlier |
| 306 | 4.1.2 | Cost Estimation | 25.57d? | 2007-08-16 | 2007-09-21 | 305 | 79.36d | 0d |  | Wizinowich [4.9%]; Dekany [14.7%]; Gavel [14.7%]; Bauman [14.7%]; Meguro [9.8%]; Johansson [9.8%]; Chin [9.8%]; Velur [14.7%]; Adkins [9.8%]; Le Mignant [4.9%] | 220h | 15,264.4 | assignment |
| 307 | 4.1.3 | Major Project Milestones | 6.57d? | 2007-08-16 | 2007-08-27 | 305 | 137.5d |  |  | Wizinowich [19%]; Dekany [38%] | 30h | 2,350.9 |  |
| 308 | 4.1.4 | Develop Full Schedule (MS Project Plan) | 13.57d? | 2007-09-21 | 2007-10-11 | 306 | 79.36d | 0d |  | Wizinowich [36.8%]; Dekany [18.4%]; Gavel [18.4%]; Max [9.2%] | 90h | 6,170.2 | end date |
| 309 | 4.2 | Risk Assessment & Management Plan | 34d? | 2007-07-18 | 2007-09-04 | 305SS | 131.5d | 57.83d |  | Wizinowich [3.7%]; Dekany [5.5%]; Gavel [5.5%] | 40h | 2,956.45 | lead; people |
| 310 | 4.3 | **Preliminary Design Phase Plan** | 183.64d? | 2007-03-05 | 2007-11-15 |  | 46.36d | 5.69d |  |  | 200h | 13,929.59 |  |
| 311 | 4.3.1 | Preliminary Design Phase Plan Version 1 (to Support Observatory FY08 Planning) | 20d? | 2007-03-05 | 2007-03-30 |  | 243d |  | start no earlier than 2007-03-05 | Wizinowich [9.4%]; Dekany [6.2%]; Gavel [6.2%]; Max [3.1%] | 40h | 2,798.55 | -2hr; later |
| 312 | 4.3.2 | Preliminary Design Phase Plan Version 2 | 18.75d? | 2007-08-16 | 2007-09-12 | 305 | 125.32d |  | start no earlier than 2007-04-09 | Wizinowich [20%]; Dekany [20%]; Gavel [20%]; Max [20%] | 80h | 5,597.1 |  |
| 313 | 4.3.3 | Preliminary Design Phase Plan Final Version | 15.57d? | 2007-10-25 | 2007-11-15 | 308FS+2w | 79.36d |  |  | Wizinowich [26.7%]; Dekany [14.4%]; Gavel [14.4%]; Max [10%] | 80h | 5,533.94 | -4hr |

Notes:
- 293: SA
- 302: PW
- 303: PW
- 304: PW
- 305: PW
- 306: PW
- 307: PW
- 308: PW
- 309: DG
- 310: PW
- 311: PW
- 312: PW
- 313: PW

| ID | WBS | Task | Duration | Start | Finish | Predecessors | Total slack | Free slack | Constraint | Resources | Work | Cost | Text1 |
| --- | --- | --- | --- | --- | --- | --- | --- | --- | --- | --- | --- | --- | --- |
| 314 | 4.4 | **Integration and Test Plans** | 70.4d? | 2007-08-16 | 2007-11-23 |  | 40.67d |  |  |  | 180h | 10,315.8 |  |
| 315 | 4.4.1 | **Subsystem Testing Plans** | 70.4d? | 2007-08-16 | 2007-11-23 |  | 40.67d | 0d |  |  | 80h | 4,584.8 |  |
| 316 | 4.4.1.1 | AO System Test Plan | 17.6d? | 2007-08-16 | 2007-09-11 | 305 | 73.67d | 0d |  | Neyman [14.2%] | 20h | 1,146.2 |  |
| 317 | 4.4.1.2 | Laser System Test Plan | 17.6d? | 2007-09-11 | 2007-10-05 | 316 | 73.67d | 0d |  | Neyman [14.2%] | 20h | 1,146.2 |  |
| 318 | 4.4.1.3 | Science Operations Test Plan | 17.6d? | 2007-10-05 | 2007-10-30 | 317 | 73.67d | 0d |  | Neyman [14.2%] | 20h | 1,146.2 |  |
| 319 | 4.4.1.4 | Science Instruments Test Plan | 17.6d? | 2007-10-30 | 2007-11-23 | 318 | 73.67d |  |  | Neyman [14.2%] | 20h | 1,146.2 |  |
| 320 | 4.4.2 | System Integration & Test Plans | 30d? | 2007-08-16 | 2007-09-27 | 305 | 114.07d | 40.4d |  | Neyman [41.7%] | 100h | 5,731 | assignment |
| 321 | 4.5 | Configuration Management Plan | 62.5d? | 2007-08-16 | 2007-11-13 | 305 | 81.57d | 7.9d | start no earlier than 2007-01-15 | Johnson [10%]; Randolph [10%]; Chin [5%] | 80h | 4,584.8 | assignment |
| 322 | 4.6 | Project Management Plan | 20d? | 2007-10-11 | 2007-11-08 | 308 | 84.93d | 11.26d | start no earlier than 2007-02-12 | Wizinowich [12.5%]; Dekany [12.5%]; Gavel [12.5%]; Max [12.5%] | 80h | 5,724 |  |
| 323 | 4.7 | SEMP Document | 13d? | 2007-11-23 | 2007-12-12 | 304, 310, 315, 320, 321, 322, 309 | 73.67d | 27.67d |  | Wizinowich [30.8%]; Dekany [15.4%]; Gavel [15.4%]; Max [15.4%] | 80h | 5,496.16 |  |

Notes:
- 314: CN
- 315: CN
- 316: CN
- 317: CN
- 318: CN
- 319: CN
- 320: CN
- 321: JJ
- 322: PW
- 323: PW
