# NGAO System Design Phase Schedule

Schedule from MS Project, 2006-06-21 to 2008-04-17, costs in $, A marks actual dates.
CARA

## Calendars

- Standard: Mon-Fri 08:00-12:00, 13:00-17:00; Sat-Sun off.

## Resources

| Resource | Group | Rate | Notes |
| --- | --- | --- | --- |
| Flicker | WMKO | 57.31 | AO Modeller |
| Gavel | UCSC | 111 | EC |
| Neyman | WMKO | 57.31 | AO |
| Dekany | COO | 88.89 | EC |
| Bouchez | COO | 88.89 | AO Scientist |
| Max | UCSC |  | EC, Science |
| Wizinowich | WMKO | 57.31 | EC |
| Britton | COO | 88.89 | AO Modeller |
| Moore | COO | 88.89 | Instrum Sci |
| Velur | COO | 88.89 | AO Scientist |
| Chin | WMKO | 57.31 | EE |
| Johansson | WMKO | 57.31 | SE, EE |
| Meguro | WMKO | 57.31 | ME |
| Stomski | WMKO | 57.31 | SE |
| Clare | WMKO | 62 | AO Modeller |
| Adkins | WMKO | 57.31 | Instruments |
| Bell | WMKO | 57.31 | ME |
| Sweeney | WMKO | 57.31 | MD |
| Kellner | WMKO | 57.31 | AO Postdoc |
| van Dam | WMKO | 57.31 | AO Scientist |
| Johnson | WMKO | 57.31 | SE |
| Bauman | UCSC | 87 | OE |
| Macintosh | UCSC | 97.3 | Science |
| Le Mignant | WMKO | 57.31 | Instrum Sci |
| Postdoc | UCSC | 34.54 | Science postdoc |
| Other | WMKO | 57.31 | Unassigned |
| Cameron | COO |  | Grad student |
| Randolph | WMKO | 57.31 | MD |
| Summers | WMKO | 57.31 | SE |
| Woillez | WMKO | 57.31 | KI Scientist |
| Ammons | UCSC |  | Grad student |
| Kupke | UCSC |  | AO Postdoc |
| Lockwood | UCSC | 100.6 | ME |
| Reinig | UCSC | 57.5 | EE, ECE |
| Ireland | COO |  | Postdoc |
| Student1 |  | 31 | Grad student |
| Student2 |  | 31 | Grad student |
| Adkins(IPM) | WMKO |  | IPM |

## Schedule

| ID | WBS | Task | Type | Duration | Start | Finish | Predecessors | Complete | Remaining | Total slack | Free slack | Constraint | Resources | Work | Actual work | Cost | Actual cost | Text1 |
| --- | --- | --- | --- | --- | --- | --- | --- | --- | --- | --- | --- | --- | --- | --- | --- | --- | --- | --- |
| 1 | 1 | **SD Phase Management** |  | 476.33d? | 2006-06-21 A | 2008-04-17 |  | 29% | 338.39d? | 0d |  |  |  | 2175h | 708h | 137,250.21 | 46,115.13 |  |
| 2 | 1.1 | **Planning and Contracting** |  | 365.26d? | 2006-06-21 A | 2007-11-14 |  | 73% | 99.45d? | 111.07d |  |  |  | 230h | 160h | 13,778.35 | 9,317.9 |  |
| 3 | 1.1.1 | NGAO Proposal to SSC | milestone | 0d | 2006-06-21 A | 2006-06-21 A |  | 100% |  |  |  | start no earlier than 2006-06-21 |  |  |  |  |  |  |
| 4 | 1.1.2 | Management Structure Decision by Directors | milestone | 0d | 2006-07-14 A | 2006-07-14 A | 3 | 100% |  |  |  | start no earlier than 2006-07-14 |  |  |  |  |  |  |
| 5 | 1.1.3 | SD Phase System Engineering Management Plan |  | 21d? | 2006-09-01 A | 2006-09-29 A | 4 | 100% |  |  |  | finish no earlier than 2006-09-29 | Max [8.9%]; Gavel [8.9%]; Dekany [8.9%]; Wizinowich [20.8%] | 80h | 80h | 5,004.2 | 5,004.2 |  |
| 6 | 1.1.4 | SD Phase Contracts Generated |  | 23d? | 2006-09-27 A | 2006-10-27 A |  | 100% |  |  |  | start no earlier than 2006-09-27 | Adkins(IPM) [16.7%]; Gavel [8.3%]; Dekany [8.3%] | 60h | 60h | 2,998.35 | 2,998.35 |  |
| 7 | 1.1.5 | Director Approval | milestone | 0d | 2006-10-09 A | 2006-10-09 |  | 75% | 0d | 383.33d | 0d | start no earlier than 2006-10-09 |  |  |  |  |  |  |
| 8 | 1.1.6 | SD Partner Contracts Issued | milestone | 0d | 2006-10-27 A | 2006-10-27 A | 6, 7 | 100% |  |  |  | start no earlier than 2006-10-13 |  |  |  |  |  |  |
| 9 | 1.1.7 | Mid-year Replan |  | 10d | 2007-03-05 A | 2007-03-16 |  | 50% | 5d | 283.33d |  | start no earlier than 2007-03-05 | Wizinowich [22.5%]; Dekany [10%]; Gavel [10%]; Max [7.5%] | 40h | 20h | 2,630.7 | 1,315.35 |  |
| 10 | 1.1.8 | FY08 Replan |  | 13.33d | 2007-10-25 | 2007-11-14 | 305 |  |  | 111.07d |  |  | Wizinowich [28.1%]; Dekany [12.5%]; Gavel [12.5%]; Max [9.4%] | 50h |  | 3,145.1 |  | have new WBS; to help align FY08 work |
| 11 | 1.2 | **Project Meetings** |  | 467d? | 2006-06-21 A | 2008-04-03 |  | 25% | 351.85d? | 9.33d |  |  |  | 1352h | 478h | 90,597.68 | 32,652.68 |  |
| 12 | 1.2.1 | Executive Committee Telecons |  | 467d | 2006-06-21 A | 2008-04-03 |  | 45% | 256.85d | 9.33d |  |  | Wizinowich [2.4%]; Dekany [2.4%]; Gavel [2.4%]; Max [2.4%] | 360h | 162h | 23,148 | 10,416.6 | ch end & time |
| 13 | 1.2.2 | Science Advisory Committee Telecons |  | 390d? | 2006-10-02 | 2008-03-28 |  |  |  | 13.33d |  | start no earlier than 2006-10-02 | Max [1.4%] | 40h |  |  |  |  |
| 14 | 1.2.3 | **Team Meetings** |  | 344.5d | 2006-09-14 A | 2008-01-09 |  | 35% | 224.67d | 70.83d |  |  |  | 952h | 316h | 67,449.68 | 22,236.08 |  |
| 15 | 1.2.3.1 | Team Meeting #1 (mgmt, science & technical - Irvine) |  | 1d | 2006-09-14 A | 2006-09-14 A |  | 100% |  |  |  | start no earlier than 2006-09-14 | Wizinowich; Dekany; Gavel; Max; Bauman; Bouchez; Velur; Flicker; Neyman; Britton; Le Mignant | 68h | 68h | 4,618.48 | 4,618.48 |  |
| 16 | 1.2.3.2 | Team Meeting #2 (CIT) |  | 1d | 2006-11-14 A | 2006-11-14 A |  | 100% |  |  |  | start no earlier than 2006-11-14 | Wizinowich; Dekany; Gavel; Max; Bauman; Bouchez; Velur; Flicker; Neyman; Britton; Le Mignant | 80h | 80h | 5,677.6 | 5,677.6 |  |
| 17 | 1.2.3.3 | Team Videocon #3 |  | 0.5d | 2006-12-13 A | 2006-12-13 A |  | 100% |  |  |  | start no earlier than 2006-12-13 | Wizinowich; Dekany; Gavel; Max; Bauman; Bouchez; Velur; Flicker; Neyman; Britton; Le Mignant | 44h | 44h | 3,131.2 | 3,131.2 |  |
| 18 | 1.2.3.4 | Team Meeting #4 (Keck) |  | 1d | 2007-01-22 A | 2007-01-22 A |  | 100% |  |  |  | start no earlier than 2007-01-22 | Wizinowich; Dekany; Gavel; Max; Bauman; Bouchez; Velur; Flicker; Neyman; Britton; Le Mignant | 80h | 80h | 5,677.6 | 5,677.6 |  |
| 19 | 1.2.3.5 | Team Videocon #5 |  | 0.5d | 2007-03-07 A | 2007-03-07 A |  | 100% |  |  |  | start no earlier than 2007-03-07 | Wizinowich; Dekany; Gavel; Max; Bauman; Bouchez; Velur; Flicker; Neyman; Britton; Le Mignant | 44h | 44h | 3,131.2 | 3,131.2 |  |
| 20 | 1.2.3.6 | Team Meeting #6 (UCSC) |  | 1d | 2007-04-18 | 2007-04-18 |  |  |  | 260.33d |  | start no earlier than 2007-04-18 | Wizinowich; Dekany; Gavel; Max; Bauman; Bouchez; Velur; Flicker; Neyman; Britton; Le Mignant | 80h |  | 5,677.6 |  |  |
| 21 | 1.2.3.7 | Team Videocon #7 |  | 0.5d | 2007-05-30 | 2007-05-30 |  |  |  | 230.33d |  | finish no earlier than 2007-05-30 | Wizinowich; Dekany; Gavel; Max; Bauman; Bouchez; Velur; Flicker; Neyman; Britton; Le Mignant | 44h |  | 3,131.2 |  |  |
| 22 | 1.2.3.8 | Team Retreat #8 (UCSC) |  | 2.5d | 2007-07-09 | 2007-07-11 |  |  |  | 0d |  | start no earlier than 2007-07-09 | Wizinowich; Dekany; Gavel; Max; Bauman; Bouchez; Velur; Flicker; Neyman; Britton; Le Mignant | 220h |  | 15,656 |  |  |
| 23 | 1.2.3.9 | Team Videocon #9 |  | 0.5d | 2007-08-22 | 2007-08-22 |  |  |  | 170.83d |  | start no earlier than 2007-08-22 | Wizinowich; Dekany; Gavel; Max; Bauman; Bouchez; Velur; Flicker; Neyman; Britton; Le Mignant | 44h |  | 3,131.2 |  |  |
| 24 | 1.2.3.10 | Team Meeting #10 (CIT) |  | 1d | 2007-09-11 | 2007-09-11 |  |  |  | 156.33d |  | start no earlier than 2007-09-11 | Wizinowich; Dekany; Gavel; Max; Bauman; Bouchez; Velur; Flicker; Neyman; Britton; Le Mignant | 80h |  | 5,677.6 |  |  |
| 25 | 1.2.3.11 | Team Videocon #11 |  | 0.5d | 2007-11-05 | 2007-11-05 |  |  |  | 117.83d |  | start no earlier than 2007-11-05 | Wizinowich; Dekany; Gavel; Max; Bauman; Bouchez; Velur; Flicker; Neyman; Britton; Le Mignant | 44h |  | 3,131.2 |  |  |
| 26 | 1.2.3.12 | Team Meeting #12 (Keck) |  | 1d | 2007-12-12 | 2007-12-12 |  |  |  | 90.33d |  | start no earlier than 2007-12-12 | Wizinowich; Dekany; Gavel; Max; Bauman; Bouchez; Velur; Flicker; Neyman; Britton; Le Mignant | 80h |  | 5,677.6 |  |  |
| 27 | 1.2.3.13 | Team Videocon #13 |  | 0.5d | 2008-01-09 | 2008-01-09 |  |  |  | 70.83d |  | start no earlier than 2008-01-09 | Wizinowich; Dekany; Gavel; Max; Bauman; Bouchez; Velur; Flicker; Neyman; Britton; Le Mignant | 44h |  | 3,131.2 |  |  |

Notes:
- 1: PW
- 2: PW
- 5: PW
- 6: PW
- 8: PW
- 9: PW
- 10: PW
- 12: PW / 1 hr per week x 4 persons for duration of SD phase is about 400 wk-hours total - RD
- 13: CM

| ID | WBS | Task | Type | Duration | Start | Finish | Predecessors | Complete | Remaining | Total slack | Free slack | Constraint | Resources | Work | Actual work | Cost | Actual cost | Text1 |
| --- | --- | --- | --- | --- | --- | --- | --- | --- | --- | --- | --- | --- | --- | --- | --- | --- | --- | --- |
| 28 | 1.3 | **Tracking and Reporting** |  | 404d? | 2006-09-16 A | 2008-04-03 |  | 40% | 242.4d? | 9.33d |  |  |  | 120h | 70h | 5,863.85 | 4,144.55 |  |
| 29 | 1.3.1 | Report Preparation/Presentation |  | 312.5d? | 2006-10-02 A | 2007-12-12 |  | 40% | 187.5d? | 0d |  | start no earlier than 2006-10-02 | Wizinowich [2%]; Dekany [2%]; Gavel [2%]; Max [2%] | 120h | 70h | 5,863.85 | 4,144.55 |  |
| 30 | 1.3.2 | Keck Science Meeting 06 (UCI) | milestone | 0d | 2006-09-16 A | 2006-09-16 A |  | 100% |  |  |  | finish no earlier than 2006-09-16 |  |  |  |  |  |  |
| 31 | 1.3.3 | SSC meeting (UCLA) | milestone | 0d | 2006-11-06 A | 2006-11-06 A |  | 100% |  |  |  | start no earlier than 2006-11-06 |  |  |  |  |  |  |
| 32 | 1.3.4 | SSC meeting (Keck) | milestone | 0d | 2007-01-24 A | 2007-01-24 A |  | 100% |  |  |  | start no earlier than 2007-01-24 |  |  |  |  |  |  |
| 33 | 1.3.5 | SSC meeting (CA) | milestone | 0d | 2007-04-03 A | 2007-04-03 A |  | 100% |  |  |  | start no earlier than 2007-04-03 |  |  |  |  |  |  |
| 34 | 1.3.6 | SSC meeting (Keck) | milestone | 0d | 2007-06-20 | 2007-06-20 |  |  |  | 216.33d |  | start no earlier than 2007-06-20 |  |  |  |  |  |  |
| 35 | 1.3.7 | Keck Science Meeting 07 | milestone | 0d | 2007-09-22 | 2007-09-22 |  |  |  | 148.33d |  | finish no earlier than 2007-09-22 |  |  |  |  |  |  |
| 36 | 1.3.8 | SSC meeting (CA) | milestone | 0d | 2007-11-06 | 2007-11-06 |  |  |  | 117.33d |  | start no earlier than 2007-11-06 |  |  |  |  |  |  |
| 37 | 1.3.9 | SSC meeting (Keck) | milestone | 0d | 2008-01-24 | 2008-01-24 |  |  |  | 60.33d |  | start no earlier than 2008-01-24 |  |  |  |  |  |  |
| 38 | 1.3.10 | SSC meeting (CA) | milestone | 0d | 2008-04-03 | 2008-04-03 |  |  |  | 9.33d |  | finish no earlier than 2008-04-03 |  |  |  |  |  |  |
| 39 | 1.4 | **Proposals & Fundraising** |  | 45d? | 2006-10-27 | 2007-01-01 |  |  |  | 338.33d |  |  |  |  |  |  |  |  |
| 40 | 1.4.1 | Dates & deliverables identified by Directors | milestone | 0d | 2006-10-27 | 2006-10-27 | 7FS+3w |  |  | 383.33d | 45d |  |  |  |  |  |  |  |
| 41 | 1.4.2 | Support Advancement Office | milestone | 0d? | 2007-01-01 | 2007-01-01 | 40 |  |  | 338.33d |  | start no earlier than 2007-01-01 | Wizinowich [2.9%]; Max [3.8%]; Gavel [0.5%]; Dekany [0.5%] |  |  |  |  | lead gone |
| 42 | 1.5 | **System Design Report & Review** |  | 143.33d? | 2007-10-01 | 2008-04-17 |  |  |  | 0d |  |  |  | 473h |  | 27,010.33 |  |  |
| 43 | 1.5.1 | System Design Report |  | 8d? | 2008-02-20 | 2008-03-03 | 323, 302, 133 |  |  | 0d |  |  | Wizinowich [31.2%]; Gavel [7.8%]; Dekany [7.8%]; Adkins [7.8%]; Max [7.8%] | 40h |  | 2,432.2 |  |  |
| 44 | 1.5.2 | **System Design Review** |  | 143.33d? | 2007-10-01 | 2008-04-17 |  |  |  | 0d |  |  |  | 433h |  | 24,578.13 |  |  |
| 45 | 1.5.2.1 | Identify Reviewers |  | 55d? | 2007-10-01 | 2007-12-14 |  |  |  | 59.33d | 55.33d | start no earlier than 2007-10-01 | Adkins(IPM) [2.3%]; Wizinowich [0.5%]; Max [0.2%]; Gavel [0.2%]; Dekany [0.2%] | 15h |  | 314.51 |  |  |
| 46 | 1.5.2.2 | Review Package Distributed |  | 1d | 2008-03-03 | 2008-03-04 | 43, 45 |  |  | 4d | 0d | start no earlier than 2008-01-14 | Adkins(IPM) | 8h |  |  |  |  |
| 47 | 1.5.2.3 | Reviewer Comments Addressed |  | 5d? | 2008-03-18 | 2008-03-25 | 46FS+10d |  |  | 4d |  | finish no earlier than 2008-02-01 | Wizinowich [75%]; Dekany [60%]; Gavel [60%]; Max [65%]; Adkins(IPM) [40%] | 120h |  | 6,516.66 |  |  |
| 48 | 1.5.2.4 | System Design Review Support |  | 20d? | 2008-03-03 | 2008-03-31 | 43 |  |  | 0d |  | start no earlier than 2007-01-16 | Wizinowich [15%]; Dekany [15%]; Gavel [15%]; Max [15%]; Bauman [7.5%]; Bouchez [2.5%]; Velur [10%]; Flicker [10%]; Neyman [16.2%]; Le Mignant [10%]; Johansson [10%]; Adkins(IPM) [10%]; Chin [5%]; Kellner [5%]; Moore [10%] | 250h |  | 15,574.74 |  |  |
| 49 | 1.5.2.5 | System Design Review Meeting | milestone | 0d | 2008-03-31 | 2008-03-31 | 48, 47 |  |  | 0d |  | start no earlier than 2008-02-06 |  |  |  |  |  |  |
| 50 | 1.5.2.6 | Reviewer Report Received | milestone | 0d | 2008-04-14 | 2008-04-14 | 49FS+10d |  |  | 0d |  | start no earlier than 2008-02-15 |  |  |  |  |  |  |
| 51 | 1.5.2.7 | Response to Reviewer Report & Distribution |  | 3d? | 2008-04-14 | 2008-04-17 | 50 |  |  | 0d |  | start no earlier than 2008-02-18 | Wizinowich [41.7%]; Dekany [33.3%]; Gavel [33.3%]; Max [41.7%]; Adkins(IPM) [16.7%] | 40h |  | 2,172.22 |  |  |

Notes:
- 28: PW
- 29: PW
- 42: SA
- 43: PW
- 44: PW
- 45: SA
- 46: SA
- 47: PW
- 48: PW
- 49: SA
- 51: PW

| ID | WBS | Task | Duration | Start | Finish | Complete | Remaining | Total slack | Constraint | Resources | Work | Actual work | Cost | Actual cost | Text1 |
| --- | --- | --- | --- | --- | --- | --- | --- | --- | --- | --- | --- | --- | --- | --- | --- |
| 52 | 2 | **System Requirements** | 285d? | 2006-10-02 A | 2007-11-02 | 44% | 158.82d? | 118.33d |  |  | 3524h | 1428h | 121,852.62 | 48,881.42 |  |
| 53 | 2.1 | **Science Requirements** | 271d? | 2006-10-02 A | 2007-10-15 | 46% | 147.16d? | 132.33d |  |  | 3090h | 1330h | 96,474.8 | 43,012.4 |  |
| 54 | 2.1.1 | **Solar System Science Requirements** | 135d? | 2006-10-02 A | 2007-04-06 | 60% | 54.19d? | 268.33d |  |  | 650h | 405h | 20,150 | 12,555 |  |
| 55 | 2.1.1.1 | **Companions & Multiplicity of Small Solar System Bodies** | 75d? | 2006-10-02 A | 2007-01-12 | 74% | 19.5d? | 328.33d |  |  | 250h | 192.5h | 7,750 | 5,967.5 |  |
| 56 | 2.1.1.1.1 | Point Source Companion Sensitivity Requirements | 45d? | 2006-10-02 A | 2006-12-01 | 75% | 11.25d? | 358.33d | finish no earlier than 2006-12-01 | Student1 [27.8%] | 100h | 75h | 3,100 | 2,325 |  |
| 57 | 2.1.1.1.2 | Spectral Sensitivity & Spectral Resolution Requirements | 45d? | 2006-10-02 A | 2006-12-01 | 85% | 6.75d? | 358.33d | finish no earlier than 2006-12-01 | Student1 [27.8%] | 100h | 85h | 3,100 | 2,635 |  |
| 58 | 2.1.1.1.3 | Observing Scenarios | 30d? | 2006-12-04 A | 2007-01-12 | 50% | 15d? | 328.33d | finish no earlier than 2007-01-12 | Student1 [10.4%] | 25h | 12.5h | 775 | 387.5 |  |
| 59 | 2.1.1.1.4 | Science Instrument Requirements | 30d? | 2006-12-04 A | 2007-01-12 | 80% | 6d? | 328.33d | start no earlier than 2006-12-04 | Student1 [10.4%] | 25h | 20h | 775 | 620 |  |
| 60 | 2.1.1.2 | **Moons of the Giant Planets** | 70d? | 2006-12-04 A | 2007-03-09 | 31% | 48.3d? | 288.33d |  |  | 150h | 32.5h | 4,650 | 1,007.5 |  |
| 61 | 2.1.1.2.1 | Performance Requirements | 40d? | 2006-12-04 A | 2007-01-26 | 10% | 36d? | 318.33d | start no earlier than 2006-12-04 | Student1 [31.2%] | 100h | 10h | 3,100 | 310 |  |
| 62 | 2.1.1.2.2 | Observing Scenarios | 30d? | 2007-01-29 A | 2007-03-09 | 50% | 15d? | 288.33d | finish no earlier than 2007-03-09 | Student1 [10.4%] | 25h | 12.5h | 775 | 387.5 |  |
| 63 | 2.1.1.2.3 | Science Instrument Requirements | 30d? | 2007-01-29 A | 2007-03-09 | 40% | 18d? | 288.33d | start no earlier than 2007-01-29 | Student1 [10.4%] | 25h | 10h | 775 | 310 |  |
| 64 | 2.1.1.3 | **Shape & Size of Asteroids** | 50d? | 2007-01-29 A | 2007-04-06 | 68% | 16.25d? | 268.33d |  |  | 250h | 180h | 7,750 | 5,580 |  |
| 65 | 2.1.1.3.1 | Spatial Resolution Requirements | 25d? | 2007-01-29 A | 2007-03-02 | 70% | 7.5d? | 293.33d | start no earlier than 2007-01-29 | Student1 [50%] | 100h | 70h | 3,100 | 2,170 |  |
| 66 | 2.1.1.3.2 | Spectral Sensitivity & Spectral Resolution Requirements | 25d? | 2007-01-29 A | 2007-03-02 | 80% | 5d? | 293.33d | start no earlier than 2007-01-29 | Student1 [50%] | 100h | 80h | 3,100 | 2,480 |  |
| 67 | 2.1.1.3.3 | Observing Scenarios | 25d? | 2007-03-05 A | 2007-04-06 | 40% | 15d? | 268.33d | finish no earlier than 2007-04-06 | Student1 [12.5%] | 25h | 10h | 775 | 310 |  |
| 68 | 2.1.1.3.4 | Science Instrument Requirements | 25d? | 2007-03-05 A | 2007-04-06 | 80% | 5d? | 268.33d | start no earlier than 2007-03-05 | Student1 [12.5%] | 25h | 20h | 775 | 620 |  |
| 69 | 2.1.2 | **Galactic Science Requirements** | 135d? | 2006-10-02 A | 2007-04-06 | 35% | 88.2d? | 268.33d |  |  | 1200h | 355h | 37,200 | 11,005 |  |
| 70 | 2.1.2.1 | **Galactic Center Proper Motions: Astrometry** | 75d? | 2006-10-02 A | 2007-01-12 | 60% | 29.69d? | 328.33d |  |  | 200h | 97.5h | 6,200 | 3,022.5 |  |
| 71 | 2.1.2.1.1 | Astrometry requirements | 50d? | 2006-10-02 A | 2006-12-08 | 40% | 30d? | 353.33d | start no earlier than 2006-10-02 | Student2 [37.5%] | 150h | 60h | 4,650 | 1,860 | mv into FY07 |
| 72 | 2.1.2.1.2 | Observing Scenarios | 35d? | 2006-11-27 A | 2007-01-12 | 75% | 8.75d? | 328.33d | finish no earlier than 2007-01-12 | Student2 [8.9%] | 25h | 18.75h | 775 | 581.25 |  |
| 73 | 2.1.2.1.3 | Science Instrument Requirements | 35d? | 2006-11-27 A | 2007-01-12 | 75% | 8.75d? | 328.33d | start no earlier than 2006-11-27 | Student2 [8.9%] | 25h | 18.75h | 775 | 581.25 |  |
| 74 | 2.1.2.2 | **Galactic Center Radial Velocities & Stellar Populations: Integral Field Spectroscopy** | 75d? | 2006-11-27 A | 2007-03-09 | 53% | 35.36d? | 288.33d |  |  | 200h | 102.5h | 6,200 | 3,177.5 |  |
| 75 | 2.1.2.2.1 | Performance Requirements | 45d? | 2006-11-27 A | 2007-01-26 | 50% | 22.5d? | 318.33d | finish no earlier than 2007-01-26 | Student2 [41.7%] | 150h | 75h | 4,650 | 2,325 |  |
| 76 | 2.1.2.2.2 | Observing Scenarios | 30d? | 2007-01-29 A | 2007-03-09 | 50% | 15d? | 288.33d | start no earlier than 2007-01-29 | Student2 [10.4%] | 25h | 12.5h | 775 | 387.5 |  |
| 77 | 2.1.2.2.3 | Science Instrument Requirements | 30d? | 2007-01-29 A | 2007-03-09 | 60% | 12d? | 288.33d | start no earlier than 2007-01-29 | Student2 [10.4%] | 25h | 15h | 775 | 465 |  |

Notes:
- 52: PW
- 53: CM
- 54: FM
- 69: ML
- 70: AG
- 74: AG

| ID | WBS | Task | Duration | Start | Finish | Complete | Remaining | Total slack | Constraint | Resources | Work | Actual work | Cost | Actual cost | Text1 |
| --- | --- | --- | --- | --- | --- | --- | --- | --- | --- | --- | --- | --- | --- | --- | --- |
| 78 | 2.1.2.3 | **Galactic Center Nature of Sgr A*: 3-5 um Color & 2 um Polarimetry Variability** | 50d? | 2007-01-29 A | 2007-04-06 | 10% | 45d? | 268.33d |  |  | 200h | 20h | 6,200 | 620 |  |
| 79 | 2.1.2.3.1 | Performance Requirements | 25d? | 2007-01-29 A | 2007-03-02 | 10% | 22.5d? | 293.33d | finish no earlier than 2007-03-02 | Student2 [75%] | 150h | 15h | 4,650 | 465 |  |
| 80 | 2.1.2.3.2 | Observing Scenarios | 25d? | 2007-03-05 A | 2007-04-06 | 10% | 22.5d? | 268.33d | start no earlier than 2007-03-05 | Student2 [12.5%] | 25h | 2.5h | 775 | 77.5 |  |
| 81 | 2.1.2.3.3 | Science Instrument Requirements | 25d? | 2007-03-05 A | 2007-04-06 | 10% | 22.5d? | 268.33d | finish no earlier than 2007-04-06 | Student2 [12.5%] | 25h | 2.5h | 775 | 77.5 |  |
| 82 | 2.1.2.4 | **Planets around Low Mass Stars & Brown Dwarfs: Companion Sensitivity** | 75d? | 2006-10-02 A | 2007-01-12 | 54% | 34.38d? | 328.33d |  |  | 200h | 115h | 6,200 | 3,565 |  |
| 83 | 2.1.2.4.1 | Companion Sensitivity Performance Requirements | 50d? | 2006-10-02 A | 2006-12-08 | 60% | 20d? | 353.33d | start no earlier than 2006-10-02 | Student2 [37.5%] | 150h | 90h | 4,650 | 2,790 | mv into FY07 |
| 84 | 2.1.2.4.2 | Observing Scenarios | 35d? | 2006-11-27 A | 2007-01-12 | 40% | 21d? | 328.33d | start no earlier than 2006-11-27 | Student2 [8.9%] | 25h | 10h | 775 | 310 |  |
| 85 | 2.1.2.4.3 | Science Instrument Requirements | 35d? | 2006-11-27 A | 2007-01-12 | 60% | 14d? | 328.33d | start no earlier than 2006-11-27 | Student2 [8.9%] | 25h | 15h | 775 | 465 |  |
| 86 | 2.1.2.5 | **Debris Disks, Protostellar Envelopes & Outflows: Contrast** | 50d? | 2007-01-29 A | 2007-04-06 | 10% | 45d? | 268.33d |  |  | 200h | 20h | 6,200 | 620 |  |
| 87 | 2.1.2.5.1 | Contrast Performance Requirements | 25d? | 2007-01-29 A | 2007-03-02 | 10% | 22.5d? | 293.33d | finish no earlier than 2007-03-02 | Student2 [75%] | 150h | 15h | 4,650 | 465 |  |
| 88 | 2.1.2.5.2 | Observing Scenarios | 25d? | 2007-03-05 A | 2007-04-06 | 10% | 22.5d? | 268.33d | start no earlier than 2007-03-05 | Student2 [12.5%] | 25h | 2.5h | 775 | 77.5 |  |
| 89 | 2.1.2.5.3 | Science Instrument Requirements | 25d? | 2007-03-05 A | 2007-04-06 | 10% | 22.5d? | 268.33d | start no earlier than 2007-03-05 | Student2 [12.5%] | 25h | 2.5h | 775 | 77.5 |  |
| 90 | 2.1.2.6 | **Debris Disks, Protostellar Envelopes & Outflows: Polarimetry** | 75d? | 2006-11-27 | 2007-03-09 |  |  | 288.33d |  |  | 200h |  | 6,200 |  |  |
| 91 | 2.1.2.6.1 | Polarimetry Performance Requirements | 45d? | 2006-11-27 | 2007-01-26 |  |  | 318.33d | finish no earlier than 2007-01-26 | Student2 [41.7%] | 150h |  | 4,650 |  |  |
| 92 | 2.1.2.6.2 | Observing Scenarios | 30d? | 2007-01-29 | 2007-03-09 |  |  | 288.33d | start no earlier than 2007-01-29 | Student2 [10.4%] | 25h |  | 775 |  |  |
| 93 | 2.1.2.6.3 | Science Instrument Requirements | 30d? | 2007-01-29 | 2007-03-09 |  |  | 288.33d | start no earlier than 2007-01-29 | Student2 [10.4%] | 25h |  | 775 |  |  |
| 94 | 2.1.3 | **Extragalactic Science Requirements** | 150d? | 2006-10-02 A | 2007-04-27 | 51% | 73.93d? | 253.33d |  |  | 1000h | 530h | 34,540 | 18,306.2 |  |
| 95 | 2.1.3.1 | **Resolved Stellar Populations in Crowded Fields** | 90d? | 2006-10-02 A | 2007-02-02 | 57% | 38.57d? | 313.33d |  |  | 300h | 177.5h | 10,362 | 6,130.85 |  |
| 96 | 2.1.3.1.1 | Performance Requirements | 60d? | 2006-10-02 A | 2006-12-22 | 60% | 24d? | 343.33d | start no earlier than 2006-10-02 | Postdoc [52.1%] | 250h | 150h | 8,635 | 5,181 | mv into FY07 |
| 97 | 2.1.3.1.2 | Observing Scenarios | 40d? | 2006-12-11 A | 2007-02-02 | 60% | 16d? | 313.33d | finish no earlier than 2007-02-02 | Postdoc [7.8%] | 25h | 15h | 863.5 | 518.1 |  |
| 98 | 2.1.3.1.3 | Science Instrument Requirements | 40d? | 2006-12-11 A | 2007-02-02 | 50% | 20d? | 313.33d | start no earlier than 2006-12-11 | Postdoc [7.8%] | 25h | 12.5h | 863.5 | 431.75 |  |
| 99 | 2.1.3.2 | **High Redshift Galaxies** | 90d? | 2006-10-02 A | 2007-02-02 | 67% | 29.57d? | 313.33d |  |  | 300h | 205h | 10,362 | 7,080.7 |  |
| 100 | 2.1.3.2.1 | Encircled Energy (& d-IFU) Performance Requirements | 60d? | 2006-10-02 A | 2006-12-22 | 70% | 18d? | 343.33d | start no earlier than 2006-10-02 | Postdoc [41.7%] | 200h | 140h | 6,908 | 4,835.6 | mv into FY07 |
| 101 | 2.1.3.2.2 | Observing Scenarios | 40d? | 2006-12-11 A | 2007-02-02 | 70% | 12d? | 313.33d | start no earlier than 2006-12-11 | Postdoc [15.6%] | 50h | 35h | 1,727 | 1,208.9 |  |
| 102 | 2.1.3.2.3 | Science Instrument Requirements | 40d? | 2006-12-11 A | 2007-02-02 | 60% | 16d? | 313.33d | start no earlier than 2006-12-11 | Postdoc [15.6%] | 50h | 30h | 1,727 | 1,036.2 |  |

Notes:
- 78: AG
- 82: ML
- 86: LH
- 94: CM

| ID | WBS | Task | Duration | Start | Finish | Predecessors | Complete | Remaining | Total slack | Free slack | Constraint | Resources | Work | Actual work | Cost | Actual cost | Text1 |
| --- | --- | --- | --- | --- | --- | --- | --- | --- | --- | --- | --- | --- | --- | --- | --- | --- | --- |
| 103 | 2.1.3.3 | **Nearby Galaxies** | 100d? | 2006-12-11 A | 2007-04-27 |  | 40% | 60d? | 253.33d |  |  |  | 200h | 80h | 6,908 | 2,763.2 |  |
| 104 | 2.1.3.3.1 | Encircled Energy & PSF Performance Requirements | 60d? | 2006-12-11 A | 2007-03-02 |  | 40% | 36d? | 293.33d |  | finish no earlier than 2007-03-02 | Postdoc [31.2%] | 150h | 60h | 5,181 | 2,072.4 |  |
| 105 | 2.1.3.3.2 | Observing Scenarios | 40d? | 2007-03-05 A | 2007-04-27 |  | 20% | 32d? | 253.33d |  | finish no earlier than 2007-04-27 | Postdoc [7.8%] | 25h | 5h | 863.5 | 172.7 |  |
| 106 | 2.1.3.3.3 | Science Instrument Requirements | 40d? | 2007-03-05 A | 2007-04-27 |  | 60% | 16d? | 253.33d |  | start no earlier than 2007-03-05 | Postdoc [7.8%] | 25h | 15h | 863.5 | 518.1 |  |
| 107 | 2.1.3.4 | **Gravitational Lensing** | 100d? | 2006-12-11 A | 2007-04-27 |  | 39% | 61.43d? | 253.33d |  |  |  | 200h | 67.5h | 6,908 | 2,331.45 |  |
| 108 | 2.1.3.4.1 | Encircled Energy & PSF Performance Requirements | 60d? | 2006-12-11 A | 2007-03-02 |  | 30% | 42d? | 293.33d |  | start no earlier than 2006-12-11 | Postdoc [31.2%] | 150h | 45h | 5,181 | 1,554.3 |  |
| 109 | 2.1.3.4.2 | Observing Scenarios | 40d? | 2007-03-05 A | 2007-04-27 |  | 30% | 28d? | 253.33d |  | start no earlier than 2007-03-05 | Postdoc [7.8%] | 25h | 7.5h | 863.5 | 259.05 |  |
| 110 | 2.1.3.4.3 | Science Instrument Requirements | 40d? | 2007-03-05 A | 2007-04-27 |  | 60% | 16d? | 253.33d |  | start no earlier than 2007-03-05 | Postdoc [7.8%] | 25h | 15h | 863.5 | 518.1 |  |
| 111 | 2.1.4 | **Science Requirements Summary** | 271d? | 2006-10-02 A | 2007-10-15 |  | 25% | 202.98d? | 122.83d |  |  |  | 240h | 40h | 4,584.8 | 1,146.2 |  |
| 112 | 2.1.4.1 | Science Requirements Summary Rev 1 | 14d? | 2006-10-02 A | 2006-10-19 A |  | 100% |  |  |  | finish no earlier than 2006-10-19 | Max [17.9%]; Wizinowich [17.9%] | 40h | 40h | 1,146.2 | 1,146.2 |  |
| 113 | 2.1.4.2 | Science Requirements Summary Rev 2 | 14d? | 2007-02-13 | 2007-03-02 |  |  |  | 283.83d | 4d | start no earlier than 2007-02-13 | Max [89.3%]; Wizinowich [17.9%] | 120h |  | 1,146.2 |  | assignment |
| 114 | 2.1.4.3 | Science Requirements Summary Rev 3 | 13.89d? | 2007-06-05 | 2007-06-22 |  |  |  | 203.33d | 4d | finish no earlier than 2007-06-22 | Max [18%]; Wizinowich [18%] | 40h |  | 1,146.2 |  |  |
| 115 | 2.1.4.4 | Science Requirements Summary Final | 13.89d? | 2007-09-26 | 2007-10-15 |  |  |  | 81.33d | 4d | finish no earlier than 2007-10-15 | Max [18%]; Wizinowich [18%] | 40h |  | 1,146.2 |  |  |
| 116 | 2.2 | **Observatory Requirements** | 245d? | 2006-10-02 A | 2007-09-07 |  | 43% | 139.05d? | 107.33d |  |  |  | 224h | 72h | 13,342.72 | 4,378.96 |  |
| 117 | 2.2.1 | Development Requirements | 40d? | 2006-10-02 A | 2006-11-24 A |  | 100% |  |  |  | start no earlier than 2006-10-02 | Neyman [2.5%]; Wizinowich [2.5%] | 16h | 16h | 916.96 | 916.96 |  |
| 118 | 2.2.2 | Observatory Interface Requirements | 20d? | 2006-10-02 A | 2006-10-27 A |  | 100% |  |  |  | start no earlier than 2006-10-02 | Neyman [5%]; Wizinowich [5%]; Adkins [5%] | 24h | 24h | 1,375.44 | 1,375.44 |  |
| 119 | 2.2.3 | Science Operations Requirements | 40d? | 2006-10-02 A | 2006-11-24 |  | 50% | 20d? | 107.33d | 0d | finish no earlier than 2006-11-24 | Le Mignant [10%]; Wizinowich [5%]; Bouchez [5%] | 64h | 32h | 4,173.12 | 2,086.56 |  |
| 120 | 2.2.4 | Observatory Requirements Rev 2 | 15d? | 2007-01-22 | 2007-02-09 | 117FS+8w, 118FS+8w, 119FS+8w |  |  | 107.33d | 0d |  | Neyman [20%]; Meguro [8.3%]; Le Mignant [13.3%]; Adkins [8.3%]; Johansson [8.3%]; Chin [8.3%] | 80h |  | 4,584.8 |  | assignments |
| 121 | 2.2.5 | Observatory Requirements Rev 3 | 30d? | 2007-04-09 | 2007-05-18 | 120FS+8w |  |  | 107.33d | 0d |  | Neyman [8.3%] | 20h |  | 1,146.2 |  |  |
| 122 | 2.2.6 | Observatory Requirements Rev 4 | 40d? | 2007-07-16 | 2007-09-07 | 121FS+8w |  |  | 107.33d | 30d |  | Neyman [6.2%] | 20h |  | 1,146.2 |  |  |
| 123 | 2.3 | **System Requirements Document** | 280d? | 2006-10-09 A | 2007-11-02 |  | 19% | 226.42d? | 118.33d |  |  |  | 210h | 26h | 12,035.1 | 1,490.06 |  |
| 124 | 2.3.1 | **Traceability Matrix** | 270d? | 2006-10-09 A | 2007-10-20 |  | 12% | 237.07d? | 128.33d |  |  |  | 130h | 5h | 7,450.3 | 286.55 |  |
| 125 | 2.3.1.1 | Traceability Matrix Rev 1 | 10d? | 2006-10-09 A | 2006-10-20 |  | 50% | 5d? | 388.33d |  | finish no earlier than 2006-10-20 | Neyman [12.5%] | 10h | 5h | 573.1 | 286.55 |  |
| 126 | 2.3.1.2 | Traceability Matrix Rev 2 | 12d? | 2007-02-12 | 2007-02-27 |  |  |  | 286.83d | 7d | start no earlier than 2007-02-12 | Neyman [25%]; Wizinowich [25%]; Adkins [25%]; Flicker [25%] | 80h |  | 4,584.8 |  |  |
| 127 | 2.3.1.3 | Traceability Matrix Rev 3 | 10d? | 2007-06-15 | 2007-06-28 |  |  |  | 199.33d | 0d | finish no earlier than 2007-06-28 | Neyman [25%] | 20h |  | 1,146.2 |  |  |
| 128 | 2.3.1.4 | Traceability Matrix Rev 4 | 9d? | 2007-10-09 | 2007-10-20 |  |  |  | 77.33d | 0d | finish no earlier than 2007-10-20 | Neyman [27.8%] | 20h |  | 1,146.2 |  |  |

Notes:
- 111: CM
- 116: CN
- 117: CN
- 118: CN
- 119: DLM
- 120: CN
- 121: CN
- 122: CN
- 124: CN
- 125: CN
- 126: CN
- 127: CN
- 128: CN

| ID | WBS | Task | Duration | Start | Finish | Predecessors | Complete | Remaining | Total slack | Free slack | Constraint | Resources | Work | Actual work | Cost | Actual cost | Text1 |
| --- | --- | --- | --- | --- | --- | --- | --- | --- | --- | --- | --- | --- | --- | --- | --- | --- | --- |
| 129 | 2.3.2 | **System Requirements Document** | 245d | 2006-11-27 A | 2007-11-02 |  | 26% | 180.69d | 118.33d |  |  |  | 80h | 21h | 4,584.8 | 1,203.51 |  |
| 130 | 2.3.2.1 | SRD Rev 1 | 10d | 2006-11-27 A | 2006-12-08 A | 112, 125, 117, 118, 119 | 100% |  |  |  | start no earlier than 2006-11-27 | Wizinowich [25%] | 20h | 20h | 1,146.2 | 1,146.2 |  |
| 131 | 2.3.2.2 | SRD Rev 2 | 10d | 2007-03-09 A | 2007-03-22 | 113, 126, 120 | 5% | 9.5d | 279.33d |  | start no earlier than 2007-03-09 | Neyman [25%] | 20h | 1h | 1,146.2 | 57.31 |  |
| 132 | 2.3.2.3 | SRD Rev 3 | 10d | 2007-06-29 | 2007-07-12 | 114, 127, 121 |  |  | 199.33d |  | start no earlier than 2007-06-29 | Neyman [25%] | 20h |  | 1,146.2 |  |  |
| 133 | 2.3.2.4 | SRD Final SD Phase Version | 10d | 2007-10-22 | 2007-11-02 | 115, 128, 122 |  |  | 77.33d |  |  | Neyman [25%] | 20h |  | 1,146.2 |  |  |
| 134 | 3 | **System Design** | 375d? | 2006-08-14 A | 2008-01-18 |  | 18% | 307.48d? | 63.33d |  |  |  | 9826h | 2220.5h | 654,913.28 | 145,035.43 |  |
| 135 | 3.1 | **Systems Engineering** | 360d? | 2006-08-14 A | 2007-12-28 |  | 44% | 202.09d? | 78.33d |  |  |  | 5256h | 2195.5h | 347,903.94 | 143,602.68 |  |
| 136 | 3.1.1 | **Performance Budgets** | 348d? | 2006-08-14 A | 2007-12-12 |  | 57% | 149.82d? | 90.33d |  |  |  | 2346h | 1263h | 138,258.26 | 78,349.9 |  |
| 137 | 3.1.1.1 | **Model Assumptions** | 230d? | 2006-08-14 A | 2007-06-29 |  | 70% | 69.54d? | 208.33d |  |  |  | 260h | 240h | 15,974.4 | 14,828.2 |  |
| 138 | 3.1.1.1.1 | **TMT site monitoring data mining** | 230d? | 2006-08-14 A | 2007-06-29 |  | 55% | 102.95d? | 208.33d |  |  |  | 80h | 60h | 4,584.8 | 3,438.6 |  |
| 139 | 3.1.1.1.1.1 | Tools in place & 1st release | 24d? | 2006-08-14 A | 2006-09-14 A |  | 100% |  |  |  | finish no earlier than 2006-09-14 | Flicker [20.8%] | 40h | 40h | 2,292.4 | 2,292.4 |  |
| 140 | 3.1.1.1.1.2 | Release updated data (every two months) | 205d? | 2006-09-18 A | 2007-06-29 | 139 | 50% | 102.5d? | 208.33d |  | finish no earlier than 2007-06-29 | Flicker [2.4%] | 40h | 20h | 2,292.4 | 1,146.2 |  |
| 141 | 3.1.1.1.2 | Telescope dynamic performance data | 44d? | 2006-10-02 A | 2006-11-30 A |  | 100% |  |  |  | start no earlier than 2006-10-02 | Neyman [17%]; Flicker [17%] | 120h | 120h | 6,877.2 | 6,877.2 |  |
| 142 | 3.1.1.1.3 | Telescope static wavefront errors | 44d? | 2006-10-02 A | 2006-11-30 A |  | 100% |  |  |  | finish no earlier than 2006-11-30 | Neyman [5.7%] | 20h | 20h | 1,146.2 | 1,146.2 |  |
| 143 | 3.1.1.1.4 | Sodium return vs laser format | 22d? | 2006-11-01 A | 2006-11-30 A |  | 100% |  |  |  | start no earlier than 2006-11-01 | Gavel [11.4%]; Neyman [11.4%] | 40h | 40h | 3,366.2 | 3,366.2 |  |
| 144 | 3.1.1.2 | **Model/Tool Validation** | 90d? | 2006-08-14 A | 2006-12-15 |  | 71% | 26.44d? | 167.83d | 7d |  |  | 334h | 202h | 11,821.88 | 8,734.38 |  |
| 145 | 3.1.1.2.1 | Agreement between Tomography Codes | 35d? | 2006-08-14 A | 2006-09-29 A |  | 100% |  |  |  | start no earlier than 2006-08-14 | Flicker [5.4%]; Gavel [3.6%]; Neyman [5.4%] | 40h | 40h | 2,829.3 | 2,829.3 |  |
| 146 | 3.1.1.2.2 | Agreement between Sky Coverage Codes | 15d? | 2006-10-16 A | 2006-11-03 A |  | 100% |  |  |  | start no earlier than 2006-10-16 | Dekany [10%]; Gavel [10%]; Clare [13.3%] | 40h | 40h | 3,390.68 | 3,390.68 | mv into FY07 |
| 147 | 3.1.1.2.3 | Anchor to Keck II LGS AO PSFs | 21d? | 2006-10-02 A | 2006-10-30 |  | 25% | 15.75d? | 201.83d |  | finish no earlier than 2006-10-30 | Neyman [23.8%] | 40h | 10h | 2,292.4 | 573.1 |  |
| 148 | 3.1.1.2.4 | Anchor to On-sky MGSU Experiments | 3.67d? | 2006-11-10 A | 2006-11-15 A |  | 100% |  |  |  | finish no earlier than 2006-11-15 | Flicker [34.1%] | 10h | 10h | 573.1 | 573.1 |  |
| 149 | 3.1.1.2.5 | Anchor to LAO Lab Experiments | 30d? | 2006-11-06 A | 2006-12-15 |  | 50% | 15d? | 167.83d |  | start no earlier than 2006-11-06 | Gavel [1.7%]; Flicker [16.7%]; Kupke [33.3%]; Ammons [33.3%] | 204h | 102h | 2,736.4 | 1,368.2 |  |
| 150 | 3.1.1.3 | Throughput | 65d? | 2006-10-02 A | 2006-12-29 |  | 50% | 32.5d? | 203.83d | 130d | start no earlier than 2006-10-02 | Bouchez [6.2%] | 32h | 16h | 2,844.48 | 1,422.24 | mv into FY07 |
| 151 | 3.1.1.4 | **Background** | 71.5d? | 2006-10-02 A | 2007-01-09 |  | 47% | 38d? | 197.33d | 123.5d |  |  | 50h | 22.5h | 4,444.5 | 2,000.03 |  |
| 152 | 3.1.1.4.1 | Document Proposal Analysis | 9d? | 2006-10-02 A | 2006-10-12 |  | 25% | 6.75d? | 259.83d |  | start no earlier than 2006-10-02 | Bouchez [13.9%] | 10h | 2.5h | 888.9 | 222.22 |  |
| 153 | 3.1.1.4.2 | Develop Background Performance Budget | 62.5d? | 2006-10-02 A | 2007-01-09 |  | 50% | 31.25d? | 197.33d |  | start no earlier than 2006-10-02 | Bouchez [8%] | 40h | 20h | 3,555.6 | 1,777.8 |  |

Notes:
- 129: PW
- 130: PW
- 131: CN
- 132: CN
- 133: CN
- 134: PW
- 135: RD
- 136: RD
- 137: CN
- 138: RF
- 139: RF
- 140: RF
- 141: CN
- 142: CN
- 143: DG
- 144: CN
- 145: DG
- 146: RD
- 147: CN
- 148: RF
- 149: DG
- 150: AB
- 151: AB
- 152: AB
- 153: AB

| ID | WBS | Task | Duration | Start | Finish | Predecessors | Complete | Remaining | Total slack | Free slack | Constraint | Resources | Work | Actual work | Cost | Actual cost | Text1 |
| --- | --- | --- | --- | --- | --- | --- | --- | --- | --- | --- | --- | --- | --- | --- | --- | --- | --- |
| 154 | 3.1.1.5 | **Wavefront Error vs Sky Coverage** | 87d? | 2006-10-02 A | 2007-01-30 |  | 33% | 58d? | 160.83d | 0d |  |  | 110h | 20h | 8,830.5 | 1,777.8 |  |
| 155 | 3.1.1.5.1 | Document WFE Budget Rev 1 | 50d? | 2006-10-02 A | 2006-12-08 |  | 50% | 25d? | 197.83d |  | start no earlier than 2006-10-02 | Dekany [10%] | 40h | 20h | 3,555.6 | 1,777.8 |  |
| 156 | 3.1.1.5.2 | Document WFE Budget Rev 2 | 25d? | 2006-12-27 | 2007-01-30 | 139, 143, 144, 183 |  |  | 160.83d |  | finish no earlier than 2007-01-30 | Dekany [20%]; Flicker [17%] | 70h |  | 5,274.9 |  |  |
| 157 | 3.1.1.6 | Encircled Energy vs Sky Coverage | 50d? | 2006-10-23 A | 2006-12-29 |  | 75% | 12.5d? | 0d |  | start no earlier than 2006-10-23 | Dekany [17.5%]; Gavel [17.5%] | 110h | 92.5h | 11,325.6 | 9,383.1 |  |
| 158 | 3.1.1.7 | Photometric Accuracy | 75d? | 2006-10-16 A | 2007-01-26 A |  | 100% |  |  |  | start no earlier than 2006-10-16 | Britton [20%]; Neyman [10%]; Flicker [10%] | 240h | 240h | 17,544 | 17,544 |  |
| 159 | 3.1.1.8 | Astrometric Accuracy | 165d? | 2006-11-13 A | 2007-06-29 |  | 50% | 82.5d? | 0d |  | start no earlier than 2006-11-13 | Britton [13.6%]; Cameron [13.6%] | 240h | 150h | 5,333.4 | 5,333.4 |  |
| 160 | 3.1.1.9 | Polarimetric Accuracy | 25d? | 2007-02-05 A | 2007-03-09 |  | 75% | 6.25d? | 153.83d | 80d | start no earlier than 2007-02-05 | Ireland [20%] | 40h | 30h |  |  |  |
| 161 | 3.1.1.10 | Companion Sensitivity | 41.25d? | 2006-11-13 A | 2007-01-09 |  | 75% | 10.31d? | 176.58d | 15.75d | start no earlier than 2006-11-13 | Macintosh [30.3%]; Neyman [24.2%]; Flicker [18.2%] | 240h | 180h | 17,753.4 | 13,315.05 | assignment |
| 162 | 3.1.1.11 | Observing Efficiency | 30d? | 2007-02-05 A | 2007-03-16 |  | 50% | 15d? | 148.83d | 75d | start no earlier than 2007-02-05 | Le Mignant [8.3%]; Other [33.3%] | 100h | 50h | 5,731 | 2,865.5 | 160->100 |
| 163 | 3.1.1.12 | Observing Uptime | 28d? | 2007-11-05 A | 2007-12-12 |  | 25% | 21d? | 90.33d |  | start no earlier than 2007-11-05 | Chin [17.9%]; Johansson [17.9%] | 80h | 20h | 4,584.8 | 1,146.2 |  |
| 164 | 3.1.1.13 | **Performance Budgets Summary** | 123d? | 2007-01-31 | 2007-07-20 |  |  |  | 73.83d |  |  |  | 160h |  | 11,064.4 |  |  |
| 165 | 3.1.1.13.1 | Performance Budgets Summary Ver 1 | 20d? | 2007-01-31 | 2007-02-27 | 154, 157, 158, 161 |  |  | 160.83d | 0d | start no earlier than 2007-01-15 | Dekany [25%]; Neyman [37.5%] | 100h |  | 6,994.2 |  |  |
| 166 | 3.1.1.13.2 | Performance Budgets Summary Ver 2 | 15d? | 2007-07-02 | 2007-07-20 | 154, 157, 158, 159, 160, 161, 162, 150, 151 |  |  | 73.83d | 0d |  | Dekany [16.7%]; Neyman [33.3%] | 60h |  | 4,070.2 |  |  |
| 167 | 3.1.1.14 | **Science Products** | 65d? | 2007-07-23 | 2007-10-19 |  |  |  | 128.33d |  |  |  | 350h |  | 21,005.9 |  |  |
| 168 | 3.1.1.14.1 | All-In Science Simulations | 20d? | 2007-07-23 | 2007-08-17 | 166 |  |  | 154.58d | 0d | start no earlier than 2007-07-16 | Neyman [50%]; Flicker [50%] | 160h |  | 9,169.6 |  |  |
| 169 | 3.1.1.14.2 | **Additional Science Characterization Results** | 45d? | 2007-08-20 | 2007-10-19 |  |  |  | 128.33d |  |  |  | 190h |  | 11,836.3 |  |  |
| 170 | 3.1.1.14.2.1 | Point Source Sensitivities | 18.75d? | 2007-08-20 | 2007-09-13 | 168 |  |  | 154.58d |  | start no earlier than 2007-04-02 | Bouchez [20%] | 30h |  | 2,666.7 |  |  |
| 171 | 3.1.1.14.2.2 | PSF Uniformity & Stability | 15d? | 2007-08-20 | 2007-09-07 | 168 |  |  | 158.33d |  | start no earlier than 2007-04-02 | Neyman [66.7%] | 80h |  | 4,584.8 |  |  |
| 172 | 3.1.1.14.2.3 | Other | 15d? | 2007-10-01 | 2007-10-19 | 168 |  |  | 128.33d |  | start no earlier than 2007-10-01 | Flicker [66.7%] | 80h |  | 4,584.8 |  | assignment |
| 173 | 3.1.2 | **Trade Studies** | 160d? | 2006-10-16 A | 2007-05-25 |  | 41% | 94.92d? | 113.83d |  |  |  | 1790h | 932.5h | 131,430.06 | 65,252.78 |  |
| 174 | 3.1.2.1 | **System Architecture Trade Studies** | 120d? | 2006-10-16 A | 2007-03-30 |  | 69% | 37.43d? | 153.83d | 80d |  |  | 690h | 537h | 48,341.26 | 36,512.01 |  |
| 175 | 3.1.2.1.1 | MOAO & MCAO TS | 25d? | 2006-11-13 A | 2006-12-15 A |  | 100% |  |  |  | finish no earlier than 2006-12-15 | Gavel [40%] | 80h | 80h | 8,880 | 8,880 | assigned |
| 176 | 3.1.2.1.2 | NGAO versus Keck AO upgrades TS (meeting 5) | 20d? | 2007-02-05 A | 2007-03-02 A |  | 100% |  |  |  | start no earlier than 2007-02-05 | Neyman [37.5%]; Wizinowich [25%] | 100h | 100h | 5,731 | 5,731 |  |
| 177 | 3.1.2.1.3 | Adaptive Secondary Mirror option TS (m5) | 20d? | 2007-03-05 A | 2007-03-30 |  | 25% | 15d? | 153.83d |  | start no earlier than 2007-03-05 | Bauman [15%]; Wizinowich [10%] | 40h | 10h | 3,004.96 | 751.24 | assignment |
| 178 | 3.1.2.1.4 | K & L-band Science TS (m5) | 20d? | 2007-02-05 | 2007-03-02 |  |  |  | 173.83d |  | start no earlier than 2007-02-05 | Bouchez [25%] | 40h |  | 3,555.6 |  |  |
| 179 | 3.1.2.1.5 | Keck Interferometer Support TS (m5) | 100d? | 2006-10-16 A | 2007-03-02 |  | 75% | 25d? | 0d |  | start no earlier than 2006-10-16 | Neyman [22.5%]; Wizinowich [2.5%] | 120h | 115h | 6,877.2 | 6,590.65 |  |
| 180 | 3.1.2.1.6 | Instrument Balance TS | 20d? | 2006-11-13 | 2006-12-08 |  |  |  | 233.83d |  | start no earlier than 2006-11-13 | Adkins [6.2%] | 10h |  | 573.1 |  |  |
| 181 | 3.1.2.1.7 | GLAO for non-NGAO Instruments TS (m5) | 20d? | 2007-02-05 A | 2007-03-02 A |  | 100% |  |  |  | start no earlier than 2007-02-05 | Flicker [12.5%] | 20h | 20h | 1,146.2 | 1,146.2 |  |
| 182 | 3.1.2.1.8 | Science Instrument Re-use Cost/Benefit TS (m3) | 20d? | 2006-11-13 A | 2006-12-08 |  | 50% | 10d? | 233.83d |  | start no earlier than 2006-11-13 | Adkins [25%]; Moore [50%] | 120h | 60h | 9,403.6 | 4,701.8 |  |
| 183 | 3.1.2.1.9 | Telescope Wavefront Errors TS | 13d? | 2006-12-04 A | 2006-12-20 A | 141, 142 | 100% |  |  |  | finish no earlier than 2006-12-20 | Neyman [38.5%]; Flicker [38.5%] | 80h | 80h | 4,584.8 | 4,584.8 |  |
| 184 | 3.1.2.1.10 | Observing Model TS | 45d? | 2006-11-13 A | 2007-01-12 |  | 90% | 4.5d? | 208.83d |  | finish no earlier than 2007-01-12 | Le Mignant [22.2%] | 80h | 72h | 4,584.8 | 4,126.32 |  |

Notes:
- 154: RD
- 155: RD
- 156: RD
- 157: DG
- 158: MB
- 159: BC
- 160: MI
- 161: RF
- 162: DLM
- 163: EJ
- 165: RD
- 166: RD
- 168: CN
- 170: AB
- 171: CN
- 172: RF
- 173: RD
- 175: DG
- 176: PW
- 177: PW
- 178: AB
- 179: CN
- 180: SA
- 181: RF
- 182: SA
- 183: CN
- 184: DLM

| ID | WBS | Task | Duration | Start | Finish | Predecessors | Complete | Remaining | Total slack | Free slack | Constraint | Resources | Work | Actual work | Cost | Actual cost |
| --- | --- | --- | --- | --- | --- | --- | --- | --- | --- | --- | --- | --- | --- | --- | --- | --- |
| 185 | 3.1.2.2 | **Adaptive Optics System Trade Studies** | 150d? | 2006-10-30 A | 2007-05-25 |  | 30% | 105.54d? | 113.83d | 40d |  |  | 880h | 330.5h | 67,322.6 | 24,384.02 |
| 186 | 3.1.2.2.1 | AO Enclosure Temperature TS (m6) | 74d? | 2007-01-02 A | 2007-04-13 |  | 25% | 55.5d? | 143.83d |  | start no earlier than 2007-01-02 | Bouchez [5.1%]; Meguro [6.8%] | 70h | 17.5h | 4,959.1 | 1,239.78 |
| 187 | 3.1.2.2.2 | Optical Relay TS (m6) | 74d? | 2007-01-02 A | 2007-04-13 |  | 25% | 55.5d? | 85.83d | 0d | finish no earlier than 2007-04-13 | Bauman [5.1%]; Dekany [5.1%] | 60h | 15h | 5,276.7 | 1,319.17 |
| 188 | 3.1.2.2.3 | Field Rotation Strategy TS (m6) | 74d? | 2007-01-02 A | 2007-04-13 |  | 25% | 55.5d? | 91.33d | 0d | start no earlier than 2007-01-02 | Bauman [10.1%]; Meguro [3.4%] | 80h | 20h | 6,366.2 | 1,591.55 |
| 189 | 3.1.2.2.4 | Dichroics & Beamsplitters TS (m6) | 74d? | 2007-01-02 | 2007-04-13 |  |  |  | 118.83d | 0d | start no earlier than 2007-01-02 | Velur [10.1%] | 60h |  | 5,333.4 |  |
| 190 | 3.1.2.2.5 | Rayleigh Rejection TS (m3) | 30d? | 2006-10-30 A | 2006-12-08 |  | 75% | 7.5d? | 233.83d |  | start no earlier than 2006-10-30 | Kellner [16.7%] | 40h | 30h | 2,292.4 | 1,719.3 |
| 191 | 3.1.2.2.6 | LGS WFS Type TS (m4) | 35d? | 2006-12-04 A | 2007-01-19 A |  | 100% |  |  |  | start no earlier than 2006-12-04 | Velur [10.7%] | 30h | 30h | 2,666.7 | 2,666.7 |
| 192 | 3.1.2.2.7 | LGS WFS number of subapertures TS (m4) | 35d? | 2006-12-04 A | 2007-01-19 A |  | 100% |  |  |  | start no earlier than 2006-12-04 | Velur [7.1%] | 20h | 20h | 1,777.8 | 1,777.8 |
| 193 | 3.1.2.2.8 | Slow WFS TS (m7) | 25d? | 2007-04-23 | 2007-05-25 |  |  |  | 35.83d | 0d | start no earlier than 2007-04-23 | Velur [40%] | 80h |  | 7,111.2 |  |
| 194 | 3.1.2.2.9 | LOWFS Architecture TS | 50d? | 2006-12-04 A | 2007-02-09 |  | 35% | 32.5d? | 0d |  | start no earlier than 2006-12-04 | Kellner [71.4%]; Velur [20%] | 160h | 108h | 11,696 | 7,073.72 |
| 195 | 3.1.2.2.10 | Number & Type of LOWFS TS (m4) | 40d? | 2006-12-04 A | 2007-01-26 A |  | 100% |  |  |  | start no earlier than 2006-12-04 | Kellner [21.4%]; Velur [9.4%] | 60h | 60h | 4,386 | 4,386 |
| 196 | 3.1.2.2.11 | Centroid Anisoplanatism TS (m7) | 25d? | 2007-04-23 | 2007-05-25 |  |  |  | 113.83d |  | start no earlier than 2007-04-23 | Kellner [20%] | 40h |  | 2,292.4 |  |
| 197 | 3.1.2.2.12 | Deformable Mirror Stroke Requirement TS (m6) | 74d? | 2007-01-02 | 2007-04-13 |  |  |  | 143.83d |  | start no earlier than 2007-01-02 | Flicker [8.4%] | 50h |  | 2,865.5 |  |
| 198 | 3.1.2.2.13 | Stand-alone vs DM on T/T Stage TS (m3) | 30d? | 2006-10-30 A | 2006-12-08 |  | 50% | 15d? | 233.83d |  | start no earlier than 2006-10-30 | Bauman [25%] | 60h | 30h | 5,220 | 2,610 |
| 199 | 3.1.2.2.14 | Correcting Fast T/T with DM TS | 30d? | 2006-10-30 | 2006-12-08 |  |  |  | 233.83d |  | finish no earlier than 2006-12-08 | Bauman [8.3%]; Flicker [8.3%] | 40h |  | 2,886.2 |  |
| 200 | 3.1.2.2.15 | Focus Compensation TS (m6) | 74d? | 2007-01-22 | 2007-05-03 |  |  |  | 129.83d |  | start no earlier than 2007-01-22 | Kellner [2.5%]; Velur [2.5%] | 30h |  | 2,193 |  |
| 201 | 3.1.2.3 | **Laser Facility Trade Studies** | 101d? | 2006-10-16 A | 2007-03-05 |  | 35% | 65.23d? | 144.83d | 0d |  |  | 220h | 65h | 15,766.2 | 4,356.75 |
| 202 | 3.1.2.3.1 | Laser Pulse Format TS (m6) | 20d? | 2007-01-02 | 2007-01-29 |  |  |  | 151.08d | 0d | start no earlier than 2007-01-02 | Velur [50%] | 80h |  | 7,111.2 |  |
| 203 | 3.1.2.3.2 | Free Space vs Fiber TS (m7) | 25d? | 2007-01-30 A | 2007-03-05 | 202 | 25% | 18.75d? | 144.83d | 24d |  | Neyman [50%] | 100h | 25h | 5,731 | 1,432.75 |
| 204 | 3.1.2.3.3 | LGS Asterism Geometry & Size TS (m2) | 5d? | 2006-10-23 A | 2006-10-27 A |  | 100% |  |  |  | finish no earlier than 2006-10-27 | Flicker [50%] | 20h | 20h | 1,146.2 | 1,146.2 |
| 205 | 3.1.2.3.4 | Variable vs fixed LGS Asterism Cost/Benefit TS (m2) | 10d? | 2006-10-16 A | 2006-10-27 A |  | 100% |  |  |  | finish no earlier than 2006-10-27 | Velur [25%] | 20h | 20h | 1,777.8 | 1,777.8 |
| 206 | 3.1.3 | **System Architecture** | 218d? | 2007-02-28 | 2007-12-28 |  |  |  | 78.33d |  |  |  | 1120h |  | 78,215.62 |  |
| 207 | 3.1.3.1 | System Architecture Ver 1 | 36d? | 2007-02-28 | 2007-04-18 | 165 |  |  | 160.83d | 0d | start no earlier than 2006-11-01 | Dekany [10.4%]; Gavel [10.4%]; Wizinowich [6.9%] | 80h |  | 7,142.9 |  |
| 208 | 3.1.3.2 | System Architecture Ver 2 | 20d? | 2007-07-23 | 2007-08-17 | 166, 174, 185, 201 |  |  | 73.83d | 50d |  | Dekany [12.5%]; Gavel [12.5%]; Wizinowich [12.5%] | 60h |  | 5,144 |  |

Notes:
- 186: AB
- 187: RD
- 188: BB
- 189: VV
- 190: VV
- 191: VV
- 192: VV
- 193: VV
- 194: RF
- 195: RC
- 196: SK
- 197: RF
- 198: BB
- 199: Cancel
- 200: SK
- 202: VV
- 203: CN
- 204: RF
- 205: VV
- 206: RD
- 207: RD
- 208: RD

| ID | WBS | Task | Duration | Start | Finish | Predecessors | Total slack | Free slack | Constraint | Resources | Work | Cost | Text1 |
| --- | --- | --- | --- | --- | --- | --- | --- | --- | --- | --- | --- | --- | --- |
| 209 | 3.1.3.3 | **Functional Requirements** | 162d? | 2007-04-19 | 2007-11-30 |  | 23.83d | 0d |  |  | 860h | 56,474.4 |  |
| 210 | 3.1.3.3.1 | AO System Functional Requirements Ver 1 | 17.25d? | 2007-04-19 | 2007-05-14 | 207 | 168.58d |  | finish no earlier than 2007-02-02 | Neyman [54.3%]; Chin [18.1%]; Stomski [18.1%]; Meguro [18.1%]; Bauman [18.1%]; Johansson [18.1%] | 200h | 12,204.25 |  |
| 211 | 3.1.3.3.2 | AO System Functional Requirements Ver 2 | 25d? | 2007-10-29 | 2007-11-30 | 208 | 23.83d |  | start no earlier than 2007-10-29 | Neyman [12.5%]; Chin [7.5%]; Stomski [7.5%]; Meguro [7.5%]; Bauman [7.5%]; Johansson [7.5%] | 100h | 6,176.35 |  |
| 212 | 3.1.3.3.3 | Laser System Functional Requirements Ver 1 | 20d? | 2007-04-19 | 2007-05-16 | 207 | 165.83d |  | finish no earlier than 2007-03-02 | Chin [34.4%]; Velur [34.4%]; Stomski [15.6%] | 135h | 9,473.75 |  |
| 213 | 3.1.3.3.4 | Laser System Functional Requirements Ver 2 | 25d? | 2007-10-29 | 2007-11-30 | 208 | 23.83d |  | start no earlier than 2007-10-29 | Chin [12.5%]; Velur [12.5%]; Stomski [7.5%] | 65h | 4,514.65 |  |
| 214 | 3.1.3.3.5 | Science Operations Functional Requirements Ver 1 | 24d? | 2007-04-19 | 2007-05-22 | 207 | 161.83d |  | finish no earlier than 2007-02-02 | Le Mignant [20.8%]; Other [31.2%] | 100h | 5,731 |  |
| 215 | 3.1.3.3.6 | Science Operations Functional Requirements Ver 2 | 25d? | 2007-10-29 | 2007-11-30 | 208 | 23.83d |  | start no earlier than 2007-10-29 | Le Mignant [20%]; Other [30%] | 100h | 5,731 |  |
| 216 | 3.1.3.3.7 | Science Instruments Function Allocation Ver 1 | 18d? | 2007-04-19 | 2007-05-14 | 207 | 167.83d |  | start no earlier than 2007-01-02 | Adkins [20.8%]; Moore [34.7%] | 80h | 6,163.8 | Moore |
| 217 | 3.1.3.3.8 | Science Instruments Function Allocation Ver 2 | 12.5d? | 2007-10-29 | 2007-11-14 | 208 | 36.33d |  | start no earlier than 2007-10-29 | Adkins [20%]; Moore [60%] | 80h | 6,479.6 | Moore |
| 218 | 3.1.3.4 | Technology Drivers Summary | 3.63d? | 2007-07-23 | 2007-07-26 | 207, 166, 174, 185, 201 | 135.2d | 0d |  | Neyman [82.7%]; Gavel [55.1%] | 40h | 3,151.44 |  |
| 219 | 3.1.3.5 | Technical Risk Analysis Ver 1 | 23d? | 2007-07-26 | 2007-08-28 | 218 | 166.7d |  | start no earlier than 2007-03-19 | Neyman [13%]; Gavel [8.7%] | 40h | 3,151.44 |  |
| 220 | 3.1.3.6 | Technical Risk Analysis Ver 2 | 20d? | 2007-12-03 | 2007-12-28 | 209 | 23.83d | 1.5d | finish no earlier than 2007-12-28 | Neyman [15%]; Gavel [10%] | 40h | 3,151.44 |  |
| 221 | 3.2 | **AO System** | 205d? | 2007-03-05 | 2007-12-14 |  | 33.83d | 11.5d |  |  | 1780h | 122,338.8 |  |
| 222 | 3.2.1 | AO System Architecture | 45d? | 2007-04-19 | 2007-06-20 | 207 | 160.83d |  | start no earlier than 2007-02-05 | Neyman [13.9%]; Gavel [8.3%]; Johansson [11.1%]; Bauman [11.1%]; Velur [11.1%]; Wizinowich [5.6%]; Dekany [5.6%] | 240h | 18,447.5 | let's discuss |
| 223 | 3.2.2 | AO Enclosure | 70d? | 2007-05-14 | 2007-08-17 | 226SS+4w | 118.83d |  |  | Meguro [17.9%] | 100h | 5,731 |  |
| 224 | 3.2.3 | **Opto-mechanical** | 185d? | 2007-04-02 | 2007-12-14 |  | 33.83d |  |  |  | 700h | 54,627.7 |  |
| 225 | 3.2.3.1 | Field Rotation | 82.5d? | 2007-04-16 | 2007-08-08 | 188 | 91.33d | 37.5d | finish no earlier than 2007-06-29 | Bauman [4.5%]; Lockwood [2.3%] | 45h | 4,119 |  |
| 226 | 3.2.3.2 | Optical Relay | 88d? | 2007-04-16 | 2007-08-15 | 187 | 85.83d | 0d | start no earlier than 2007-03-05 | Bauman [5.7%]; Lockwood [3.4%]; Dekany [2%] | 60h | 5,374.9 |  |
| 227 | 3.2.3.3 | Optical Switchyard | 55d? | 2007-04-16 | 2007-06-29 | 189 | 118.83d | 65d | finish no earlier than 2007-06-29 | Bauman [5.7%]; Lockwood [5.7%] | 50h | 4,690 |  |
| 228 | 3.2.3.4 | Optical Support Structure | 35d? | 2007-10-01 | 2007-11-16 | 225, 226, 227 | 53.83d |  | finish no earlier than 2007-11-16 | Lockwood [10.7%]; Bauman [5.4%] | 45h | 4,323 |  |
| 229 | 3.2.3.5 | **Wavefront Sensors** | 158d? | 2007-05-07 | 2007-12-12 |  | 35.83d |  |  |  | 240h | 17,228.2 |  |
| 230 | 3.2.3.5.1 | High Order LGS Wavefront Sensors | 158d? | 2007-05-07 | 2007-12-12 | 191, 192 | 35.83d |  | start no earlier than 2007-05-07 | Velur [4.7%]; Meguro [1.6%] | 80h | 6,479.6 |  |
| 231 | 3.2.3.5.2 | High Order NGS Wavefront Sensor | 158d? | 2007-05-07 | 2007-12-12 |  | 35.83d |  | start no earlier than 2007-05-07 | Velur [2.4%]; Meguro [0.8%] | 40h | 3,239.8 |  |
| 232 | 3.2.3.5.3 | Low Order NGS Wavefront Sensors | 158d? | 2007-05-07 | 2007-12-12 | 194, 195 | 35.83d |  | start no earlier than 2007-05-07 | Kellner [3.2%]; Meguro [1.6%]; Velur [1.6%] | 80h | 5,216.4 |  |
| 233 | 3.2.3.5.4 | Calibration Wavefront Sensor | 143d? | 2007-05-28 | 2007-12-12 | 193 | 35.83d |  | start no earlier than 2007-04-16 | Kellner [3.5%] | 40h | 2,292.4 |  |

Notes:
- 210: CN
- 211: CN
- 212: JC
- 213: JC
- 214: DLM
- 215: DLM
- 216: SA
- 217: SA
- 218: DG
- 219: DG
- 220: DG
- 221: DG
- 222: DG
- 223: JM
- 224: BB
- 225: BB
- 226: BB
- 227: BB
- 228: BB
- 229: VV
- 230: VV
- 231: VV
- 232: SK
- 233: SK

| ID | WBS | Task | Duration | Start | Finish | Predecessors | Total slack | Free slack | Constraint | Resources | Work | Cost | Text1 |
| --- | --- | --- | --- | --- | --- | --- | --- | --- | --- | --- | --- | --- | --- |
| 234 | 3.2.3.6 | **Wavefront Correctors** | 175d? | 2007-04-02 | 2007-11-30 |  | 43.83d |  |  |  | 140h | 10,752.2 |  |
| 235 | 3.2.3.6.1 | Tip/Tilt Corrector | 45d? | 2007-10-01 | 2007-11-30 |  | 43.83d |  | start no earlier than 2007-10-01 | Flicker [2.8%]; Bauman [2.8%] | 20h | 1,443.1 |  |
| 236 | 3.2.3.6.2 | Deformable Mirror | 65d? | 2007-04-02 | 2007-06-29 |  | 153.83d |  | start no earlier than 2007-04-02 | Flicker [7.7%]; Bauman [11.8%]; Dekany [15%] | 120h | 9,309.1 |  |
| 237 | 3.2.3.7 | **Acquisition Cameras** | 20d? | 2007-10-01 | 2007-10-26 |  | 68.83d |  |  |  | 40h | 3,555.6 |  |
| 238 | 3.2.3.7.1 | NGS Acquisition Camera | 20d? | 2007-10-01 | 2007-10-26 |  | 68.83d |  | finish no earlier than 2007-10-26 | Bouchez [12.5%] | 20h | 1,777.8 |  |
| 239 | 3.2.3.7.2 | LGS Acquisition Camera | 20d? | 2007-10-01 | 2007-10-26 |  | 68.83d |  | finish no earlier than 2007-10-26 | Bouchez [12.5%] | 20h | 1,777.8 |  |
| 240 | 3.2.3.8 | Atmospheric Dispersion Correction | 85d? | 2007-08-20 | 2007-12-14 |  | 33.83d |  | start no earlier than 2007-08-20 | Kellner [2.9%] | 20h | 1,146.2 |  |
| 241 | 3.2.3.9 | Alignment, Calibration, Diagnostics, Metrology and Monitoring | 65d? | 2007-04-02 | 2007-06-29 |  | 153.83d |  | start no earlier than 2007-04-02 | Neyman [5.8%]; Flicker [5.8%] | 60h | 3,438.6 |  |
| 242 | 3.2.4 | **Non-real-time Control** | 110d? | 2007-06-25 | 2007-11-23 |  | 48.83d |  |  |  | 400h | 22,943 |  |
| 243 | 3.2.4.1 | Non-RTC Software | 50d? | 2007-06-25 | 2007-08-31 |  | 108.83d |  | start no earlier than 2007-06-25 | Johansson [20%]; Stomski [20%]; Johnson [10%] | 200h | 11,462 |  |
| 244 | 3.2.4.2 | Non-RTC Electronics | 90d? | 2007-07-23 | 2007-11-23 |  | 48.83d |  | start no earlier than 2007-07-23 | Chin [13.9%]; Reinig [13.9%] | 200h | 11,481 |  |
| 245 | 3.2.5 | **Real-time Control** | 112d? | 2007-03-05 | 2007-08-07 |  | 126.83d |  |  |  | 340h | 20,589.6 |  |
| 246 | 3.2.5.1 | RTC Architecture Analysis and Design Study | 45d? | 2007-03-05 | 2007-05-04 |  | 126.83d | 0d | finish no earlier than 2007-05-04 | Gavel [5.6%]; Johansson [11.1%]; Flicker [11.1%]; Reinig [22.2%] | 180h | 11,404.8 |  |
| 247 | 3.2.5.2 | RTC Software Module Definition | 67d? | 2007-05-07 | 2007-08-07 | 246 | 126.83d |  |  | Johansson [11.2%]; Reinig [3.7%] | 80h | 4,588.6 |  |
| 248 | 3.2.5.3 | RTC Hardware Module Definition | 67d? | 2007-05-07 | 2007-08-07 | 246 | 126.83d |  |  | Johansson [3.7%]; Reinig [11.2%] | 80h | 4,596.2 |  |
| 249 | 3.3 | **Laser Facility** | 204d? | 2007-03-06 | 2007-12-14 |  | 33.83d | 11.5d |  |  | 750h | 52,456.5 | Discuss; JC? |
| 250 | 3.3.1 | Laser System Architecture | 50d? | 2007-03-06 | 2007-05-14 | 154, 157, 201 | 144.83d | 0d |  | Velur [20%] | 80h | 7,111.2 |  |
| 251 | 3.3.2 | Laser Enclosure | 43d? | 2007-05-15 | 2007-07-12 | 250 | 144.83d |  |  | Meguro [23.3%] | 80h | 4,584.8 |  |
| 252 | 3.3.3 | Laser | 35d? | 2007-05-15 | 2007-07-02 | 250 | 152.83d |  | start no earlier than 2007-03-05 | Velur [35.7%] | 100h | 8,889 |  |
| 253 | 3.3.4 | **Laser Launch Facility** | 40d? | 2007-04-09 | 2007-06-01 |  | 173.83d |  |  |  | 300h | 20,982.6 | ch name back |
| 254 | 3.3.4.1 | Laser Beam Transport | 40d? | 2007-04-09 | 2007-06-01 | 202, 203 | 173.83d |  | start no earlier than 2007-04-09 | Neyman [10.9%]; Kellner [6.2%]; Chin [1.6%] | 60h | 3,438.6 |  |
| 255 | 3.3.4.2 | Laser Pointing & Diagnostics | 40d? | 2007-04-09 | 2007-06-01 | 202, 203 | 173.83d |  | start no earlier than 2007-04-09 | Velur [21.9%]; Kellner [21.9%]; Chin [6.2%]; Moore [22%] | 120h | 9,087.8 | add AM |
| 256 | 3.3.4.3 | Laser Launch Telescope | 40d? | 2007-04-09 | 2007-06-01 | 204, 202, 203 | 173.83d |  | finish no earlier than 2007-06-01 | Velur [15.6%]; Kellner [15.6%]; Chin [11.1%] | 120h | 8,456.2 |  |
| 257 | 3.3.5 | **Laser Safety Systems** | 20d? | 2007-10-08 | 2007-11-02 |  | 63.83d |  |  |  | 40h | 2,292.4 |  |
| 258 | 3.3.5.1 | Personnel and Equipment Safety Systems | 20d? | 2007-10-08 | 2007-11-02 |  | 63.83d |  | start no earlier than 2007-10-08 | Chin [12.5%] | 20h | 1,146.2 |  |
| 259 | 3.3.5.2 | Aircraft, Satellite & Laser Traffic Control Safety Systems | 20d? | 2007-10-08 | 2007-11-02 |  | 63.83d |  | start no earlier than 2007-10-08 | Chin [12.5%] | 20h | 1,146.2 |  |

Notes:
- 234: BB
- 235: BB
- 236: BB
- 237: AB
- 238: AB
- 239: AB
- 240: SK
- 241: CN
- 242: JC
- 243: EJ
- 244: JC
- 245: DG
- 246: DG
- 247: EJ
- 248: MR
- 250: VV
- 251: JM
- 252: VV
- 253: VV
- 254: CN
- 255: VV
- 256: VV
- 257: JC
- 258: JC
- 259: JC

| ID | WBS | Task | Duration | Start | Finish | Total slack | Free slack | Constraint | Resources | Work | Cost | Text1 |
| --- | --- | --- | --- | --- | --- | --- | --- | --- | --- | --- | --- | --- |
| 260 | 3.3.6 | **Laser System Control** | 55d? | 2007-10-01 | 2007-12-14 | 33.83d |  |  |  | 150h | 8,596.5 |  |
| 261 | 3.3.6.1 | Laser System Software | 55d? | 2007-10-01 | 2007-12-14 | 33.83d |  | finish no earlier than 2007-12-14 | Johansson [9.1%]; Stomski [9.1%] | 80h | 4,584.8 |  |
| 262 | 3.3.6.2 | Laser System Electronics | 55d? | 2007-10-01 | 2007-12-14 | 33.83d |  | finish no earlier than 2007-12-14 | Chin [15.9%] | 70h | 4,011.7 |  |
| 263 | 3.4 | **Science Operations** | 249d? | 2007-01-02 | 2007-12-14 | 33.83d | 11.5d |  |  | 670h | 32,477.5 |  |
| 264 | 3.4.1 | **Astronomical Observations Operations** | 207d? | 2007-03-01 | 2007-12-14 | 33.83d |  |  |  | 220h | 8,054.2 |  |
| 265 | 3.4.1.1 | **Pre-Observing Interfaces** | 22d? | 2007-05-01 | 2007-05-30 | 175.83d |  |  |  | 60h | 2,072.4 |  |
| 266 | 3.4.1.1.1 | AO Guide Star Interface | 22d? | 2007-05-01 | 2007-05-30 | 175.83d |  | finish no earlier than 2007-05-30 | Postdoc [11.4%] | 20h | 690.8 | assigned |
| 267 | 3.4.1.1.2 | Science Observations Simulation Tools | 22d? | 2007-05-01 | 2007-05-30 | 175.83d |  | start no earlier than 2007-05-01 | Postdoc [22.7%] | 40h | 1,381.6 | assigned |
| 268 | 3.4.1.2 | **Observing Interfaces** | 207d? | 2007-03-01 | 2007-12-14 | 33.83d |  |  |  | 80h | 3,218.6 |  |
| 269 | 3.4.1.2.1 | Acquisition | 43d? | 2007-03-01 | 2007-04-30 | 197.83d |  | finish no earlier than 2007-04-30 | Postdoc [5.8%] | 20h | 690.8 | assigned |
| 270 | 3.4.1.2.2 | Observing Sequences | 43d? | 2007-03-01 | 2007-04-30 | 197.83d |  | start no earlier than 2007-03-01 | Postdoc [5.8%] | 20h | 690.8 | assigned |
| 271 | 3.4.1.2.3 | Instrument, AO & Telescope Observer Interfaces | 43d? | 2007-03-01 | 2007-04-30 | 197.83d |  | start no earlier than 2007-03-01 | Johansson [5.8%] | 20h | 1,146.2 | assigned |
| 272 | 3.4.1.2.4 | Science Data Quality Monitoring | 43d? | 2007-10-17 | 2007-12-14 | 33.83d |  | finish no earlier than 2007-12-14 | Postdoc [5.8%] | 20h | 690.8 | assigned |
| 273 | 3.4.1.3 | **Post-Observing Interfaces** | 42d? | 2007-10-01 | 2007-11-27 | 46.83d |  |  |  | 80h | 2,763.2 |  |
| 274 | 3.4.1.3.1 | Generic Data Products | 42d? | 2007-10-01 | 2007-11-27 | 46.83d |  | start no earlier than 2007-10-01 | Postdoc [6%] | 20h | 690.8 | assigned |
| 275 | 3.4.1.3.2 | Science Data Quality Assessment | 42d? | 2007-10-01 | 2007-11-27 | 46.83d |  | start no earlier than 2007-10-01 | Postdoc [6%] | 20h | 690.8 | assigned |
| 276 | 3.4.1.3.3 | Science Data Archiving | 42d? | 2007-10-01 | 2007-11-27 | 46.83d |  | start no earlier than 2007-10-01 | Postdoc [11.9%] | 40h | 1,381.6 | assigned |
| 277 | 3.4.2 | **AO-Instrument Operations** | 214d? | 2007-01-02 | 2007-10-26 | 68.83d |  |  |  | 450h | 24,423.3 |  |
| 278 | 3.4.2.1 | **AO-Instrument Operations Architecture** | 214d? | 2007-01-02 | 2007-10-26 | 68.83d |  |  |  | 270h | 14,107.5 |  |
| 279 | 3.4.2.1.1 | AO-Instrument Observing Modes | 24d? | 2007-01-02 | 2007-02-02 | 258.83d |  | start no earlier than 2007-01-02 | Le Mignant [20.8%]; Postdoc [20.8%] | 80h | 3,674 | assigned |
| 280 | 3.4.2.1.2 | AO-Instrument Operations Support | 83d? | 2007-02-05 | 2007-05-30 | 175.83d |  | finish no earlier than 2007-05-30 | Le Mignant [3%] | 20h | 1,146.2 | assigned |
| 281 | 3.4.2.1.3 | AO-Instrument Configuration & Setup | 83d? | 2007-07-04 | 2007-10-26 | 68.83d |  | finish no earlier than 2007-10-26 | Le Mignant [3%] | 20h | 1,146.2 | assigned |
| 282 | 3.4.2.1.4 | AO-Instrument Calibrations | 83d? | 2007-06-04 | 2007-09-26 | 90.83d |  | start no earlier than 2007-06-04 | van Dam [3%] | 20h | 1,146.2 | assigned |
| 283 | 3.4.2.1.5 | AO-Instrument Nighttime Operation Modes | 83d? | 2007-06-04 | 2007-09-26 | 90.83d |  | start no earlier than 2007-06-04 | Le Mignant [3%] | 20h | 1,146.2 | assigned |
| 284 | 3.4.2.1.6 | AO-Instrument Science Acquisition & Control | 83d? | 2007-07-02 | 2007-10-24 | 70.83d |  | start no earlier than 2007-07-02 | Postdoc [3%] | 20h | 690.8 | assigned |
| 285 | 3.4.2.1.7 | AO-Instrument Health Monitoring & Automated Recovery | 83d? | 2007-06-11 | 2007-10-03 | 85.83d |  | start no earlier than 2007-06-11 | Johansson [3%] | 20h | 1,146.2 | assigned |
| 286 | 3.4.2.1.8 | AO-Instrument Laser Traffic Control | 20d? | 2007-10-01 | 2007-10-26 | 68.83d |  | start no earlier than 2007-10-01 | Summers [6.2%] | 10h | 573.1 |  |
| 287 | 3.4.2.1.9 | AO-Instrument User Interfaces | 20d? | 2007-10-01 | 2007-10-26 | 68.83d |  | start no earlier than 2007-10-01 | Johansson [25%] | 40h | 2,292.4 | assigned |
| 288 | 3.4.2.1.10 | AO-Instrument Maintenance Plan | 20d? | 2007-10-01 | 2007-10-26 | 68.83d |  | start no earlier than 2007-10-01 | Chin [12.5%] | 20h | 1,146.2 | assigned |

Notes:
- 260: JC
- 261: EJ
- 262: JC
- 263: DLM
- 264: DLM
- 277: DLM
- 278: DLM
- 279: DLM
- 286: DS

| ID | WBS | Task | Duration | Start | Finish | Predecessors | Complete | Remaining | Total slack | Free slack | Constraint | Resources | Work | Actual work | Cost | Actual cost | Text1 |
| --- | --- | --- | --- | --- | --- | --- | --- | --- | --- | --- | --- | --- | --- | --- | --- | --- | --- |
| 289 | 3.4.2.2 | **AO-Instrument Operations Optimization** | 45d? | 2007-03-05 | 2007-05-04 |  |  |  | 193.83d |  |  |  | 180h |  | 10,315.8 |  |  |
| 290 | 3.4.2.2.1 | AO-Instrument Performance Prediction | 30d? | 2007-03-05 | 2007-04-13 |  |  |  | 208.83d |  | start no earlier than 2007-03-05 | Flicker [25%]; van Dam [8.3%] | 80h |  | 4,584.8 |  | assigned |
| 291 | 3.4.2.2.2 | AO-Instrument Real-Time Optimization | 30d? | 2007-03-05 | 2007-04-13 |  |  |  | 208.83d |  | start no earlier than 2007-03-05 | Flicker [25%]; van Dam [8.3%] | 80h |  | 4,584.8 |  | assigned |
| 292 | 3.4.2.2.3 | AO-Instrument Environment Monitoring | 15d? | 2007-04-16 | 2007-05-04 |  |  |  | 193.83d |  | finish no earlier than 2007-05-04 | Chin [16.7%] | 20h |  | 1,146.2 |  | assigned |
| 293 | 3.5 | **Science Instruments** | 295d? | 2006-10-02 A | 2007-11-16 |  | 4% | 283.33d? | 53.83d | 31.5d |  |  | 1290h | 25h | 93,446.34 | 1,432.75 |  |
| 294 | 3.5.1 | OSIRIS | 66.67d? | 2006-12-01 | 2007-03-05 |  |  |  | 238.16d |  | start no earlier than 2006-12-01 | Adkins [3%]; Other [15.8%] | 100h |  | 5,731 |  |  |
| 295 | 3.5.2 | Interferometer | 130d? | 2006-10-02 A | 2007-03-30 |  | 25% | 97.5d? | 218.83d |  | start no earlier than 2006-10-02 | Adkins [1.5%]; Neyman [3.8%]; Other [3.3%]; Wizinowich [1%] | 100h | 25h | 5,731 | 1,432.75 |  |
| 296 | 3.5.3 | OHANA | 50d? | 2007-02-01 | 2007-04-11 |  |  |  | 210.83d |  | start no earlier than 2007-02-01 | Adkins [2%]; Neyman [2%]; Woillez [6%] | 40h |  | 2,292.4 |  |  |
| 297 | 3.5.4 | Near-IR Imager | 145d? | 2006-11-06 | 2007-05-25 |  |  |  | 178.83d |  | start no earlier than 2006-11-06 | Adkins [2.1%]; Moore [15.2%] | 200h |  | 17,020.08 |  |  |
| 298 | 3.5.5 | Visible Imager | 130d? | 2007-05-14 | 2007-11-09 |  |  |  | 58.83d |  | start no earlier than 2007-05-14 | Adkins [2.3%]; Moore [16.9%] | 200h |  | 17,020.08 |  |  |
| 299 | 3.5.6 | Visible IFU | 100d? | 2007-07-02 | 2007-11-16 |  |  |  | 53.83d |  | start no earlier than 2007-07-02 | Adkins [2%]; Moore [10.5%] | 100h |  | 8,383.72 |  |  |
| 300 | 3.5.7 | Deployable Near-IR IFU | 105d? | 2007-02-01 | 2007-06-27 |  |  |  | 155.83d |  | start no earlier than 2007-02-01 | Adkins [7.1%]; Moore [16.7%]; Neyman [16.7%]; Other [19%] | 500h |  | 33,076.2 |  |  |
| 301 | 3.5.8 | Thermal Near-IR Imager | 95d? | 2007-07-09 | 2007-11-16 |  |  |  | 53.83d |  | start no earlier than 2007-07-09 | Adkins [1.1%]; Moore [5.5%] | 50h |  | 4,191.86 |  |  |
| 302 | 3.6 | System Design Manual | 12.5d? | 2008-01-01 | 2008-01-18 | 209, 220, 293, 164, 263, 218, 249, 221 |  |  | 22.33d |  | finish no earlier than 2008-01-18 | Wizinowich [42%]; Dekany [20%]; Gavel [20%] | 80h |  | 6,290.2 |  |  |
| 303 | 4 | **Systems Engineering Management Plan (SEMP)** | 252.33d? | 2007-03-05 A | 2008-02-20 |  | 1% | 248.74d? | 0d |  |  |  | 1200h | 10h | 83,733.3 | 714.64 |  |
| 304 | 4.1 | **Project Plan** | 60.57d? | 2007-09-26 | 2007-12-20 |  |  |  | 0d |  |  |  | 540h |  | 41,077.5 |  |  |
| 305 | 4.1.1 | WBS and Task Definition | 21.43d? | 2007-09-26 | 2007-10-25 | 22FS+55d |  |  | 0d |  |  | Wizinowich [35%]; Dekany [35%]; Gavel [35%]; Max [35%] | 200h |  | 15,432 |  | moved earlier |
| 306 | 4.1.2 | Cost Estimation | 25.57d? | 2007-10-25 | 2007-11-30 | 305 |  |  | 5.69d | 0d |  | Wizinowich [4.9%]; Dekany [14.7%]; Gavel [14.7%]; Bauman [14.7%]; Meguro [9.8%]; Johansson [9.8%]; Chin [9.8%]; Velur [14.7%]; Adkins [9.8%]; Le Mignant [4.9%] | 220h |  | 17,004.4 |  | assignment |
| 307 | 4.1.3 | Major Project Milestones | 6.57d? | 2007-10-25 | 2007-11-05 | 305 |  |  | 63.83d |  |  | Wizinowich [19%]; Dekany [38%] | 30h |  | 2,350.9 |  |  |
| 308 | 4.1.4 | Develop Full Schedule (MS Project Plan) | 13.57d? | 2007-11-30 | 2007-12-20 | 306 |  |  | 5.69d | 0d |  | Wizinowich [36.8%]; Dekany [18.4%]; Gavel [18.4%]; Max [9.2%] | 90h |  | 6,290.2 |  | end date |
| 309 | 4.2 | Risk Assessment & Management Plan | 34d? | 2007-09-26 | 2007-11-13 | 305SS |  |  | 57.83d |  |  | Wizinowich [3.7%]; Dekany [5.5%]; Gavel [5.5%] | 40h |  | 3,571.45 |  | lead; people |
| 310 | 4.3 | **Preliminary Design Phase Plan** | 233.64d? | 2007-03-05 A | 2008-01-24 |  | 9% | 212.14d? | 5.69d |  |  |  | 200h | 10h | 14,007.59 | 714.64 |  |
| 311 | 4.3.1 | Preliminary Design Phase Plan Version 1 (to Support Observatory FY08 Planning) | 20d? | 2007-03-05 A | 2007-03-30 |  | 25% | 15d? | 219.33d |  | start no earlier than 2007-03-05 | Wizinowich [9.4%]; Dekany [6.2%]; Gavel [6.2%]; Max [3.1%] | 40h | 10h | 2,858.55 | 714.64 | -2hr; later |
| 312 | 4.3.2 | Preliminary Design Phase Plan Version 2 | 18.75d? | 2007-10-25 | 2007-11-21 | 305 |  |  | 51.65d |  | start no earlier than 2007-04-09 | Wizinowich [20%]; Dekany [20%]; Gavel [20%]; Max [20%] | 80h |  | 5,717.1 |  |  |
| 313 | 4.3.3 | Preliminary Design Phase Plan Final Version | 15.57d? | 2008-01-03 | 2008-01-24 | 308FS+2w |  |  | 5.69d |  |  | Wizinowich [26.7%]; Dekany [14.4%]; Gavel [14.4%]; Max [10%] | 80h |  | 5,431.94 |  | -4hr |

Notes:
- 293: SA
- 302: PW
- 303: PW
- 304: PW
- 305: PW
- 306: PW
- 307: PW
- 308: PW
- 309: DG
- 310: PW
- 311: PW
- 312: PW
- 313: PW

| ID | WBS | Task | Duration | Start | Finish | Predecessors | Total slack | Constraint | Resources | Work | Cost | Text1 |
| --- | --- | --- | --- | --- | --- | --- | --- | --- | --- | --- | --- | --- |
| 314 | 4.4 | **Integration and Test Plans** | 70.4d? | 2007-10-25 | 2008-02-01 |  | 0d |  |  | 180h | 10,315.8 |  |
| 315 | 4.4.1 | **Subsystem Testing Plans** | 70.4d? | 2007-10-25 | 2008-02-01 |  | 0d |  |  | 80h | 4,584.8 |  |
| 316 | 4.4.1.1 | AO System Test Plan | 17.6d? | 2007-10-25 | 2007-11-20 | 305 | 0d |  | Neyman [14.2%] | 20h | 1,146.2 |  |
| 317 | 4.4.1.2 | Laser System Test Plan | 17.6d? | 2007-11-20 | 2007-12-14 | 316 | 0d |  | Neyman [14.2%] | 20h | 1,146.2 |  |
| 318 | 4.4.1.3 | Science Operations Test Plan | 17.6d? | 2007-12-14 | 2008-01-08 | 317 | 0d |  | Neyman [14.2%] | 20h | 1,146.2 |  |
| 319 | 4.4.1.4 | Science Instruments Test Plan | 17.6d? | 2008-01-08 | 2008-02-01 | 318 | 0d |  | Neyman [14.2%] | 20h | 1,146.2 |  |
| 320 | 4.4.2 | System Integration & Test Plans | 30d? | 2007-10-25 | 2007-12-06 | 305 | 40.4d |  | Neyman [41.7%] | 100h | 5,731 | assignment |
| 321 | 4.5 | Configuration Management Plan | 62.5d? | 2007-10-25 | 2008-01-22 | 305 | 7.9d | start no earlier than 2007-01-15 | Johnson [10%]; Randolph [10%]; Chin [5%] | 80h | 4,584.8 | assignment |
| 322 | 4.6 | Project Management Plan | 20d? | 2007-12-20 | 2008-01-17 | 308 | 11.26d | start no earlier than 2007-02-12 | Wizinowich [12.5%]; Dekany [12.5%]; Gavel [12.5%]; Max [12.5%] | 80h | 5,144 |  |
| 323 | 4.7 | SEMP Document | 13d? | 2008-02-01 | 2008-02-20 | 304, 310, 315, 320, 321, 322, 309 | 0d |  | Wizinowich [30.8%]; Dekany [15.4%]; Gavel [15.4%]; Max [15.4%] | 80h | 5,032.16 |  |

Notes:
- 314: CN
- 315: CN
- 316: CN
- 317: CN
- 318: CN
- 319: CN
- 320: CN
- 321: JJ
- 322: PW
- 323: PW
