# NGAO System Design Phase Schedule

Schedule from MS Project, 2006-06-21 to 2008-04-16, costs in $, A marks actual dates.
CARA

## Calendars

- Standard: Mon-Fri 08:00-12:00, 13:00-17:00; Sat-Sun off. Exceptions (off unless hours are given): 2007-09-15 08:00-12:00, 13:00-17:00.

## Resources

| Resource | Group | Rate | Notes |
| --- | --- | --- | --- |
| Flicker | WMKO | 57.31 | AO Modeller |
| Gavel | UCSC | 111 | EC |
| Neyman | WMKO | 57.31 | AO |
| Dekany | COO | 88.89 | EC |
| Bouchez | COO | 88.89 | AO Scientist |
| Max | UCSC |  | EC, Science |
| Wizinowich | WMKO | 57.31 | EC |
| Britton | COO | 88.89 | AO Modeller |
| Moore | COO | 88.89 | Instrum Sci |
| Velur | COO | 88.89 | AO Scientist |
| Chin | WMKO | 57.31 | EE |
| Johansson | WMKO | 57.31 | SE, EE |
| Meguro | WMKO | 57.31 | ME |
| Stomski | WMKO | 57.31 | SE |
| Clare | WMKO | 62 | AO Modeller |
| Adkins | WMKO | 57.31 | Instruments |
| Bell | WMKO | 57.31 | ME |
| Sweeney | WMKO | 57.31 | MD |
| Kellner | WMKO | 57.31 | AO Postdoc |
| van Dam | WMKO | 57.31 | AO Scientist |
| Johnson | WMKO | 57.31 | SE |
| Bauman | UCSC | 87 | OE |
| Macintosh | UCSC | 97.3 | Science |
| Le Mignant | WMKO | 57.31 | Instrum Sci |
| McGraw | UCSC | 34.54 | Science postdoc |
| Other | WMKO | 57.31 | Unassigned |
| Cameron | COO |  | Grad student |
| Randolph | WMKO | 57.31 | MD |
| Summers | WMKO | 57.31 | SE |
| Woillez | WMKO | 57.31 | KI Scientist |
| Ammons | UCSC |  | Grad student |
| Kupke | UCSC |  | AO Postdoc |
| Lockwood | UCSC | 100.6 | ME |
| Reinig | UCSC | 57.5 | EE, ECE |
| Ireland | COO |  | Postdoc |
| Student1 |  | 31 | Grad student |
| Student2 |  |  | Grad student |
| Adkins(IPM) | WMKO |  | IPM |
| Mechanical Engineer 1 |  | 88.89 |  |
| Optical Engineer 1 |  | 88.89 |  |
| Mechanical Engineer 2 |  | 88.89 |  |
| Optical Engineer 2 |  | 88.89 |  |
| Mechanical Engineer 3 |  | 88.89 |  |
| Optical Engineer 3 |  | 88.89 |  |

## Schedule

| ID | WBS | Task | Type | Duration | Start | Finish | Predecessors | Complete | Remaining | Baseline start | Baseline finish | Baseline duration | Total slack | Free slack | Constraint | Resources | Work | Actual work | Cost | Baseline cost | Actual cost | Text1 |
| --- | --- | --- | --- | --- | --- | --- | --- | --- | --- | --- | --- | --- | --- | --- | --- | --- | --- | --- | --- | --- | --- | --- |
| 1 | 1 | **SD Phase Management** |  | 476.33d? | 2006-06-21 A | 2008-04-16 |  | 29% | 338.72d? | 2006-06-21 | 2008-04-17 | 476.33d? | 0d |  |  |  | 2167h | 702h | 136,791.73 | 137,250.21 | 45,720.53 |  |
| 2 | 1.1 | **Planning and Contracting** |  | 365.26d? | 2006-06-21 A | 2007-11-13 |  | 74% | 95.57d? | 2006-06-21 | 2007-11-14 | 365.26d? | 111.07d |  |  |  | 230h | 154h | 13,778.35 | 13,778.35 | 8,923.3 |  |
| 3 | 1.1.1 | NGAO Proposal to SSC | milestone | 0d | 2006-06-21 A | 2006-06-21 A |  | 100% |  | 2006-06-21 | 2006-06-21 | 0d |  |  | start no earlier than 2006-06-21 |  |  |  |  |  |  |  |
| 4 | 1.1.2 | Management Structure Decision by Directors | milestone | 0d | 2006-07-14 A | 2006-07-14 A | 3 | 100% |  | 2006-07-14 | 2006-07-14 | 0d |  |  | start no earlier than 2006-07-14 |  |  |  |  |  |  |  |
| 5 | 1.1.3 | SD Phase System Engineering Management Plan |  | 21d? | 2006-09-01 A | 2006-09-29 A | 4 | 100% |  | 2006-09-01 | 2006-09-29 | 21d? |  |  | finish no earlier than 2006-09-29 | Max [8.9%]; Gavel [8.9%]; Dekany [8.9%]; Wizinowich [20.8%] | 80h | 80h | 5,004.2 | 5,004.2 | 5,004.2 |  |
| 6 | 1.1.4 | SD Phase Contracts Generated |  | 23d? | 2006-09-27 A | 2006-10-27 A |  | 100% |  | 2006-09-27 | 2006-10-27 | 23d? |  |  | start no earlier than 2006-09-27 | Adkins(IPM) [16.7%]; Gavel [8.3%]; Dekany [8.3%] | 60h | 60h | 2,998.35 | 2,998.35 | 2,998.35 |  |
| 7 | 1.1.5 | Director Approval | milestone | 0d | 2006-10-09 A | 2006-10-09 |  | 75% | 0d | 2006-10-09 | 2006-10-09 | 0d | 383.33d | 0d | start no earlier than 2006-10-09 |  |  |  |  |  |  |  |
| 8 | 1.1.6 | SD Partner Contracts Issued | milestone | 0d | 2006-10-27 A | 2006-10-27 A | 6, 7 | 100% |  | 2006-10-27 | 2006-10-27 | 0d |  |  | start no earlier than 2006-10-13 |  |  |  |  |  |  |  |
| 9 | 1.1.7 | Mid-year Replan |  | 7d | 2007-03-19 A | 2007-03-27 |  | 50% | 3.5d | 2007-03-05 | 2007-03-16 | 10d | 276.33d |  | finish no earlier than 2007-03-27 | Wizinowich [56.2%]; Dekany [25%]; Gavel [25%]; Max [18.8%] | 40h | 14h | 2,630.7 | 2,630.7 | 920.75 |  |
| 10 | 1.1.8 | FY08 Replan |  | 13.33d | 2007-10-24 | 2007-11-13 | 372 |  |  | 2007-10-25 | 2007-11-14 | 13.33d | 111.07d |  |  | Wizinowich [28.1%]; Dekany [12.5%]; Gavel [12.5%]; Max [9.4%] | 50h |  | 3,145.1 | 3,145.1 |  | have new WBS; to help align FY08 work |
| 11 | 1.2 | **Project Meetings** |  | 467d? | 2006-06-21 A | 2008-04-02 |  | 25% | 351.98d? | 2006-06-21 | 2008-04-03 | 467d? | 9.33d |  |  |  | 1352h | 478h | 90,597.68 | 90,597.68 | 32,652.68 |  |
| 12 | 1.2.1 | Executive Committee Telecons |  | 467d | 2006-06-21 A | 2008-04-02 |  | 45% | 256.85d | 2006-06-21 | 2008-04-03 | 467d | 9.33d |  |  | Wizinowich [2.4%]; Dekany [2.4%]; Gavel [2.4%]; Max [2.4%] | 360h | 162h | 23,148 | 23,148 | 10,416.6 | ch end & time |
| 13 | 1.2.2 | Science Advisory Committee Telecons |  | 390d? | 2006-10-02 | 2008-03-27 |  |  |  | 2006-10-02 | 2008-03-28 | 390d? | 13.33d |  | start no earlier than 2006-10-02 | Max [1.4%] | 40h |  |  |  |  |  |
| 14 | 1.2.3 | **Team Meetings** |  | 345.5d | 2006-09-14 A | 2008-01-09 |  | 32% | 234.94d | 2006-09-14 | 2008-01-09 | 344.5d | 69.83d |  |  |  | 952h | 316h | 67,449.68 | 67,449.68 | 22,236.08 |  |
| 15 | 1.2.3.1 | Team Meeting #1 (mgmt, science & technical - Irvine) |  | 1d | 2006-09-14 A | 2006-09-14 A |  | 100% |  | 2006-09-14 | 2006-09-14 | 1d |  |  | start no earlier than 2006-09-14 | Wizinowich; Dekany; Gavel; Max; Bauman; Bouchez; Velur; Flicker; Neyman; Britton; Le Mignant | 68h | 68h | 4,618.48 | 4,618.48 | 4,618.48 |  |
| 16 | 1.2.3.2 | Team Meeting #2 (CIT) |  | 1d | 2006-11-14 A | 2006-11-14 A |  | 100% |  | 2006-11-14 | 2006-11-14 | 1d |  |  | start no earlier than 2006-11-14 | Wizinowich; Dekany; Gavel; Max; Bauman; Bouchez; Velur; Flicker; Neyman; Britton; Le Mignant | 80h | 80h | 5,677.6 | 5,677.6 | 5,677.6 |  |
| 17 | 1.2.3.3 | Team Videocon #3 |  | 0.5d | 2006-12-13 A | 2006-12-13 A |  | 100% |  | 2006-12-13 | 2006-12-13 | 0.5d |  |  | start no earlier than 2006-12-13 | Wizinowich; Dekany; Gavel; Max; Bauman; Bouchez; Velur; Flicker; Neyman; Britton; Le Mignant | 44h | 44h | 3,131.2 | 3,131.2 | 3,131.2 |  |
| 18 | 1.2.3.4 | Team Meeting #4 (Keck) |  | 1d | 2007-01-22 A | 2007-01-22 A |  | 100% |  | 2007-01-22 | 2007-01-22 | 1d |  |  | start no earlier than 2007-01-22 | Wizinowich; Dekany; Gavel; Max; Bauman; Bouchez; Velur; Flicker; Neyman; Britton; Le Mignant | 80h | 80h | 5,677.6 | 5,677.6 | 5,677.6 |  |
| 19 | 1.2.3.5 | Team Videocon #5 |  | 0.5d | 2007-03-07 A | 2007-03-07 A |  | 100% |  | 2007-03-07 | 2007-03-07 | 0.5d |  |  | start no earlier than 2007-03-07 | Wizinowich; Dekany; Gavel; Max; Bauman; Bouchez; Velur; Flicker; Neyman; Britton; Le Mignant | 44h | 44h | 3,131.2 | 3,131.2 | 3,131.2 |  |
| 20 | 1.2.3.6 | Team Meeting #6 (UCSC) |  | 2d | 2007-04-25 | 2007-04-26 |  |  |  | 2007-04-18 | 2007-04-18 | 1d | 254.33d |  | finish no earlier than 2007-04-26 | Wizinowich [50%]; Dekany [50%]; Gavel [50%]; Max [50%]; Bauman [50%]; Bouchez; Velur [50%]; Flicker [50%]; Neyman [50%]; Britton [50%]; Le Mignant | 80h |  | 5,677.6 | 5,677.6 |  |  |
| 21 | 1.2.3.7 | Team Videocon #7 |  | 0.5d | 2007-05-30 | 2007-05-30 |  |  |  | 2007-05-30 | 2007-05-30 | 0.5d | 230.33d |  | finish no earlier than 2007-05-30 | Wizinowich; Dekany; Gavel; Max; Bauman; Bouchez; Velur; Flicker; Neyman; Britton; Le Mignant | 44h |  | 3,131.2 | 3,131.2 |  |  |
| 22 | 1.2.3.8 | Team Retreat #8 (UCSC) |  | 2.5d | 2007-07-09 | 2007-07-11 |  |  |  | 2007-07-09 | 2007-07-11 | 2.5d | 0d |  | start no earlier than 2007-07-09 | Wizinowich; Dekany; Gavel; Max; Bauman; Bouchez; Velur; Flicker; Neyman; Britton; Le Mignant | 220h |  | 15,656 | 15,656 |  |  |
| 23 | 1.2.3.9 | Team Videocon #9 |  | 0.5d | 2007-08-22 | 2007-08-22 |  |  |  | 2007-08-22 | 2007-08-22 | 0.5d | 170.83d |  | start no earlier than 2007-08-22 | Wizinowich; Dekany; Gavel; Max; Bauman; Bouchez; Velur; Flicker; Neyman; Britton; Le Mignant | 44h |  | 3,131.2 | 3,131.2 |  |  |
| 24 | 1.2.3.10 | Team Meeting #10 (CIT) |  | 1d | 2007-09-11 | 2007-09-11 |  |  |  | 2007-09-11 | 2007-09-11 | 1d | 156.33d |  | start no earlier than 2007-09-11 | Wizinowich; Dekany; Gavel; Max; Bauman; Bouchez; Velur; Flicker; Neyman; Britton; Le Mignant | 80h |  | 5,677.6 | 5,677.6 |  |  |
| 25 | 1.2.3.11 | Team Videocon #11 |  | 0.5d | 2007-11-05 | 2007-11-05 |  |  |  | 2007-11-05 | 2007-11-05 | 0.5d | 116.83d |  | start no earlier than 2007-11-05 | Wizinowich; Dekany; Gavel; Max; Bauman; Bouchez; Velur; Flicker; Neyman; Britton; Le Mignant | 44h |  | 3,131.2 | 3,131.2 |  |  |
| 26 | 1.2.3.12 | Team Meeting #12 (Keck) |  | 1d | 2007-12-12 | 2007-12-12 |  |  |  | 2007-12-12 | 2007-12-12 | 1d | 89.33d |  | start no earlier than 2007-12-12 | Wizinowich; Dekany; Gavel; Max; Bauman; Bouchez; Velur; Flicker; Neyman; Britton; Le Mignant | 80h |  | 5,677.6 | 5,677.6 |  |  |
| 27 | 1.2.3.13 | Team Videocon #13 |  | 0.5d | 2008-01-09 | 2008-01-09 |  |  |  | 2008-01-09 | 2008-01-09 | 0.5d | 69.83d |  | start no earlier than 2008-01-09 | Wizinowich; Dekany; Gavel; Max; Bauman; Bouchez; Velur; Flicker; Neyman; Britton; Le Mignant | 44h |  | 3,131.2 | 3,131.2 |  |  |

Notes:
- 1: PW
- 2: PW
- 5: PW
- 6: PW
- 8: PW
- 9: PW
- 10: PW
- 12: PW / 1 hr per week x 4 persons for duration of SD phase is about 400 wk-hours total - RD
- 13: CM

| ID | WBS | Task | Type | Duration | Start | Finish | Predecessors | Complete | Remaining | Baseline start | Baseline finish | Baseline duration | Total slack | Free slack | Constraint | Resources | Work | Actual work | Cost | Baseline cost | Actual cost | Text1 |
| --- | --- | --- | --- | --- | --- | --- | --- | --- | --- | --- | --- | --- | --- | --- | --- | --- | --- | --- | --- | --- | --- | --- |
| 28 | 1.3 | **Tracking and Reporting** |  | 405d? | 2006-09-16 A | 2008-04-03 |  | 40% | 243d? | 2006-09-16 | 2008-04-03 | 404d? | 8.33d |  |  |  | 120h | 70h | 5,863.85 | 5,863.85 | 4,144.55 |  |
| 29 | 1.3.1 | Report Preparation/Presentation |  | 312.5d? | 2006-10-02 A | 2007-12-11 |  | 40% | 187.5d? | 2006-10-02 | 2007-12-12 | 312.5d? | 0d |  | start no earlier than 2006-10-02 | Wizinowich [2%]; Dekany [2%]; Gavel [2%]; Max [2%] | 120h | 70h | 5,863.85 | 5,863.85 | 4,144.55 |  |
| 30 | 1.3.2 | Keck Science Meeting 06 (UCI) | milestone | 0d | 2006-09-16 A | 2006-09-16 A |  | 100% |  | 2006-09-16 | 2006-09-16 | 0d |  |  | finish no earlier than 2006-09-16 |  |  |  |  |  |  |  |
| 31 | 1.3.3 | SSC meeting (UCLA) | milestone | 0d | 2006-11-06 A | 2006-11-06 A |  | 100% |  | 2006-11-06 | 2006-11-06 | 0d |  |  | start no earlier than 2006-11-06 |  |  |  |  |  |  |  |
| 32 | 1.3.4 | SSC meeting (Keck) | milestone | 0d | 2007-01-24 A | 2007-01-24 A |  | 100% |  | 2007-01-24 | 2007-01-24 | 0d |  |  | start no earlier than 2007-01-24 |  |  |  |  |  |  |  |
| 33 | 1.3.5 | SSC meeting (CA) | milestone | 0d | 2007-04-03 A | 2007-04-03 A |  | 100% |  | 2007-04-03 | 2007-04-03 | 0d |  |  | start no earlier than 2007-04-03 |  |  |  |  |  |  |  |
| 34 | 1.3.6 | SSC meeting (Keck) | milestone | 0d | 2007-06-20 | 2007-06-20 |  |  |  | 2007-06-20 | 2007-06-20 | 0d | 216.33d |  | start no earlier than 2007-06-20 |  |  |  |  |  |  |  |
| 35 | 1.3.7 | Keck Science Meeting 07 | milestone | 0d | 2007-09-15 | 2007-09-15 |  |  |  | 2007-09-22 | 2007-09-22 | 0d | 153.33d |  | start no earlier than 2007-09-15 |  |  |  |  |  |  |  |
| 36 | 1.3.8 | SSC meeting (CA) | milestone | 0d | 2007-11-06 | 2007-11-06 |  |  |  | 2007-11-06 | 2007-11-06 | 0d | 116.33d |  | start no earlier than 2007-11-06 |  |  |  |  |  |  |  |
| 37 | 1.3.9 | SSC meeting (Keck) | milestone | 0d | 2008-01-24 | 2008-01-24 |  |  |  | 2008-01-24 | 2008-01-24 | 0d | 59.33d |  | start no earlier than 2008-01-24 |  |  |  |  |  |  |  |
| 38 | 1.3.10 | SSC meeting (CA) | milestone | 0d | 2008-04-03 | 2008-04-03 |  |  |  | 2008-04-03 | 2008-04-03 | 0d | 8.33d |  | finish no earlier than 2008-04-03 |  |  |  |  |  |  |  |
| 39 | 1.4 | **Proposals & Fundraising** |  | 45d? | 2006-10-27 | 2007-01-01 |  |  |  | 2006-10-27 | 2007-01-01 | 45d? | 338.33d |  |  |  |  |  |  |  |  |  |
| 40 | 1.4.1 | Dates & deliverables identified by Directors | milestone | 0d | 2006-10-27 | 2006-10-27 | 7FS+3w |  |  | 2006-10-27 | 2006-10-27 | 0d | 383.33d | 45d |  |  |  |  |  |  |  |  |
| 41 | 1.4.2 | Support Advancement Office | milestone | 0d? | 2007-01-01 | 2007-01-01 | 40 |  |  | 2007-01-01 | 2007-01-01 | 0d? | 338.33d |  | start no earlier than 2007-01-01 | Wizinowich [2.9%]; Max [3.8%]; Gavel [0.5%]; Dekany [0.5%] |  |  |  |  |  | lead gone |
| 42 | 1.5 | **System Design Report & Review** |  | 142.33d? | 2007-10-01 | 2008-04-16 |  |  |  | 2007-10-01 | 2008-04-17 | 143.33d? | 0d |  |  |  | 465h |  | 26,551.85 | 27,010.33 |  |  |
| 43 | 1.5.1 | System Design Report |  | 8d? | 2008-02-19 | 2008-02-29 | 390, 367, 130 |  |  | 2008-02-20 | 2008-03-03 | 8d? | 0d |  |  | Wizinowich [31.2%]; Gavel [7.8%]; Dekany [7.8%]; Adkins [7.8%]; Max [7.8%] | 40h |  | 2,432.2 | 2,432.2 |  |  |
| 44 | 1.5.2 | **System Design Review** |  | 142.33d? | 2007-10-01 | 2008-04-16 |  |  |  | 2007-10-01 | 2008-04-17 | 143.33d? | 0d |  |  |  | 425h |  | 24,119.65 | 24,578.13 |  |  |
| 45 | 1.5.2.1 | Identify Reviewers |  | 55d? | 2007-10-01 | 2007-12-14 |  |  |  | 2007-10-01 | 2007-12-14 | 55d? | 58.33d | 54.33d | start no earlier than 2007-10-01 | Adkins(IPM) [2.3%]; Wizinowich [0.5%]; Max [0.2%]; Gavel [0.2%]; Dekany [0.2%] | 15h |  | 314.51 | 314.51 |  |  |
| 46 | 1.5.2.2 | Review Package Distributed |  | 1d | 2008-02-29 | 2008-03-03 | 43, 45 |  |  | 2008-03-03 | 2008-03-04 | 1d | 4d | 0d | start no earlier than 2008-01-14 | Adkins(IPM) | 8h |  |  |  |  |  |
| 47 | 1.5.2.3 | Reviewer Comments Addressed |  | 5d? | 2008-03-17 | 2008-03-24 | 46FS+10d |  |  | 2008-03-18 | 2008-03-25 | 5d? | 4d |  | finish no earlier than 2008-02-01 | Wizinowich [75%]; Dekany [60%]; Gavel [60%]; Max [65%]; Adkins(IPM) [40%] | 120h |  | 6,516.66 | 6,516.66 |  |  |
| 48 | 1.5.2.4 | System Design Review Support |  | 20d? | 2008-02-29 | 2008-03-28 | 43 |  |  | 2008-03-03 | 2008-03-31 | 20d? | 0d |  | start no earlier than 2007-01-16 | Wizinowich [15%]; Dekany [15%]; Gavel [15%]; Max [15%]; Bauman [7.5%]; Bouchez [2.5%]; Velur [10%]; Flicker [10%]; Neyman [16.2%]; Le Mignant [10%]; Johansson [10%]; Adkins(IPM) [10%]; Chin [5%]; Kellner [5%]; Moore [10%] | 242h |  | 15,116.26 | 15,574.74 |  |  |
| 49 | 1.5.2.5 | System Design Review Meeting | milestone | 0d | 2008-03-28 | 2008-03-28 | 48, 47 |  |  | 2008-03-31 | 2008-03-31 | 0d | 0d |  | start no earlier than 2008-02-06 |  |  |  |  |  |  |  |
| 50 | 1.5.2.6 | Reviewer Report Received | milestone | 0d | 2008-04-11 | 2008-04-11 | 49FS+10d |  |  | 2008-04-14 | 2008-04-14 | 0d | 0d |  | start no earlier than 2008-02-15 |  |  |  |  |  |  |  |
| 51 | 1.5.2.7 | Response to Reviewer Report & Distribution |  | 3d? | 2008-04-11 | 2008-04-16 | 50 |  |  | 2008-04-14 | 2008-04-17 | 3d? | 0d |  | start no earlier than 2008-02-18 | Wizinowich [41.7%]; Dekany [33.3%]; Gavel [33.3%]; Max [41.7%]; Adkins(IPM) [16.7%] | 40h |  | 2,172.22 | 2,172.22 |  |  |

Notes:
- 28: PW
- 29: PW
- 42: SA
- 43: PW
- 44: PW
- 45: SA
- 46: SA
- 47: PW
- 48: PW
- 49: SA
- 51: PW

| ID | WBS | Task | Duration | Start | Finish | Complete | Remaining | Baseline start | Baseline finish | Baseline duration | Total slack | Constraint | Resources | Work | Actual work | Cost | Baseline cost | Actual cost | Text1 |
| --- | --- | --- | --- | --- | --- | --- | --- | --- | --- | --- | --- | --- | --- | --- | --- | --- | --- | --- | --- |
| 52 | 2 | **System Requirements** | 286d? | 2006-10-02 A | 2007-11-02 | 48% | 148d? | 2006-10-02 | 2007-11-02 | 285d? | 117.33d |  |  | 3254h | 1827.24h | 81,956.42 | 121,852.62 | 48,404.22 |  |
| 53 | 2.1 | **Science Requirements** | 272d? | 2006-10-02 A | 2007-10-15 | 49% | 138.78d? | 2006-10-02 | 2007-10-15 | 271d? | 131.33d |  |  | 2890h | 1728.71h | 60,590.3 | 96,474.8 | 42,504.82 |  |
| 54 | 2.1.1 | **Solar System Science Requirements** | 240d? | 2006-10-02 A | 2007-08-31 | 57% | 104.07d? | 2006-10-02 | 2007-04-06 | 135d? | 163.33d |  |  | 650h | 501.54h | 21,465.5 | 20,150 | 16,648.18 |  |
| 55 | 2.1.1.1 | **Companions & Multiplicity of Small Solar System Bodies** | 162d? | 2006-10-02 A | 2007-05-15 | 74% | 42.59d? | 2006-10-02 | 2007-01-12 | 75d? | 241.33d |  |  | 250h | 230.73h | 8,407.75 | 7,750 | 7,777.36 |  |
| 56 | 2.1.1.1.1 | Point Source Companion Sensitivity Requirements | 162d? | 2006-10-02 A | 2007-05-15 | 75% | 40.5d? | 2006-10-02 | 2006-12-01 | 45d? | 241.33d | finish no earlier than 2007-05-15 | Student1 [27.8%] | 100h | 92.11h | 3,100 | 3,100 | 2,855.26 |  |
| 57 | 2.1.1.1.2 | Spectral Sensitivity & Spectral Resolution Requirements | 162d? | 2006-10-02 A | 2007-05-15 | 85% | 24.3d? | 2006-10-02 | 2006-12-01 | 45d? | 241.33d | finish no earlier than 2007-05-15 | Student1 [27.8%] | 100h | 97.05h | 3,100 | 3,100 | 3,008.69 |  |
| 58 | 2.1.1.1.3 | Observing Scenarios | 117d? | 2006-12-04 A | 2007-05-15 | 50% | 58.5d? | 2006-12-04 | 2007-01-12 | 30d? | 241.33d | finish no earlier than 2007-05-15 | Student1 [10.4%] | 25h | 17.83h | 775 | 775 | 552.76 |  |
| 59 | 2.1.1.1.4 | Science Instrument Requirements | 117d? | 2006-12-04 A | 2007-05-15 | 80% | 23.4d? | 2006-12-04 | 2007-01-12 | 30d? | 241.33d | finish no earlier than 2007-05-15 | Le Mignant [10.4%] | 25h | 23.74h | 1,432.75 | 775 | 1,360.65 |  |
| 60 | 2.1.1.2 | **Moons of the Giant Planets** | 195d? | 2006-12-04 A | 2007-08-31 | 31% | 133.6d? | 2006-12-04 | 2007-03-09 | 70d? | 163.33d |  |  | 150h | 50.63h | 5,307.75 | 4,650 | 2,045.19 |  |
| 61 | 2.1.1.2.1 | Performance Requirements | 195d? | 2006-12-04 A | 2007-08-31 | 10% | 175.5d? | 2006-12-04 | 2007-01-26 | 40d? | 163.33d | finish no earlier than 2007-08-31 | Student1 [31.2%] | 100h | 17.3h | 3,100 | 3,100 | 536.41 |  |
| 62 | 2.1.1.2.2 | Observing Scenarios | 155d? | 2007-01-29 A | 2007-08-31 | 50% | 77.5d? | 2007-01-29 | 2007-03-09 | 30d? | 163.33d | finish no earlier than 2007-08-31 | Le Mignant [10.4%] | 25h | 18.08h | 1,432.75 | 775 | 1,036.19 |  |
| 63 | 2.1.1.2.3 | Science Instrument Requirements | 155d? | 2007-01-29 A | 2007-08-31 | 40% | 93d? | 2007-01-29 | 2007-03-09 | 30d? | 163.33d | finish no earlier than 2007-08-31 | Student1 [10.4%] | 25h | 15.24h | 775 | 775 | 472.59 |  |
| 64 | 2.1.1.3 | **Shape & Size of Asteroids** | 77d? | 2007-01-29 A | 2007-05-15 | 69% | 23.91d? | 2007-01-29 | 2007-04-06 | 50d? | 241.33d |  |  | 250h | 220.18h | 7,750 | 7,750 | 6,825.63 |  |
| 65 | 2.1.1.3.1 | Spatial Resolution Requirements | 77d? | 2007-01-29 A | 2007-05-15 | 70% | 23.1d? | 2007-01-29 | 2007-03-02 | 25d? | 241.33d | finish no earlier than 2007-05-15 | Student1 [50%] | 100h | 88.35h | 3,100 | 3,100 | 2,738.94 |  |
| 66 | 2.1.1.3.2 | Spectral Sensitivity & Spectral Resolution Requirements | 77d? | 2007-01-29 A | 2007-05-15 | 80% | 15.4d? | 2007-01-29 | 2007-03-02 | 25d? | 241.33d | finish no earlier than 2007-05-15 | Student1 [50%] | 100h | 94.6h | 3,100 | 3,100 | 2,932.49 |  |
| 67 | 2.1.1.3.3 | Observing Scenarios | 52d? | 2007-03-05 A | 2007-05-15 | 40% | 31.2d? | 2007-03-05 | 2007-04-06 | 25d? | 241.33d | finish no earlier than 2007-05-15 | Student1 [12.5%] | 25h | 13.86h | 775 | 775 | 429.57 |  |
| 68 | 2.1.1.3.4 | Science Instrument Requirements | 52d? | 2007-03-05 A | 2007-05-15 | 80% | 10.4d? | 2007-03-05 | 2007-04-06 | 25d? | 241.33d | finish no earlier than 2007-05-15 | Student1 [12.5%] | 25h | 23.38h | 775 | 775 | 724.62 |  |
| 69 | 2.1.2 | **Galactic Science Requirements** | 240d? | 2006-10-02 A | 2007-08-31 | 43% | 137.88d? | 2006-10-02 | 2007-04-06 | 135d? | 163.33d |  |  | 1000h | 471.75h |  | 37,200 |  |  |
| 70 | 2.1.2.1 | **Galactic Center Proper Motions: Astrometry** | 196d? | 2006-10-02 A | 2007-07-02 | 61% | 75.47d? | 2006-10-02 | 2007-01-12 | 75d? | 207.33d |  |  | 200h | 136.11h |  | 6,200 |  |  |
| 71 | 2.1.2.1.1 | Astrometry requirements | 196d? | 2006-10-02 A | 2007-07-02 | 40% | 117.6d? | 2006-10-02 | 2006-12-08 | 50d? | 207.33d | finish no earlier than 2007-07-02 | Student2 [37.5%] | 150h | 89.86h |  | 4,650 |  | mv into FY07 |
| 72 | 2.1.2.1.2 | Observing Scenarios | 156d? | 2006-11-27 A | 2007-07-02 | 75% | 39d? | 2006-11-27 | 2007-01-12 | 35d? | 207.33d | finish no earlier than 2007-07-02 | Student2 [8.9%] | 25h | 23.12h |  | 775 |  |  |
| 73 | 2.1.2.1.3 | Science Instrument Requirements | 156d? | 2006-11-27 A | 2007-07-02 | 75% | 39d? | 2006-11-27 | 2007-01-12 | 35d? | 207.33d | finish no earlier than 2007-07-02 | Student2 [8.9%] | 25h | 23.12h |  | 775 |  |  |
| 74 | 2.1.2.2 | **Galactic Center Radial Velocities & Stellar Populations: Integral Field Spectroscopy** | 178d? | 2006-11-27 A | 2007-08-01 | 53% | 83.67d? | 2006-11-27 | 2007-03-09 | 75d? | 185.33d |  |  | 200h | 145.4h |  | 6,200 |  |  |
| 75 | 2.1.2.2.1 | Performance Requirements | 178d? | 2006-11-27 A | 2007-08-01 | 50% | 89d? | 2006-11-27 | 2007-01-26 | 45d? | 185.33d | finish no earlier than 2007-08-01 | Student2 [41.7%] | 150h | 107.07h |  | 4,650 |  |  |
| 76 | 2.1.2.2.2 | Observing Scenarios | 133d? | 2007-01-29 A | 2007-08-01 | 50% | 66.5d? | 2007-01-29 | 2007-03-09 | 30d? | 185.33d | finish no earlier than 2007-08-01 | Student2 [10.4%] | 25h | 17.96h |  | 775 |  |  |
| 77 | 2.1.2.2.3 | Science Instrument Requirements | 133d? | 2007-01-29 A | 2007-08-01 | 60% | 53.2d? | 2007-01-29 | 2007-03-09 | 30d? | 185.33d | finish no earlier than 2007-08-01 | Student2 [10.4%] | 25h | 20.37h |  | 775 |  |  |
| 78 | 2.1.2.3 | Galactic Center Nature of Sgr A*: 3-5 um Color & 2 um Polarimetry Variability | 1d? | 2007-01-29 A | 2007-01-29 | 10% | 0.9d? | 2007-01-29 | 2007-04-06 | 50d? | 317.33d |  |  |  |  |  | 6,200 |  |  |

Notes:
- 52: PW
- 53: CM
- 54: FM
- 55: FM
- 58: DLM
- 60: FM
- 62: DLM
- 64: FM
- 69: ML
- 70: AG
- 74: AG
- 78: Cancel

| ID | WBS | Task | Duration | Start | Finish | Complete | Remaining | Baseline start | Baseline finish | Baseline duration | Total slack | Constraint | Resources | Work | Actual work | Cost | Baseline cost | Actual cost | Text1 |
| --- | --- | --- | --- | --- | --- | --- | --- | --- | --- | --- | --- | --- | --- | --- | --- | --- | --- | --- | --- |
| 79 | 2.1.2.4 | **Planets around Low Mass Stars & Brown Dwarfs: Companion Sensitivity** | 175d? | 2006-10-02 A | 2007-06-01 | 54% | 80.62d? | 2006-10-02 | 2007-01-12 | 75d? | 228.33d |  |  | 200h | 156.26h |  | 6,200 |  |  |
| 80 | 2.1.2.4.1 | Companion Sensitivity Performance Requirements | 175d? | 2006-10-02 A | 2007-06-01 | 60% | 70d? | 2006-10-02 | 2006-12-08 | 50d? | 228.33d | finish no earlier than 2007-06-01 | Student2 [37.5%] | 150h | 121.03h |  | 4,650 |  | mv into FY07 |
| 81 | 2.1.2.4.2 | Observing Scenarios | 135d? | 2006-11-27 A | 2007-06-01 | 40% | 81d? | 2006-11-27 | 2007-01-12 | 35d? | 228.33d | finish no earlier than 2007-06-01 | Student2 [8.9%] | 25h | 14.96h |  | 775 |  |  |
| 82 | 2.1.2.4.3 | Science Instrument Requirements | 135d? | 2006-11-27 A | 2007-06-01 | 60% | 54d? | 2006-11-27 | 2007-01-12 | 35d? | 228.33d | finish no earlier than 2007-06-01 | Student2 [8.9%] | 25h | 20.26h |  | 775 |  |  |
| 83 | 2.1.2.5 | **Debris Disks, Protostellar Envelopes & Outflows: Contrast** | 111d? | 2007-01-29 A | 2007-07-02 | 10% | 99.9d? | 2007-01-29 | 2007-04-06 | 50d? | 207.33d |  |  | 200h | 33.99h |  | 6,200 |  |  |
| 84 | 2.1.2.5.1 | Contrast Performance Requirements | 111d? | 2007-01-29 A | 2007-07-02 | 10% | 99.9d? | 2007-01-29 | 2007-03-02 | 25d? | 207.33d | finish no earlier than 2007-07-02 | Student2 [75%] | 150h | 25.7h |  | 4,650 |  |  |
| 85 | 2.1.2.5.2 | Observing Scenarios | 86d? | 2007-03-05 A | 2007-07-02 | 10% | 77.4d? | 2007-03-05 | 2007-04-06 | 25d? | 207.33d | finish no earlier than 2007-07-02 | Student2 [12.5%] | 25h | 4.14h |  | 775 |  |  |
| 86 | 2.1.2.5.3 | Science Instrument Requirements | 86d? | 2007-03-05 A | 2007-07-02 | 10% | 77.4d? | 2007-03-05 | 2007-04-06 | 25d? | 207.33d | finish no earlier than 2007-07-02 | Student2 [12.5%] | 25h | 4.14h |  | 775 |  |  |
| 87 | 2.1.2.6 | **Debris Disks, Protostellar Envelopes & Outflows: Polarimetry** | 79d? | 2007-05-15 | 2007-08-31 |  |  | 2006-11-27 | 2007-03-09 | 75d? | 163.33d |  |  | 200h |  |  | 6,200 |  |  |
| 88 | 2.1.2.6.1 | Polarimetry Performance Requirements | 79d? | 2007-05-15 | 2007-08-31 |  |  | 2006-11-27 | 2007-01-26 | 45d? | 163.33d | start no earlier than 2007-05-15 | Student2 [23.7%] | 150h |  |  | 4,650 |  |  |
| 89 | 2.1.2.6.2 | Observing Scenarios | 79d? | 2007-05-15 | 2007-08-31 |  |  | 2007-01-29 | 2007-03-09 | 30d? | 163.33d | start no earlier than 2007-05-15 | Student2 [4%] | 25h |  |  | 775 |  |  |
| 90 | 2.1.2.6.3 | Science Instrument Requirements | 79d? | 2007-05-15 | 2007-08-31 |  |  | 2007-01-29 | 2007-03-09 | 30d? | 163.33d | start no earlier than 2007-05-15 | Student2 [4%] | 25h |  |  | 775 |  |  |
| 91 | 2.1.3 | **Extragalactic Science Requirements** | 262d? | 2006-10-02 A | 2007-10-01 | 52% | 125.85d? | 2006-10-02 | 2007-04-27 | 150d? | 141.33d |  |  | 1000h | 715.42h | 34,540 | 34,540 | 24,710.44 |  |
| 92 | 2.1.3.1 | **Resolved Stellar Populations in Crowded Fields** | 262d? | 2006-10-02 A | 2007-10-01 | 57% | 112.89d? | 2006-10-02 | 2007-02-02 | 90d? | 141.33d |  |  | 300h | 242.18h | 10,362 | 10,362 | 8,364.97 |  |
| 93 | 2.1.3.1.1 | Performance Requirements | 261d? | 2006-10-02 A | 2007-10-01 | 60% | 104.4d? | 2006-10-02 | 2006-12-22 | 60d? | 141.33d | finish no earlier than 2007-10-01 | McGraw [52.1%] | 250h | 203.6h | 8,635 | 8,635 | 7,032.34 | mv into FY07 |
| 94 | 2.1.3.1.2 | Observing Scenarios | 211d? | 2006-12-11 A | 2007-10-01 | 60% | 84.4d? | 2006-12-11 | 2007-02-02 | 40d? | 141.33d | finish no earlier than 2007-10-01 | McGraw [7.8%] | 25h | 20.49h | 863.5 | 863.5 | 707.61 |  |
| 95 | 2.1.3.1.3 | Science Instrument Requirements | 211d? | 2006-12-11 A | 2007-10-01 | 50% | 105.5d? | 2006-12-11 | 2007-02-02 | 40d? | 141.33d | finish no earlier than 2007-10-01 | McGraw [7.8%] | 25h | 18.1h | 863.5 | 863.5 | 625.02 |  |
| 96 | 2.1.3.2 | **High Redshift Galaxies** | 175d? | 2006-10-02 A | 2007-06-01 | 67% | 57.65d? | 2006-10-02 | 2007-02-02 | 90d? | 228.33d |  |  | 300h | 260.62h | 10,362 | 10,362 | 9,001.67 |  |
| 97 | 2.1.3.2.1 | Encircled Energy (& d-IFU) Performance Requirements | 175d? | 2006-10-02 A | 2007-06-01 | 70% | 52.5d? | 2006-10-02 | 2006-12-22 | 60d? | 228.33d | finish no earlier than 2007-06-01 | McGraw [41.7%] | 200h | 176.32h | 6,908 | 6,908 | 6,089.95 | mv into FY07 |
| 98 | 2.1.3.2.2 | Observing Scenarios | 125d? | 2006-12-11 A | 2007-06-01 | 70% | 37.5d? | 2006-12-11 | 2007-02-02 | 40d? | 228.33d | finish no earlier than 2007-06-01 | McGraw [15.6%] | 50h | 44.2h | 1,727 | 1,727 | 1,526.7 |  |
| 99 | 2.1.3.2.3 | Science Instrument Requirements | 125d? | 2006-12-11 A | 2007-06-01 | 60% | 50d? | 2006-12-11 | 2007-02-02 | 40d? | 228.33d | finish no earlier than 2007-06-01 | McGraw [15.6%] | 50h | 40.1h | 1,727 | 1,727 | 1,385.02 |  |
| 100 | 2.1.3.3 | **Nearby Galaxies** | 190d? | 2006-12-11 A | 2007-08-31 | 40% | 114d? | 2006-12-11 | 2007-04-27 | 100d? | 163.33d |  |  | 200h | 116.24h | 6,908 | 6,908 | 4,014.86 |  |
| 101 | 2.1.3.3.1 | Encircled Energy & PSF Performance Requirements | 190d? | 2006-12-11 A | 2007-08-31 | 40% | 114d? | 2006-12-11 | 2007-03-02 | 60d? | 163.33d | finish no earlier than 2007-08-31 | McGraw [31.2%] | 150h | 88.19h | 5,181 | 5,181 | 3,046.18 |  |
| 102 | 2.1.3.3.2 | Observing Scenarios | 130d? | 2007-03-05 A | 2007-08-31 | 20% | 104d? | 2007-03-05 | 2007-04-27 | 40d? | 163.33d | finish no earlier than 2007-08-31 | McGraw [7.8%] | 25h | 7.95h | 863.5 | 863.5 | 274.62 |  |
| 103 | 2.1.3.3.3 | Science Instrument Requirements | 130d? | 2007-03-05 A | 2007-08-31 | 60% | 52d? | 2007-03-05 | 2007-04-27 | 40d? | 163.33d | finish no earlier than 2007-08-31 | McGraw [7.8%] | 25h | 20.09h | 863.5 | 863.5 | 694.06 |  |

Notes:
- 79: ML
- 83: LH
- 91: CM

| ID | WBS | Task | Duration | Start | Finish | Predecessors | Complete | Remaining | Baseline start | Baseline finish | Baseline duration | Total slack | Free slack | Constraint | Resources | Work | Actual work | Cost | Baseline cost | Actual cost | Text1 |
| --- | --- | --- | --- | --- | --- | --- | --- | --- | --- | --- | --- | --- | --- | --- | --- | --- | --- | --- | --- | --- | --- |
| 104 | 2.1.3.4 | **Gravitational Lensing** | 146d? | 2006-12-11 A | 2007-07-02 |  | 38% | 90.35d? | 2006-12-11 | 2007-04-27 | 100d? | 207.33d |  |  |  | 200h | 96.38h | 6,908 | 6,908 | 3,328.94 |  |
| 105 | 2.1.3.4.1 | Encircled Energy & PSF Performance Requirements | 146d? | 2006-12-11 A | 2007-07-02 |  | 30% | 102.2d? | 2006-12-11 | 2007-03-02 | 60d? | 207.33d |  | finish no earlier than 2007-07-02 | McGraw [31.2%] | 150h | 66.16h | 5,181 | 5,181 | 2,285.31 |  |
| 106 | 2.1.3.4.2 | Observing Scenarios | 86d? | 2007-03-05 A | 2007-07-02 |  | 30% | 60.2d? | 2007-03-05 | 2007-04-27 | 40d? | 207.33d |  | finish no earlier than 2007-07-02 | McGraw [7.8%] | 25h | 10.76h | 863.5 | 863.5 | 371.77 |  |
| 107 | 2.1.3.4.3 | Science Instrument Requirements | 86d? | 2007-03-05 A | 2007-07-02 |  | 60% | 34.4d? | 2007-03-05 | 2007-04-27 | 40d? | 207.33d |  | finish no earlier than 2007-07-02 | McGraw [7.8%] | 25h | 19.45h | 863.5 | 863.5 | 671.86 |  |
| 108 | 2.1.4 | **Science Case Requirements Document** | 272d? | 2006-10-02 A | 2007-10-15 |  | 14% | 233.05d? | 2006-10-02 | 2007-10-15 | 271d? | 131.33d |  |  |  | 240h | 40h | 4,584.8 | 4,584.8 | 1,146.2 |  |
| 109 | 2.1.4.1 | Science Case Requirements Doc Rev 1 | 14d? | 2006-10-02 A | 2006-10-19 A |  | 100% |  | 2006-10-02 | 2006-10-19 | 14d? |  |  | finish no earlier than 2006-10-19 | Max [17.9%]; Wizinowich [17.9%] | 40h | 40h | 1,146.2 | 1,146.2 | 1,146.2 |  |
| 110 | 2.1.4.2 | Science Case Requirements Doc Rev 2 | 45d? | 2007-04-02 | 2007-06-01 |  |  |  | 2007-02-13 | 2007-03-02 | 14d? | 228.33d |  | start no earlier than 2007-04-02 | Max [27.8%]; Wizinowich [5.6%] | 120h |  | 1,146.2 | 1,146.2 |  | assignment |
| 111 | 2.1.4.3 | Science Case Requirements Doc Rev 3 | 24.89d? | 2007-06-05 | 2007-07-09 |  |  |  | 2007-06-05 | 2007-06-22 | 13.89d? | 192.33d | 5d | finish no earlier than 2007-07-09 | Max [10%]; Wizinowich [10%] | 40h |  | 1,146.2 | 1,146.2 |  |  |
| 112 | 2.1.4.4 | Science Case Requirements Doc Final | 13.89d? | 2007-09-26 | 2007-10-15 |  |  |  | 2007-09-26 | 2007-10-15 | 13.89d? | 80.33d | 4d | finish no earlier than 2007-10-15 | Max [18%]; Wizinowich [18%] | 40h |  | 1,146.2 | 1,146.2 |  |  |
| 113 | 2.2 | **Observatory Requirements** | 245d? | 2006-10-02 A | 2007-09-07 |  | 43% | 139.05d? | 2006-10-02 | 2007-09-07 | 245d? | 107.33d |  |  |  | 224h | 72h | 13,342.72 | 13,342.72 | 4,378.96 |  |
| 114 | 2.2.1 | Development Requirements | 40d? | 2006-10-02 A | 2006-11-24 A |  | 100% |  | 2006-10-02 | 2006-11-24 | 40d? |  |  | start no earlier than 2006-10-02 | Neyman [2.5%]; Wizinowich [2.5%] | 16h | 16h | 916.96 | 916.96 | 916.96 |  |
| 115 | 2.2.2 | Observatory Interface Requirements | 20d? | 2006-10-02 A | 2006-10-27 A |  | 100% |  | 2006-10-02 | 2006-10-27 | 20d? |  |  | start no earlier than 2006-10-02 | Neyman [5%]; Wizinowich [5%]; Adkins [5%] | 24h | 24h | 1,375.44 | 1,375.44 | 1,375.44 |  |
| 116 | 2.2.3 | Science Operations Requirements | 40d? | 2006-10-02 A | 2006-11-24 |  | 50% | 20d? | 2006-10-02 | 2006-11-24 | 40d? | 107.33d | 0d | finish no earlier than 2006-11-24 | Le Mignant [10%]; Wizinowich [5%]; Bouchez [5%] | 64h | 32h | 4,173.12 | 4,173.12 | 2,086.56 |  |
| 117 | 2.2.4 | Observatory Requirements Rev 2 | 15d? | 2007-01-22 | 2007-02-09 | 114FS+8w, 115FS+8w, 116FS+8w |  |  | 2007-01-22 | 2007-02-09 | 15d? | 107.33d | 0d |  | Neyman [20%]; Meguro [8.3%]; Le Mignant [13.3%]; Adkins [8.3%]; Johansson [8.3%]; Chin [8.3%] | 80h |  | 4,584.8 | 4,584.8 |  | assignments |
| 118 | 2.2.5 | Observatory Requirements Rev 3 | 30d? | 2007-04-09 | 2007-05-18 | 117FS+8w |  |  | 2007-04-09 | 2007-05-18 | 30d? | 107.33d | 0d |  | Neyman [8.3%] | 20h |  | 1,146.2 | 1,146.2 |  |  |
| 119 | 2.2.6 | Observatory Requirements Rev 4 | 40d? | 2007-07-16 | 2007-09-07 | 118FS+8w |  |  | 2007-07-16 | 2007-09-07 | 40d? | 107.33d | 31d |  | Neyman [6.2%] | 20h |  | 1,146.2 | 1,146.2 |  |  |
| 120 | 2.3 | **System Requirements Document** | 281d? | 2006-10-09 A | 2007-11-02 |  | 17% | 232.35d? | 2006-10-09 | 2007-11-02 | 280d? | 117.33d |  |  |  | 140h | 26.53h | 8,023.4 | 12,035.1 | 1,520.45 |  |
| 121 | 2.3.1 | **Traceability Matrix** | 271d? | 2006-10-09 A | 2007-10-20 |  | 12% | 237.95d? | 2006-10-09 | 2007-10-20 | 270d? | 127.33d |  |  |  | 60h | 5h | 3,438.6 | 7,450.3 | 286.55 |  |
| 122 | 2.3.1.1 | Traceability Matrix Rev 1 | 10d? | 2006-10-09 A | 2006-10-20 |  | 50% | 5d? | 2006-10-09 | 2006-10-20 | 10d? | 388.33d |  | finish no earlier than 2006-10-20 | Neyman [12.5%] | 10h | 5h | 573.1 | 573.1 | 286.55 |  |
| 123 | 2.3.1.2 | Traceability Matrix Rev 2 | 12d? | 2007-02-12 | 2007-02-27 |  |  |  | 2007-02-12 | 2007-02-27 | 12d? | 275.43d | 33d | finish no earlier than 2007-02-27 | Wizinowich [10.4%] | 10h |  | 573.1 | 4,584.8 |  |  |
| 124 | 2.3.1.3 | Traceability Matrix Rev 3 | 10d? | 2007-06-15 | 2007-06-28 |  |  |  | 2007-06-15 | 2007-06-28 | 10d? | 199.33d | 12d | finish no earlier than 2007-06-28 | Neyman [25%] | 20h |  | 1,146.2 | 1,146.2 |  |  |
| 125 | 2.3.1.4 | Traceability Matrix Rev 4 | 9d? | 2007-10-09 | 2007-10-20 |  |  |  | 2007-10-09 | 2007-10-20 | 9d? | 76.33d | 0d | finish no earlier than 2007-10-20 | Neyman [27.8%] | 20h |  | 1,146.2 | 1,146.2 |  |  |
| 126 | 2.3.2 | **System Requirements Document** | 246d | 2006-11-27 A | 2007-11-02 |  | 21% | 193.49d | 2006-11-27 | 2007-11-02 | 245d | 117.33d |  |  |  | 80h | 21.53h | 4,584.8 | 4,584.8 | 1,233.9 |  |
| 127 | 2.3.2.1 | SRD Rev 1 | 10d | 2006-11-27 A | 2006-12-08 A | 109, 122, 114, 115 | 100% |  | 2006-11-27 | 2006-12-08 | 10d |  |  | start no earlier than 2006-11-27 | Wizinowich [25%] | 20h | 20h | 1,146.2 | 1,146.2 | 1,146.2 |  |
| 128 | 2.3.2.2 | SRD Rev 2 | 22d | 2007-04-16 A | 2007-05-15 | 123, 117, 109 | 5% | 20.9d | 2007-03-09 | 2007-03-22 | 10d | 241.33d |  | finish no earlier than 2007-05-15 | Wizinowich [25%] | 20h | 1.53h | 1,146.2 | 1,146.2 | 87.7 |  |
| 129 | 2.3.2.3 | SRD Rev 3 | 10d | 2007-07-17 | 2007-07-30 | 111, 124, 118 |  |  | 2007-06-29 | 2007-07-12 | 10d | 187.33d |  | finish no earlier than 2007-07-30 | Wizinowich [25%] | 20h |  | 1,146.2 | 1,146.2 |  |  |
| 130 | 2.3.2.4 | SRD Final SD Phase Version | 10d | 2007-10-22 | 2007-11-02 | 112, 125, 119 |  |  | 2007-10-22 | 2007-11-02 | 10d | 76.33d |  |  | Wizinowich [25%] | 20h |  | 1,146.2 | 1,146.2 |  |  |

Notes:
- 108: CM
- 113: CN
- 114: CN
- 115: CN
- 116: DLM
- 117: PW
- 118: CN
- 119: CN
- 121: CN
- 122: CN
- 123: PW
- 124: CN
- 125: CN
- 126: PW
- 127: PW
- 128: PW
- 129: PW
- 130: PW

| ID | WBS | Task | Duration | Start | Finish | Predecessors | Complete | Remaining | Baseline start | Baseline finish | Baseline duration | Total slack | Free slack | Constraint | Resources | Work | Actual work | Cost | Baseline cost | Actual cost | Text1 |
| --- | --- | --- | --- | --- | --- | --- | --- | --- | --- | --- | --- | --- | --- | --- | --- | --- | --- | --- | --- | --- | --- |
| 131 | 3 | **System Design** | 421d? | 2006-08-14 A | 2008-03-21 |  | 26% | 311.7d? | 2006-08-14 | 2008-01-18 | 375d? | 17.33d |  |  |  | 9590h | 2255.78h | 654,886.48 | 654,913.28 | 145,900.99 |  |
| 132 | 3.1 | **Systems Engineering** | 385d? | 2006-08-14 A | 2008-02-01 |  | 51% | 188.62d? | 2006-08-14 | 2007-12-28 | 360d? | 53.33d |  |  |  | 5456h | 2244.8h | 380,571.12 | 347,903.94 | 145,271.46 |  |
| 133 | 3.1.1 | **Performance Budgets** | 337.75d? | 2006-08-14 A | 2007-11-27 |  | 54% | 156.14d? | 2006-08-14 | 2007-12-12 | 348d? | 100.58d |  |  |  | 2144h | 1298.66h | 128,745.66 | 138,258.26 | 78,333.23 |  |
| 134 | 3.1.1.1 | **Model Assumptions** | 278.43d? | 2006-08-14 A | 2007-09-06 |  | 68% | 87.8d? | 2006-08-14 | 2007-06-29 | 230d? | 159.9d |  |  |  | 292h | 240h | 18,060.96 | 15,974.4 | 14,828.2 |  |
| 135 | 3.1.1.1.1 | **TMT site monitoring data mining** | 230d? | 2006-08-14 A | 2007-06-29 |  | 55% | 102.95d? | 2006-08-14 | 2007-06-29 | 230d? | 208.33d |  |  |  | 80h | 60h | 4,584.8 | 4,584.8 | 3,438.6 |  |
| 136 | 3.1.1.1.1.1 | Tools in place & 1st release | 24d? | 2006-08-14 A | 2006-09-14 A |  | 100% |  | 2006-08-14 | 2006-09-14 | 24d? |  |  | finish no earlier than 2006-09-14 | Flicker [20.8%] | 40h | 40h | 2,292.4 | 2,292.4 | 2,292.4 |  |
| 137 | 3.1.1.1.1.2 | Release updated data (every two months) | 205d? | 2006-09-18 A | 2007-06-29 | 136 | 50% | 102.5d? | 2006-09-18 | 2007-06-29 | 205d? | 208.33d |  | finish no earlier than 2007-06-29 | Flicker [2.4%] | 40h | 20h | 2,292.4 | 2,292.4 | 1,146.2 |  |
| 138 | 3.1.1.1.2 | Telescope dynamic performance data | 44d? | 2006-10-02 A | 2006-11-30 A |  | 100% |  | 2006-10-02 | 2006-11-30 | 44d? |  |  | start no earlier than 2006-10-02 | Neyman [17%]; Flicker [17%] | 120h | 120h | 6,877.2 | 6,877.2 | 6,877.2 |  |
| 139 | 3.1.1.1.3 | Telescope static wavefront errors | 44d? | 2006-10-02 A | 2006-11-30 A |  | 100% |  | 2006-10-02 | 2006-11-30 | 44d? |  |  | finish no earlier than 2006-11-30 | Neyman [5.7%] | 20h | 20h | 1,146.2 | 1,146.2 | 1,146.2 |  |
| 140 | 3.1.1.1.4 | Sodium return vs laser format | 22d? | 2006-11-01 A | 2006-11-30 A |  | 100% |  | 2006-11-01 | 2006-11-30 | 22d? |  |  | start no earlier than 2006-11-01 | Gavel [11.4%]; Neyman [11.4%] | 40h | 40h | 3,366.2 | 3,366.2 | 3,366.2 |  |
| 141 | 3.1.1.1.5 | **Evaluate & Adopt New Model Assumptions** | 63.43d? | 2007-06-11 | 2007-09-06 |  |  |  |  |  |  | 159.9d |  |  |  | 32h |  | 2,086.56 |  |  |  |
| 142 | 3.1.1.1.5.1 | New Model Assumptions Rev 1 | 5d? | 2007-06-11 | 2007-06-15 |  |  |  |  |  |  | 218.33d |  | finish no earlier than 2007-06-15 | Dekany [35%]; Flicker [30%]; Neyman | 20h |  | 1,272.52 |  |  |  |
| 143 | 3.1.1.1.5.2 | New Model Assumptions Rev 2 | 1.43d? | 2007-09-05 | 2007-09-06 |  |  |  |  |  |  | 159.9d |  | start no earlier than 2007-09-05 | Dekany [35%]; Flicker; Neyman | 12h |  | 814.04 |  |  |  |
| 144 | 3.1.1.2 | **Model/Tool Validation** | 230d? | 2006-08-14 A | 2007-06-29 |  | 45% | 127.04d? | 2006-08-14 | 2006-12-15 | 90d? | 208.33d |  |  |  | 334h | 254.94h | 13,085.08 | 11,821.88 | 10,663.26 |  |
| 145 | 3.1.1.2.1 | Agreement between Tomography Codes | 35d? | 2006-08-14 A | 2006-09-29 A |  | 100% |  | 2006-08-14 | 2006-09-29 | 35d? |  |  | start no earlier than 2006-08-14 | Flicker [5.4%]; Gavel [3.6%]; Neyman [5.4%] | 40h | 40h | 2,829.3 | 2,829.3 | 2,829.3 |  |
| 146 | 3.1.1.2.2 | Agreement between Sky Coverage Codes | 15d? | 2006-10-16 A | 2006-11-03 A |  | 100% |  | 2006-10-16 | 2006-11-03 | 15d? |  |  | start no earlier than 2006-10-16 | Dekany [10%]; Gavel [10%]; Clare [13.3%] | 40h | 40h | 3,390.68 | 3,390.68 | 3,390.68 | mv into FY07 |
| 147 | 3.1.1.2.3 | Anchor to Keck II LGS AO PSFs | 195d? | 2006-10-02 A | 2007-06-29 |  | 25% | 146.25d? | 2006-10-02 | 2006-10-30 | 21d? | 208.33d |  | finish no earlier than 2007-06-29 | Neyman [23.8%] | 40h | 16.88h | 2,292.4 | 2,292.4 | 967.25 |  |
| 148 | 3.1.1.2.4 | Anchor to On-sky MGSU Experiments | 3.67d? | 2006-11-10 A | 2006-11-15 A |  | 100% |  | 2006-11-10 | 2006-11-15 | 3.67d? |  |  | finish no earlier than 2006-11-15 | Flicker [34.1%] | 10h | 10h | 573.1 | 573.1 | 573.1 |  |
| 149 | 3.1.1.2.5 | Anchor to LAO Lab Experiments | 170d? | 2006-11-06 A | 2007-06-29 |  | 50% | 85d? | 2006-11-06 | 2006-12-15 | 30d? | 208.33d |  | finish no earlier than 2007-06-29 | Gavel [1.7%]; Dekany [16.7%]; Kupke [33.3%]; Ammons [33.3%] | 204h | 148.06h | 3,999.6 | 2,736.4 | 2,902.94 |  |
| 150 | 3.1.1.3 | Throughput | 165d? | 2006-10-02 A | 2007-05-18 |  | 50% | 82.5d? | 2006-10-02 | 2006-12-29 | 65d? | 173.14d | 96d | finish no earlier than 2007-05-18 | Bouchez [6.2%] | 32h | 22.04h | 2,844.48 | 2,844.48 | 1,958.93 | mv into FY07 |
| 151 | 3.1.1.4 | **Background** | 165d? | 2006-10-02 A | 2007-05-18 |  | 50% | 82.74d? | 2006-10-02 | 2007-01-09 | 71.5d? | 173.14d | 96d |  |  | 41h | 27.74h | 3,644.49 | 4,444.5 | 2,466.25 |  |
| 152 | 3.1.1.4.1 | Document Proposal Analysis | 0.9d? | 2006-10-02 A | 2006-10-02 |  | 25% | 0.68d? | 2006-10-02 | 2006-10-12 | 9d? | 337.24d |  | start no earlier than 2006-10-02 | Bouchez [13.9%] | 1h | 0.25h | 88.89 | 888.9 | 22.22 |  |
| 153 | 3.1.1.4.2 | Develop Background Performance Budget | 156d? | 2006-10-02 A | 2007-05-18 |  | 50% | 78d? | 2006-10-02 | 2007-01-09 | 62.5d? | 173.14d |  | finish no earlier than 2007-05-18 | Bouchez [8%] | 40h | 27.49h | 3,555.6 | 3,555.6 | 2,444.03 |  |
| 154 | 3.1.1.5 | **Wavefront Error vs Sky Coverage** | 261d? | 2006-10-02 A | 2007-09-28 |  | 34% | 173.05d? | 2006-10-02 | 2007-01-30 | 87d? | 77.14d | 0d |  |  | 125h | 28.08h | 11,111.25 | 8,830.5 | 2,495.76 |  |
| 155 | 3.1.1.5.1 | Document WFE Budget Rev 1 | 155d? | 2006-10-02 A | 2007-05-04 |  | 50% | 77.5d? | 2006-10-02 | 2006-12-08 | 50d? | 35.28d | 15d | finish no earlier than 2007-05-04 | Dekany [10%]; Britton [40%] | 55h | 28.08h | 4,888.95 | 3,555.6 | 2,495.76 |  |
| 156 | 3.1.1.5.2 | Document WFE Budget Rev 2 | 75d? | 2007-06-19 | 2007-09-28 | 136, 140, 183, 145, 146, 220FF |  |  | 2006-12-27 | 2007-01-30 | 25d? | 77.14d | 0d | finish no earlier than 2007-09-28 | Dekany [6.7%]; Britton [17%] | 70h |  | 6,222.3 | 5,274.9 |  |  |
| 157 | 3.1.1.6 | Encircled Energy vs Sky Coverage | 140d? | 2006-10-23 A | 2007-05-04 |  | 75% | 35d? | 2006-10-23 | 2006-12-29 | 50d? | 0d |  | finish no earlier than 2007-05-04 | Dekany [17.5%]; Gavel [17.5%] | 110h | 104.02h | 11,325.6 | 11,325.6 | 10,662.31 |  |
| 158 | 3.1.1.7 | Photometric Accuracy | 75d? | 2006-10-16 A | 2007-01-26 A |  | 100% |  | 2006-10-16 | 2007-01-26 | 75d? |  |  | start no earlier than 2006-10-16 | Britton [20%]; Neyman [10%]; Flicker [10%] | 240h | 240h | 17,544 | 17,544 | 17,544 |  |
| 159 | 3.1.1.8 | Astrometric Accuracy | 165d? | 2006-11-13 A | 2007-06-29 |  | 50% | 82.5d? | 2006-11-13 | 2007-06-29 | 165d? | 0d |  | start no earlier than 2006-11-13 | Britton [13.6%]; Cameron [13.6%] | 240h | 150h | 5,333.4 | 5,333.4 | 5,333.4 |  |
| 160 | 3.1.1.9 | Polarimetric Accuracy | 80d? | 2007-02-05 A | 2007-05-25 |  | 75% | 20d? | 2007-02-05 | 2007-03-09 | 25d? | 168.14d | 91d | finish no earlier than 2007-05-25 | Ireland [20%] | 40h | 36.73h |  |  |  |  |
| 161 | 3.1.1.10 | Companion Sensitivity | 140d? | 2006-11-13 A | 2007-05-25 |  | 75% | 35d? | 2006-11-13 | 2007-01-09 | 41.25d? | 0d |  | finish no earlier than 2007-05-25 | Macintosh [30.3%]; Neyman [24.2%]; Flicker [26.7%]; Dekany [35%] | 180h | 95.19h | 11,831.3 | 17,753.4 | 6,654.82 | assignment |
| 162 | 3.1.1.11 | Observing Efficiency | 171d? | 2007-02-05 A | 2007-09-28 |  | 50% | 85.5d? | 2007-02-05 | 2007-03-16 | 30d? | 77.14d | 0d | finish no earlier than 2007-09-28 | Le Mignant [8.3%]; Other [33.3%] | 100h | 79.92h | 5,731 | 5,731 | 4,580.09 | 160->100 |
| 163 | 3.1.1.12 | Observing Uptime | 26d? | 2007-08-27 A | 2007-09-28 |  | 27% | 19d? | 2007-11-05 | 2007-12-12 | 28d? | 77.14d | 0d | finish no earlier than 2007-09-28 | Chin [19.7%]; Johansson [19.7%] | 80h | 20h | 4,584.8 | 4,584.8 | 1,146.2 |  |

Notes:
- 131: PW
- 132: RD
- 133: RD
- 134: CN
- 135: RF
- 136: RF
- 137: RF
- 138: CN
- 139: CN
- 140: DG
- 141: RD
- 142: RD
- 143: RD
- 144: CN
- 145: DG
- 146: RD
- 147: CN
- 148: RF
- 149: DG
- 150: AB
- 151: AB
- 152: AB
- 153: AB
- 154: RD
- 155: RD
- 156: RD
- 157: DG
- 158: MB
- 159: BC
- 160: MI
- 161: RF
- 162: DLM
- 163: EJ

| ID | WBS | Task | Duration | Start | Finish | Predecessors | Complete | Remaining | Baseline start | Baseline finish | Baseline duration | Total slack | Free slack | Constraint | Resources | Work | Actual work | Cost | Baseline cost | Actual cost | Text1 |
| --- | --- | --- | --- | --- | --- | --- | --- | --- | --- | --- | --- | --- | --- | --- | --- | --- | --- | --- | --- | --- | --- |
| 164 | 3.1.1.13 | **Performance Budgets Summary** | 106d? | 2007-05-28 | 2007-10-19 |  |  |  | 2007-01-31 | 2007-07-20 | 123d? | 20.28d |  |  |  | 100h |  | 8,889 | 11,064.4 |  |  |
| 165 | 3.1.1.13.1 | Performance Budgets Summary Ver 1 | 10d? | 2007-05-28 | 2007-06-08 | 157, 158, 161, 155 |  |  | 2007-01-31 | 2007-02-27 | 20d? | 20.28d | 17.14d | start no earlier than 2007-05-28 | Britton [50%] | 40h |  | 3,555.6 | 6,994.2 |  |  |
| 166 | 3.1.1.13.2 | Performance Budgets Summary Ver 2 | 15d? | 2007-10-01 | 2007-10-19 | 154, 157, 158, 159, 160, 161, 162, 150, 151, 163 |  |  | 2007-07-02 | 2007-07-20 | 15d? | 77.14d |  |  | Dekany [16.7%]; Britton [33.3%] | 60h |  | 5,333.4 | 4,070.2 |  |  |
| 167 | 3.1.1.14 | **Science Products** | 41.75d? | 2007-10-01 | 2007-11-27 |  |  |  | 2007-07-23 | 2007-10-19 | 65d? | 100.58d |  |  |  | 230h |  | 14,760.3 | 21,005.9 |  |  |
| 168 | 3.1.1.14.1 | All-In Science Simulations | 23d? | 2007-10-01 | 2007-10-31 | 156 |  |  | 2007-07-23 | 2007-08-17 | 20d? | 100.58d | 0d | finish no earlier than 2007-10-31 | Neyman [21.7%]; Flicker [21.7%] | 80h |  | 4,584.8 | 9,169.6 |  |  |
| 169 | 3.1.1.14.2 | **Additional Science Characterization Results** | 18.75d? | 2007-11-01 | 2007-11-27 |  |  |  | 2007-08-20 | 2007-10-19 | 45d? | 100.58d |  |  |  | 150h |  | 10,175.5 | 11,836.3 |  |  |
| 170 | 3.1.1.14.2.1 | Point Source Sensitivities | 18.75d? | 2007-11-01 | 2007-11-27 | 168 |  |  | 2007-08-20 | 2007-09-13 | 18.75d? | 100.58d |  | start no earlier than 2007-04-02 | Bouchez [20%] | 30h |  | 2,666.7 | 2,666.7 |  |  |
| 171 | 3.1.1.14.2.2 | PSF Uniformity & Stability | 15d? | 2007-11-01 | 2007-11-21 | 168 |  |  | 2007-08-20 | 2007-09-07 | 15d? | 104.33d |  | start no earlier than 2007-04-02 | Neyman [66.7%]; Britton [40%] | 100h |  | 6,362.6 | 4,584.8 |  |  |
| 172 | 3.1.1.14.2.3 | Other | 3.75d? | 2007-11-19 | 2007-11-22 | 168 |  |  | 2007-10-01 | 2007-10-19 | 15d? | 103.58d |  | start no earlier than 2007-11-19 | Flicker [66.7%] | 20h |  | 1,146.2 | 4,584.8 |  | assignment |
| 173 | 3.1.2 | **Trade Studies** | 170d? | 2006-10-16 A | 2007-06-08 |  | 62% | 64.83d? | 2006-10-16 | 2007-05-25 | 160d? | 223.33d |  |  |  | 1350h | 946.13h | 99,006.04 | 131,430.06 | 66,938.23 |  |
| 174 | 3.1.2.1 | **System Architecture Trade Studies** | 155d? | 2006-10-16 A | 2007-05-18 |  | 74% | 40.74d? | 2006-10-16 | 2007-03-30 | 120d? | 35.28d | 32.14d |  |  | 618h | 564.82h | 42,270.76 | 48,341.26 | 38,509.11 |  |
| 175 | 3.1.2.1.1 | MOAO & MCAO TS | 25d? | 2006-11-13 A | 2006-12-15 A |  | 100% |  | 2006-11-13 | 2006-12-15 | 25d? |  |  | finish no earlier than 2006-12-15 | Gavel [40%] | 80h | 80h | 8,880 | 8,880 | 8,880 | assigned |
| 176 | 3.1.2.1.2 | NGAO versus Keck AO upgrades TS (meeting 5) | 20d? | 2007-02-05 A | 2007-03-02 A |  | 100% |  | 2007-02-05 | 2007-03-02 | 20d? |  |  | start no earlier than 2007-02-05 | Neyman [37.5%]; Wizinowich [25%] | 100h | 100h | 5,731 | 5,731 | 5,731 |  |
| 177 | 3.1.2.1.3 | Adaptive Secondary Mirror option TS (m5) | 17d? | 2007-04-06 A | 2007-04-30 |  | 25% | 12.75d? | 2007-03-05 | 2007-03-30 | 20d? | 0d |  | finish no earlier than 2007-04-30 | Bauman [15%]; Wizinowich [12.5%] | 16h | 3.4h | 916.96 | 3,004.96 | 194.85 | assignment |
| 178 | 3.1.2.1.4 | K & L-band Science TS (m5) | 0.5d? | 2007-02-05 | 2007-02-05 |  |  |  | 2007-02-05 | 2007-03-02 | 20d? | 109.78d |  | start no earlier than 2007-02-05 | Bouchez [25%] | 1h |  | 88.89 | 3,555.6 |  |  |
| 179 | 3.1.2.1.5 | Keck Interferometer Support TS (m5) | 100d? | 2006-10-16 A | 2007-03-02 |  | 75% | 25d? | 2006-10-16 | 2007-03-02 | 100d? | 0d |  | start no earlier than 2006-10-16 | Neyman [22.5%]; Wizinowich [2.5%] | 120h | 115h | 6,877.2 | 6,877.2 | 6,590.65 |  |
| 180 | 3.1.2.1.6 | Instrument Balance TS | 2d? | 2006-11-13 | 2006-11-14 |  |  |  | 2006-11-13 | 2006-12-08 | 20d? | 168.28d |  | start no earlier than 2006-11-13 | Adkins [6.2%] | 1h |  | 57.31 | 573.1 |  |  |
| 181 | 3.1.2.1.7 | GLAO for non-NGAO Instruments TS (m5) | 20d? | 2007-02-05 A | 2007-03-02 A |  | 100% |  | 2007-02-05 | 2007-03-02 | 20d? |  |  | start no earlier than 2007-02-05 | Flicker [12.5%] | 20h | 20h | 1,146.2 | 1,146.2 | 1,146.2 |  |
| 182 | 3.1.2.1.8 | Science Instrument Re-use Cost/Benefit TS (m3) | 135d? | 2006-11-13 A | 2007-05-18 |  | 50% | 67.5d? | 2006-11-13 | 2006-12-08 | 20d? | 35.28d |  | finish no earlier than 2007-05-18 | Adkins [25%]; Moore [50%] | 120h | 87.6h | 9,403.6 | 9,403.6 | 6,864.63 |  |
| 183 | 3.1.2.1.9 | Telescope Wavefront Errors TS | 13d? | 2006-12-04 A | 2006-12-20 A | 138, 139 | 100% |  | 2006-12-04 | 2006-12-20 | 13d? |  |  | finish no earlier than 2006-12-20 | Neyman [38.5%]; Flicker [38.5%] | 80h | 80h | 4,584.8 | 4,584.8 | 4,584.8 |  |
| 184 | 3.1.2.1.10 | Observing Model TS | 125d? | 2006-11-13 A | 2007-05-04 |  | 90% | 12.5d? | 2006-11-13 | 2007-01-12 | 45d? | 45.28d |  | finish no earlier than 2007-05-04 | Le Mignant [22.2%] | 80h | 78.82h | 4,584.8 | 4,584.8 | 4,516.98 |  |
| 185 | 3.1.2.2 | **Adaptive Optics System Trade Studies** | 138d? | 2006-10-30 A | 2007-05-09 |  | 54% | 63.59d? | 2006-10-30 | 2007-05-25 | 150d? | 42.28d | 39.14d |  |  | 530h | 341.07h | 39,600.38 | 67,322.6 | 25,490.8 |  |
| 186 | 3.1.2.2.1 | AO Enclosure Temperature TS (m6) | 1.06d? | 2007-01-02 A | 2007-01-03 |  | 25% | 0.79d? | 2007-01-02 | 2007-04-13 | 74d? | 133.22d |  | start no earlier than 2007-01-02 | Bouchez [5.1%]; Meguro [6.8%] | 1h | 0.25h | 70.84 | 4,959.1 | 17.7 |  |
| 187 | 3.1.2.2.2 | Optical Relay TS (m6) | 74d? | 2007-01-02 A | 2007-04-13 |  | 25% | 55.5d? | 2007-01-02 | 2007-04-13 | 74d? | 60.28d |  | finish no earlier than 2007-04-13 | Bauman [5.1%]; Dekany [5.1%] | 60h | 15h | 5,276.7 | 5,276.7 | 1,319.17 |  |
| 188 | 3.1.2.2.3 | Field Rotation Strategy TS (m6) | 74d? | 2007-01-02 A | 2007-04-13 |  | 25% | 55.5d? | 2007-01-02 | 2007-04-13 | 74d? | 60.28d |  | start no earlier than 2007-01-02 | Bauman [10.1%]; Dekany [3.4%] | 60h | 20h | 5,257.8 | 6,366.2 | 1,749.45 |  |
| 189 | 3.1.2.2.4 | Dichroics & Beamsplitters TS (m6) | 1.23d? | 2007-01-02 | 2007-01-03 |  |  |  | 2007-01-02 | 2007-04-13 | 74d? | 133.05d |  | start no earlier than 2007-01-02 | Velur [10.1%] | 1h |  | 88.89 | 5,333.4 |  |  |
| 190 | 3.1.2.2.5 | Rayleigh Rejection TS (m3) | 54d? | 2006-10-30 A | 2007-05-09 |  | 75% | 13.5d? | 2006-10-30 | 2006-12-08 | 30d? | 42.28d |  | finish no earlier than 2007-05-09 | Velur [16.7%] | 72h | 54h | 6,400.08 | 2,292.4 | 4,800.06 |  |
| 191 | 3.1.2.2.6 | LGS WFS Type TS (m4) | 35d? | 2006-12-04 A | 2007-01-19 A |  | 100% |  | 2006-12-04 | 2007-01-19 | 35d? |  |  | start no earlier than 2006-12-04 | Velur [10.7%] | 30h | 30h | 2,666.7 | 2,666.7 | 2,666.7 |  |
| 192 | 3.1.2.2.7 | LGS WFS number of subapertures TS (m4) | 35d? | 2006-12-04 A | 2007-01-19 A |  | 100% |  | 2006-12-04 | 2007-01-19 | 35d? |  |  | start no earlier than 2006-12-04 | Velur [7.1%] | 20h | 20h | 1,777.8 | 1,777.8 | 1,777.8 |  |
| 193 | 3.1.2.2.8 | Slow WFS TS (m7) | 0.31d? | 2007-04-23 | 2007-04-23 |  |  |  | 2007-04-23 | 2007-05-25 | 25d? | 54.97d |  | start no earlier than 2007-04-23 | Velur [40%] | 1h |  | 88.89 | 7,111.2 |  |  |
| 194 | 3.1.2.2.9 | LOWFS Architecture TS | 80.5d? | 2006-12-04 A | 2007-05-09 |  | 35% | 52.33d? | 2006-12-04 | 2007-02-09 | 50d? | 0d |  | finish no earlier than 2007-05-09 | Flicker [71.4%]; Velur [20%]; Kellner [18.8%] | 220h | 141.32h | 13,239.8 | 11,696 | 8,730.41 |  |
| 195 | 3.1.2.2.10 | Number & Type of LOWFS TS (m4) | 40d? | 2006-12-04 A | 2007-01-26 A |  | 100% |  | 2006-12-04 | 2007-01-26 | 40d? |  |  | start no earlier than 2006-12-04 | Kellner [21.4%]; Velur [9.4%] | 60h | 60h | 4,386 | 4,386 | 4,386 |  |
| 196 | 3.1.2.2.11 | Centroid Anisoplanatism TS (m7) | 0.62d? | 2007-04-23 | 2007-04-23 |  |  |  | 2007-04-23 | 2007-05-25 | 25d? | 54.66d |  | start no earlier than 2007-04-23 | Kellner [20%] | 1h |  | 57.31 | 2,292.4 |  |  |
| 197 | 3.1.2.2.12 | Deformable Mirror Stroke Requirement TS (m6) | 1.48d? | 2007-01-02 | 2007-01-03 |  |  |  | 2007-01-02 | 2007-04-13 | 74d? | 132.8d |  | start no earlier than 2007-01-02 | Flicker [8.4%] | 1h |  | 57.31 | 2,865.5 |  |  |
| 198 | 3.1.2.2.13 | Stand-alone vs DM on T/T Stage TS (m3) | 0.5d? | 2006-10-30 A | 2006-10-30 |  | 50% | 0.25d? | 2006-10-30 | 2006-12-08 | 30d? | 179.78d |  | start no earlier than 2006-10-30 | Bauman [25%] | 1h | 0.5h | 87 | 5,220 | 43.5 |  |
| 199 | 3.1.2.2.14 | Correcting Fast T/T with DM TS | 0.75d? | 2006-12-08 | 2006-12-08 |  |  |  | 2006-10-30 | 2006-12-08 | 30d? | 150.28d |  | finish no earlier than 2006-12-08 | Bauman [8.3%]; Flicker [8.3%] | 1h |  | 72.16 | 2,886.2 |  |  |
| 200 | 3.1.2.2.15 | Focus Compensation TS (m6) | 2.47d? | 2007-01-22 | 2007-01-24 |  |  |  | 2007-01-22 | 2007-05-03 | 74d? | 117.81d |  | start no earlier than 2007-01-22 | Kellner [2.5%]; Velur [2.5%] | 1h |  | 73.1 | 2,193 |  |  |

Notes:
- 165: MB
- 166: MB
- 168: CN
- 170: AB
- 171: CN
- 172: RF
- 173: RD
- 175: DG
- 176: PW
- 177: PW
- 178: Cancel
- 179: CN
- 180: Cancel
- 181: RF
- 182: AM
- 183: CN
- 184: DLM
- 186: Cancel
- 187: RD
- 188: RD
- 189: Cancel
- 190: VV
- 191: VV
- 192: VV
- 193: Cancel
- 194: RF
- 195: RC
- 196: Cancel
- 197: Cancel
- 198: Cancel
- 199: Cancel
- 200: Cancel

| ID | WBS | Task | Duration | Start | Finish | Predecessors | Complete | Remaining | Baseline start | Baseline finish | Baseline duration | Total slack | Free slack | Constraint | Resources | Work | Actual work | Cost | Baseline cost | Actual cost | Text1 |
| --- | --- | --- | --- | --- | --- | --- | --- | --- | --- | --- | --- | --- | --- | --- | --- | --- | --- | --- | --- | --- | --- |
| 201 | 3.1.2.3 | **Laser Facility Trade Studies** | 165d? | 2006-10-16 A | 2007-06-01 |  | 37% | 103.63d? | 2006-10-16 | 2007-03-05 | 101d? | 25.28d | 0d |  |  | 142h | 40.25h | 12,843.6 | 15,766.2 | 2,938.33 |  |
| 202 | 3.1.2.3.1 | Laser Pulse Format TS (m6) | 0.25d? | 2007-01-02 | 2007-01-02 |  |  |  | 2007-01-02 | 2007-01-29 | 20d? | 133.84d | 19.75d | start no earlier than 2007-01-02 | Velur [50%] | 1h |  | 88.89 | 7,111.2 |  |  |
| 203 | 3.1.2.3.2 | Free Space vs Fiber TS (m7) | 0.25d? | 2007-01-30 A | 2007-01-30 | 202 | 25% | 0.19d? | 2007-01-30 | 2007-03-05 | 25d? | 114.03d |  |  | Neyman [50%] | 1h | 0.25h | 57.31 | 5,731 | 14.33 |  |
| 204 | 3.1.2.3.3 | LGS Asterism Geometry & Size TS (m2) | 5d? | 2006-10-23 A | 2006-10-27 A |  | 100% |  | 2006-10-23 | 2006-10-27 | 5d? |  |  | finish no earlier than 2006-10-27 | Flicker [50%] | 20h | 20h | 1,146.2 | 1,146.2 | 1,146.2 |  |
| 205 | 3.1.2.3.4 | Variable vs fixed LGS Asterism Cost/Benefit TS (m2) | 10d? | 2006-10-16 A | 2006-10-27 A |  | 100% |  | 2006-10-16 | 2006-10-27 | 10d? |  |  | finish no earlier than 2006-10-27 | Velur [25%] | 20h | 20h | 1,777.8 | 1,777.8 | 1,777.8 |  |
| 206 | 3.1.2.3.5 | Uplink compensation | 25d? | 2007-04-30 | 2007-06-01 |  |  |  |  |  |  | 25.28d |  | finish no earlier than 2007-06-01 | Gavel [20%]; Velur | 100h |  | 9,773.4 |  |  |  |
| 207 | 3.1.2.4 | Trade Study Conclusions Summary | 20d? | 2007-05-14 | 2007-06-08 |  |  |  |  |  |  | 223.33d |  | start no earlier than 2007-05-14 | Neyman [18.8%]; Wizinowich; Gavel; Dekany | 60h |  | 4,291.3 |  |  |  |
| 208 | 3.1.3 | **System Architecture** | 194d? | 2007-05-08 | 2008-02-01 |  |  |  | 2007-02-28 | 2007-12-28 | 218d? | 5.14d |  |  |  | 1962h |  | 152,819.42 | 78,215.62 |  |  |
| 209 | 3.1.3.1 | **Candidate Subsystems** | 39.14d? | 2007-05-10 | 2007-07-04 |  |  |  | 2007-02-28 | 2007-04-18 | 36d? | 3.14d | 0d |  |  | 510h |  | 42,198.08 | 7,142.9 |  |  |
| 210 | 3.1.3.1.1 | Define Candidate Subsystems | 16d? | 2007-05-10 | 2007-05-31 |  |  |  |  |  |  | 3.14d | 0d | finish no earlier than 2007-05-31 | Bauman [31.2%]; Dekany; Gavel; Neyman; Velur; Wizinowich | 260h |  | 21,393.8 |  |  |  |
| 211 | 3.1.3.1.2 | Subsystems Performance Evaluation | 16d? | 2007-06-01 | 2007-06-22 | 210 |  |  |  |  |  | 139.14d |  | finish no earlier than 2007-06-22 | Dekany [26.6%]; Gavel; Neyman; Bauman | 70h |  | 6,085.98 |  |  |  |
| 212 | 3.1.3.1.3 | Subsystems Cost Evaluation | 16d? | 2007-06-01 | 2007-06-22 | 210 |  |  |  |  |  | 139.14d |  | finish no earlier than 2007-06-22 | Bauman [7.8%]; Dekany; Gavel; Neyman; Velur; Wizinowich | 70h |  | 6,014 |  |  |  |
| 213 | 3.1.3.1.4 | Subsystems Risk Evaluation | 16d? | 2007-06-01 | 2007-06-22 | 210 |  |  |  |  |  | 3.14d | 0d | finish no earlier than 2007-06-22 | Dekany [35%]; Gavel; Neyman [15.6%]; Wizinowich | 40h |  | 2,987.2 |  |  |  |
| 214 | 3.1.3.1.5 | Organize Candidate Subsystems | 7.14d? | 2007-06-25 | 2007-07-04 | 213 |  |  |  |  |  | 3.14d | 0d |  | Dekany [35%]; Gavel; Neyman; Wizinowich | 70h |  | 5,717.1 |  |  |  |
| 215 | 3.1.3.2 | **Candidate Architectures** | 127.86d? | 2007-07-04 | 2007-12-28 | 174, 185, 201, 165, 214 |  |  | 2007-07-23 | 2007-08-17 | 20d? | 3.14d | 0d |  |  | 905h |  | 75,529.7 | 5,144 |  |  |
| 216 | 3.1.3.2.1 | Define Candidate Architectures | 12.5d? | 2007-07-04 | 2007-07-20 |  |  |  |  |  |  | 3.14d | 0d |  | Bauman [40%]; Dekany; Gavel; Neyman; Velur; Wizinowich | 280h |  | 23,613.8 |  |  |  |
| 217 | 3.1.3.2.2 | Architectures Performance Evaluation | 4.69d? | 2007-07-20 | 2007-07-27 | 216 |  |  |  |  |  | 10.95d | 7.81d |  | Bauman [40%]; Dekany; Gavel; Neyman; Velur; Wizinowich | 100h |  | 8,402.8 |  |  |  |
| 218 | 3.1.3.2.3 | Architectures Cost Evaluation | 12.5d? | 2007-07-20 | 2007-08-08 | 216 |  |  |  |  |  | 3.14d | 0d |  | Bauman [40%]; Dekany; Gavel; Neyman; Velur; Wizinowich | 240h |  | 20,689.8 |  |  |  |
| 219 | 3.1.3.2.4 | Architectures Risk Evaluation | 3.01d? | 2007-07-20 | 2007-07-25 | 216 |  |  |  |  |  | 12.62d | 9.49d |  | Neyman [83%]; Dekany; Gavel; Wizinowich | 40h |  | 2,987.2 |  |  |  |
| 220 | 3.1.3.2.5 | Adopt Baseline Architecture(s) | 10.71d? | 2007-08-08 | 2007-08-22 | 217, 218, 219 |  |  |  |  |  | 3.14d | 0d |  | Dekany [35%]; Gavel; Neyman; Wizinowich | 75h |  | 6,051 |  |  |  |
| 221 | 3.1.3.2.6 | System Architecture ver 1 | 7d | 2007-08-23 | 2007-08-31 | 220 |  |  |  |  |  | 88.14d |  | finish no earlier than 2007-08-31 | Dekany [71.4%]; Gavel; Neyman; Wizinowich | 100h |  | 8,068 |  |  |  |
| 222 | 3.1.3.2.7 | System Architecture ver 2 | 7.14d? | 2007-12-18 | 2007-12-28 | 236, 268 |  |  |  |  |  | 3.14d | 0d |  | Dekany [35%]; Gavel; Neyman; Wizinowich | 70h |  | 5,717.1 |  |  |  |
| 223 | 3.1.3.3 | **Functional Requirements** | 194d? | 2007-05-08 | 2008-02-01 |  |  |  | 2007-04-19 | 2007-11-30 | 162d? | 3.14d | 0d |  |  | 477h |  | 29,513.46 | 56,474.4 |  |  |
| 224 | 3.1.3.3.1 | Draft Functional Requirements Document | 7.35d? | 2007-05-22 | 2007-05-31 |  |  |  |  |  |  | 179.14d |  | finish no earlier than 2007-05-31 | Wizinowich [34%] | 20h |  | 1,146.2 |  |  |  |
| 225 | 3.1.3.3.2 | AO System Functional Requirements Ver 1 | 17.25d? | 2007-08-06 | 2007-08-29 | 209 |  |  | 2007-04-19 | 2007-05-14 | 17.25d? | 115.89d |  | start no earlier than 2007-08-06 | Neyman [54.3%]; Chin [18.1%]; Stomski [18.1%]; Meguro [18.1%]; Bauman [18.1%]; Johansson [18.1%]; Wizinowich [34%] | 145h |  | 8,606.86 | 12,204.25 |  |  |
| 226 | 3.1.3.3.3 | AO System Functional Requirements Ver 2 | 13.33d? | 2007-12-28 | 2008-01-16 | 215 |  |  | 2007-10-29 | 2007-11-30 | 25d? | 14.8d |  | start no earlier than 2007-10-29 | Neyman [12.5%]; Chin [7.5%]; Stomski [7.5%]; Meguro [7.5%]; Bauman [7.5%]; Johansson [7.5%] | 50h |  | 3,103.02 | 6,176.35 |  |  |
| 227 | 3.1.3.3.4 | Laser System Functional Requirements Ver 1 | 20d? | 2007-07-04 | 2007-08-01 | 209 |  |  | 2007-04-19 | 2007-05-16 | 20d? | 135.99d |  | finish no earlier than 2007-03-02 | Chin [34.4%]; Velur [34.4%]; Stomski [15.6%]; Meguro [27%]; Wizinowich [34%] | 110h |  | 7,567.3 | 9,473.75 |  |  |
| 228 | 3.1.3.3.5 | Laser System Functional Requirements Ver 2 | 20d? | 2007-12-28 | 2008-01-25 | 215 |  |  | 2007-10-29 | 2007-11-30 | 25d? | 8.14d |  | start no earlier than 2007-10-29 | Chin [12.5%]; Velur [12.5%]; Stomski [7.5%] | 36h |  | 2,442.12 | 4,514.65 |  |  |
| 229 | 3.1.3.3.6 | Science Operations Functional Requirements Ver 1 | 24d? | 2007-07-04 | 2007-08-07 | 209 |  |  | 2007-04-19 | 2007-05-22 | 24d? | 131.99d |  | finish no earlier than 2007-02-02 | Le Mignant [20.8%]; Wizinowich [31.2%] | 50h |  | 2,865.5 | 5,731 |  |  |
| 230 | 3.1.3.3.7 | Science Operations Functional Requirements Ver 2 | 25d? | 2007-12-28 | 2008-02-01 | 215 |  |  | 2007-10-29 | 2007-11-30 | 25d? | 3.14d |  | start no earlier than 2007-10-29 | Le Mignant [20%]; Other [30%] | 50h |  | 2,865.5 | 5,731 |  |  |
| 231 | 3.1.3.3.8 | Science Instruments Function Allocation Ver 1 | 18d? | 2007-05-08 | 2007-05-31 | 317 |  |  | 2007-04-19 | 2007-05-14 | 18d? | 179.14d |  | finish no earlier than 2007-05-31 | Adkins [4.2%]; Wizinowich [34.7%] | 8h |  | 458.48 | 6,163.8 |  | Moore |
| 232 | 3.1.3.3.9 | Science Instruments Function Allocation Ver 2 | 3.75d? | 2008-01-14 | 2008-01-17 | 320 |  |  | 2007-10-29 | 2007-11-14 | 12.5d? | 13.39d |  | finish no earlier than 2007-06-29 | Adkins [20%]; Wizinowich [60%] | 8h |  | 458.48 | 6,479.6 |  | Moore |
| 233 | 3.1.3.4 | Technology Drivers Summary | 2.27d? | 2007-10-23 | 2007-10-25 | 220 |  |  | 2007-07-23 | 2007-07-26 | 3.63d? | 123.33d |  | finish no earlier than 2007-10-25 | Gavel [55.1%] | 10h |  | 1,110 | 3,151.44 |  |  |
| 234 | 3.1.3.5 | Technical Risk Analysis Ver 1 | 15d? | 2007-08-27 | 2007-09-14 | 220 |  |  | 2007-07-26 | 2007-08-28 | 23d? | 153.33d |  | finish no earlier than 2007-09-14 | Neyman [8.3%]; Wizinowich [34%]; Dekany [35%]; Gavel [35%] | 20h |  | 1,316.74 | 3,151.44 |  |  |
| 235 | 3.1.3.6 | Technical Risk Analysis Ver 2 | 20d? | 2007-12-28 | 2008-01-25 | 222 |  |  | 2007-12-03 | 2007-12-28 | 20d? | 8.14d | 5d | finish no earlier than 2007-12-28 | Neyman [15%]; Gavel [10%] | 40h |  | 3,151.44 | 3,151.44 |  |  |

Notes:
- 202: Cancel
- 203: Cancel
- 204: RF
- 205: VV
- 206: DG
- 207: CN
- 208: RD
- 209: RD
- 210: RD
- 211: RD
- 212: DG
- 213: CN
- 214: RD
- 215: RD
- 216: RD
- 217: RD
- 218: DG
- 219: CN
- 220: RD
- 221: RD
- 222: RD
- 223: PW
- 224: PW
- 225: CN
- 226: CN
- 227: JC
- 228: JC
- 229: DLM
- 230: DLM
- 231: SA
- 232: SA
- 233: DG
- 234: CN
- 235: CN

| ID | WBS | Task | Duration | Start | Finish | Predecessors | Baseline start | Baseline finish | Baseline duration | Total slack | Free slack | Constraint | Resources | Work | Cost | Baseline cost | Text1 |
| --- | --- | --- | --- | --- | --- | --- | --- | --- | --- | --- | --- | --- | --- | --- | --- | --- | --- |
| 236 | 3.2 | **AO System** | 132.86d? | 2007-06-18 | 2007-12-18 |  | 2007-03-05 | 2007-12-14 | 205d? | 3.14d | 0d |  |  | 1829h | 131,805.84 | 122,338.8 |  |
| 237 | 3.2.1 | AO System Architecture | 60d? | 2007-08-22 | 2007-11-13 | 220 | 2007-04-19 | 2007-06-20 | 45d? | 28.14d |  | start no earlier than 2007-02-05 | Gavel [8.3%] | 40h | 4,440 | 18,447.5 | let's discuss |
| 238 | 3.2.2 | AO Enclosure | 28d? | 2007-08-22 | 2007-09-28 | 220 | 2007-05-14 | 2007-08-17 | 70d? | 60.14d |  |  | Meguro [17.9%] | 40h | 2,292.4 | 5,731 |  |
| 239 | 3.2.3 | **Opto-mechanical** | 85d? | 2007-08-22 | 2007-12-18 | 220 | 2007-04-02 | 2007-12-14 | 185d? | 3.14d |  |  |  | 1079h | 85,560.15 | 54,627.7 |  |
| 240 | 3.2.3.1 | Field Rotation | 53.14d? | 2007-08-22 | 2007-11-02 | 188 | 2007-04-16 | 2007-08-08 | 82.5d? | 14.99d | 0d | finish no earlier than 2007-11-02 | Bauman [7.1%]; Lockwood [3.5%] | 45h | 4,119 | 4,119 |  |
| 241 | 3.2.3.2 | Optical Relay | 53.14d? | 2007-08-22 | 2007-11-02 | 187 | 2007-04-16 | 2007-08-15 | 88d? | 14.99d | 0d | finish no earlier than 2007-11-02 | Bauman [9.4%]; Lockwood [3.4%]; Dekany [2.4%] | 60h | 5,374.9 | 5,374.9 |  |
| 242 | 3.2.3.3 | Optical Switchyard | 53.14d? | 2007-08-22 | 2007-11-02 | 189 | 2007-04-16 | 2007-06-29 | 55d? | 14.99d | 0d | finish no earlier than 2007-11-02 | Bauman [5.9%]; Lockwood [5.9%] | 50h | 4,690 | 4,690 |  |
| 243 | 3.2.3.4 | Optical Support Structure | 20d? | 2007-11-05 | 2007-11-30 | 240, 241, 242 | 2007-10-01 | 2007-11-16 | 35d? | 14.99d |  | finish no earlier than 2007-11-30 | Lockwood [18.8%]; Bauman [9.4%] | 45h | 4,323 | 4,323 |  |
| 244 | 3.2.3.5 | **Wavefront Sensors** | 63.14d? | 2007-08-22 | 2007-11-16 |  | 2007-05-07 | 2007-12-12 | 158d? | 24.99d |  |  |  | 240h | 18,491.4 | 17,228.2 |  |
| 245 | 3.2.3.5.1 | High Order LGS Wavefront Sensors | 63.14d? | 2007-08-22 | 2007-11-16 | 191, 192 | 2007-05-07 | 2007-12-12 | 158d? | 24.99d |  | finish no earlier than 2007-11-16 | Velur [11.9%]; Meguro [4%] | 80h | 6,479.6 | 6,479.6 |  |
| 246 | 3.2.3.5.2 | High Order NGS Wavefront Sensor | 63.14d? | 2007-08-22 | 2007-11-16 |  | 2007-05-07 | 2007-12-12 | 158d? | 24.99d |  | finish no earlier than 2007-11-16 | Velur [5.9%]; Meguro [2%] | 40h | 3,239.8 | 3,239.8 |  |
| 247 | 3.2.3.5.3 | Low Order NGS Wavefront Sensors | 63.14d? | 2007-08-22 | 2007-11-16 | 194, 195 | 2007-05-07 | 2007-12-12 | 158d? | 24.99d |  | finish no earlier than 2007-11-16 | Kellner [3.2%]; Meguro [4%]; Velur [7.9%]; Moore [40%] | 80h | 6,479.6 | 5,216.4 |  |
| 248 | 3.2.3.5.4 | Calibration Wavefront Sensor | 63.14d? | 2007-08-22 | 2007-11-16 | 193 | 2007-05-28 | 2007-12-12 | 143d? | 24.99d |  | finish no earlier than 2007-11-16 | Neyman [7.9%] | 40h | 2,292.4 | 2,292.4 |  |
| 249 | 3.2.3.6 | **Wavefront Correctors** | 73.14d? | 2007-08-22 | 2007-11-30 |  | 2007-04-02 | 2007-11-30 | 175d? | 14.99d |  |  |  | 115h | 7,452.9 | 10,752.2 |  |
| 250 | 3.2.3.6.1 | Tip/Tilt Corrector | 45d? | 2007-10-01 | 2007-11-30 | 252 | 2007-10-01 | 2007-11-30 | 45d? | 14.99d |  | start no earlier than 2007-10-01 | Flicker [2.8%]; Bauman [2.8%] | 20h | 1,443.1 | 1,443.1 |  |
| 251 | 3.2.3.6.2 | Deformable Mirror | 65d? | 2007-08-22 | 2007-11-20 |  | 2007-04-02 | 2007-06-29 | 65d? | 23.14d |  | start no earlier than 2007-04-02 | Neyman [7.7%]; Bauman [11.8%] | 50h | 3,162.4 | 9,309.1 |  |
| 252 | 3.2.3.6.3 | Tip/tilt Vibration Mitigation | 28.14d? | 2007-08-22 | 2007-09-28 |  |  |  |  | 14.99d | 0d | finish no earlier than 2007-09-28 | Neyman [8.9%]; Johansson; Gavel | 45h | 2,847.4 |  |  |
| 253 | 3.2.3.7 | **Acquisition Cameras** | 20d? | 2007-10-01 | 2007-10-26 |  | 2007-10-01 | 2007-10-26 | 20d? | 39.99d |  |  |  | 40h | 2,292.4 | 3,555.6 |  |
| 254 | 3.2.3.7.1 | NGS Acquisition Camera | 20d? | 2007-10-01 | 2007-10-26 |  | 2007-10-01 | 2007-10-26 | 20d? | 39.99d |  | finish no earlier than 2007-10-26 | Neyman [12.5%] | 20h | 1,146.2 | 1,777.8 |  |
| 255 | 3.2.3.7.2 | LGS Acquisition Camera | 20d? | 2007-10-01 | 2007-10-26 |  | 2007-10-01 | 2007-10-26 | 20d? | 39.99d |  | finish no earlier than 2007-10-26 | Neyman [12.5%] | 20h | 1,146.2 | 1,777.8 |  |
| 256 | 3.2.3.8 | Atmospheric Dispersion Correction | 85d? | 2007-08-22 | 2007-12-18 |  | 2007-08-20 | 2007-12-14 | 85d? | 3.14d |  | finish no earlier than 2007-12-14 | Bauman [2.9%]; Dekany [35%] | 24h | 2,095.55 | 1,146.2 |  |
| 257 | 3.2.3.9 | Alignment, Calibration, Diagnostics, Metrology and Monitoring | 24d? | 2007-08-22 | 2007-09-24 |  | 2007-04-02 | 2007-06-29 | 65d? | 64.14d |  | finish no earlier than 2007-06-29 | Neyman [10.4%]; Flicker [10.4%]; Le Mignant [10.4%] | 60h | 3,438.6 | 3,438.6 |  |
| 258 | 3.2.3.10 | Atmospheric Profiler | 30.14d? | 2007-08-22 | 2007-10-02 |  |  |  |  | 57.99d |  | finish no earlier than 2007-10-02 | Britton [20.7%] | 50h | 4,444.5 |  |  |
| 259 | 3.2.3.11 | d-IFU & LOWFS AO & Object Selection | 56d? | 2007-08-22 | 2007-11-07 |  |  |  |  | 32.14d |  | finish no earlier than 2007-08-06 | Moore [44.6%]; Gavel; Meguro | 320h | 26,802.8 |  |  |
| 260 | 3.2.3.12 | PSF Monitoring Camera | 20d? | 2007-10-01 | 2007-10-26 |  |  |  |  | 39.99d |  | start no earlier than 2007-10-01 | Britton [6.2%]; Neyman | 30h | 2,035.1 |  |  |

Notes:
- 236: DG
- 237: DG
- 238: JM
- 239: BB
- 240: BB
- 241: BB
- 242: BB
- 243: BB
- 244: VV
- 245: VV
- 246: VV
- 247: VV
- 248: CN
- 249: CN
- 250: BB
- 251: CN
- 252: CN
- 253: CN
- 254: CN
- 255: CN
- 256: RD
- 257: CN
- 258: MB
- 259: AM
- 260: MB

| ID | WBS | Task | Duration | Start | Finish | Predecessors | Baseline start | Baseline finish | Baseline duration | Total slack | Free slack | Constraint | Resources | Work | Cost | Baseline cost | Text1 |
| --- | --- | --- | --- | --- | --- | --- | --- | --- | --- | --- | --- | --- | --- | --- | --- | --- | --- |
| 261 | 3.2.4 | **Non-real-time Control** | 110d? | 2007-06-25 | 2007-11-22 |  | 2007-06-25 | 2007-11-23 | 110d? | 20.99d |  |  |  | 330h | 18,923.69 | 22,943 |  |
| 262 | 3.2.4.1 | Non-RTC Software | 50d? | 2007-06-25 | 2007-08-31 |  | 2007-06-25 | 2007-08-31 | 50d? | 80.99d |  | start no earlier than 2007-06-25 | Johansson [20%]; Stomski [20%]; Johnson [10%] | 170h | 9,742.7 | 11,462 |  |
| 263 | 3.2.4.2 | Non-RTC Electronics | 90d? | 2007-07-23 | 2007-11-22 |  | 2007-07-23 | 2007-11-23 | 90d? | 20.99d |  | finish no earlier than 2007-11-22 | Chin [8.3%]; Reinig [8.3%]; Johansson [33%] | 160h | 9,180.99 | 11,481 |  |
| 264 | 3.2.5 | **Real-time Control** | 112d? | 2007-06-18 | 2007-11-19 |  | 2007-03-05 | 2007-08-07 | 112d? | 23.99d |  |  |  | 340h | 20,589.6 | 20,589.6 |  |
| 265 | 3.2.5.1 | RTC Architecture Analysis and Design Study | 45d? | 2007-06-18 | 2007-08-17 |  | 2007-03-05 | 2007-05-04 | 45d? | 23.99d | 0d | start no earlier than 2007-06-18 | Gavel [5.6%]; Johansson [11.1%]; Flicker [11.1%]; Reinig [22.2%] | 180h | 11,404.8 | 11,404.8 |  |
| 266 | 3.2.5.2 | RTC Software Module Definition | 67d? | 2007-08-20 | 2007-11-19 | 265 | 2007-05-07 | 2007-08-07 | 67d? | 23.99d |  |  | Johansson [11.2%]; Reinig [3.7%] | 80h | 4,588.6 | 4,588.6 |  |
| 267 | 3.2.5.3 | RTC Hardware Module Definition | 67d? | 2007-08-20 | 2007-11-19 | 265 | 2007-05-07 | 2007-08-07 | 67d? | 23.99d |  |  | Johansson [3.7%]; Reinig [11.2%] | 80h | 4,596.2 | 4,596.2 |  |
| 268 | 3.3 | **Laser Facility** | 141d? | 2007-06-04 | 2007-12-14 |  | 2007-03-06 | 2007-12-14 | 204d? | 4.99d | 1.86d |  |  | 570h | 38,985.93 | 52,456.5 | Discuss; JC? |
| 269 | 3.3.1 | Laser System Architecture | 50d? | 2007-06-04 | 2007-08-10 | 157, 201, 155 | 2007-03-06 | 2007-05-14 | 50d? | 52.99d | 0d |  | Velur [20%] | 80h | 7,111.2 | 7,111.2 |  |
| 270 | 3.3.2 | Laser Enclosure | 43d? | 2007-08-13 | 2007-10-09 | 269 | 2007-05-15 | 2007-07-12 | 43d? | 52.99d |  |  | Meguro [23.3%] | 80h | 4,584.8 | 4,584.8 |  |
| 271 | 3.3.3 | Laser | 35d? | 2007-08-13 | 2007-09-27 | 269 | 2007-05-15 | 2007-07-02 | 35d? | 60.99d |  | finish no earlier than 2007-09-27 | Velur [7.1%] | 20h | 1,777.8 | 8,889 |  |
| 272 | 3.3.4 | **Laser Launch Facility** | 25d? | 2007-08-06 | 2007-09-07 |  | 2007-04-09 | 2007-06-01 | 40d? | 75.99d |  |  |  | 200h | 14,623.23 | 20,982.6 | ch name back |
| 273 | 3.3.4.1 | Laser Beam Transport | 25d? | 2007-08-06 | 2007-09-07 | 202, 203 | 2007-04-09 | 2007-06-01 | 40d? | 75.99d |  | finish no earlier than 2007-09-07 | Neyman [15%]; Velur [8%]; Chin [2%] | 50h | 3,370.78 | 3,438.6 |  |
| 274 | 3.3.4.2 | Laser Pointing & Diagnostics | 25d? | 2007-08-06 | 2007-09-07 | 202, 203 | 2007-04-09 | 2007-06-01 | 40d? | 75.99d |  | start no earlier than 2007-08-06 | Velur [20%]; Neyman [21.9%]; Chin [6.2%]; Bauman [22%] | 80h | 6,293.35 | 9,087.8 | add AM |
| 275 | 3.3.4.3 | Laser Launch Telescope | 25d? | 2007-08-06 | 2007-09-07 | 204, 202, 203 | 2007-04-09 | 2007-06-01 | 40d? | 75.99d |  | start no earlier than 2007-08-06 | Velur [15%]; Neyman [15%]; Chin [11.1%] | 70h | 4,959.1 | 8,456.2 |  |
| 276 | 3.3.5 | **Laser Safety Systems** | 20d? | 2007-10-08 | 2007-11-02 |  | 2007-10-08 | 2007-11-02 | 20d? | 34.99d |  |  |  | 40h | 2,292.4 | 2,292.4 |  |
| 277 | 3.3.5.1 | Personnel and Equipment Safety Systems | 20d? | 2007-10-08 | 2007-11-02 |  | 2007-10-08 | 2007-11-02 | 20d? | 34.99d |  | start no earlier than 2007-10-08 | Chin [12.5%] | 20h | 1,146.2 | 1,146.2 |  |
| 278 | 3.3.5.2 | Aircraft, Satellite & Laser Traffic Control Safety Systems | 20d? | 2007-10-08 | 2007-11-02 |  | 2007-10-08 | 2007-11-02 | 20d? | 34.99d |  | start no earlier than 2007-10-08 | Chin [12.5%] | 20h | 1,146.2 | 1,146.2 |  |
| 279 | 3.3.6 | **Laser System Control** | 55d? | 2007-10-01 | 2007-12-14 |  | 2007-10-01 | 2007-12-14 | 55d? | 4.99d |  |  |  | 150h | 8,596.5 | 8,596.5 |  |
| 280 | 3.3.6.1 | Laser System Software | 55d? | 2007-10-01 | 2007-12-14 |  | 2007-10-01 | 2007-12-14 | 55d? | 4.99d |  | finish no earlier than 2007-12-14 | Johansson [9.1%]; Stomski [9.1%] | 80h | 4,584.8 | 4,584.8 |  |
| 281 | 3.3.6.2 | Laser System Electronics | 55d? | 2007-10-01 | 2007-12-14 |  | 2007-10-01 | 2007-12-14 | 55d? | 4.99d |  | finish no earlier than 2007-12-14 | Chin [15.9%] | 70h | 4,011.7 | 4,011.7 |  |
| 282 | 3.4 | **Science Operations** | 174d? | 2007-05-22 | 2008-01-17 |  | 2007-01-02 | 2007-12-14 | 249d? | 13.14d | 10d |  |  | 790h | 40,617.9 | 32,477.5 |  |
| 283 | 3.4.1 | **Astronomical Observations Operations** | 170d? | 2007-05-28 | 2008-01-17 |  | 2007-03-01 | 2007-12-14 | 207d? | 13.14d |  |  |  | 340h | 16,194.6 | 8,054.2 |  |
| 284 | 3.4.1.1 | **Pre-Observing Interfaces** | 22d? | 2007-07-26 | 2007-08-24 |  | 2007-05-01 | 2007-05-30 | 22d? | 118.14d |  |  |  | 60h | 2,072.4 | 2,072.4 |  |
| 285 | 3.4.1.1.1 | AO Guide Star Interface | 22d? | 2007-07-26 | 2007-08-24 |  | 2007-05-01 | 2007-05-30 | 22d? | 118.14d |  | start no earlier than 2007-07-26 | McGraw [11.4%] | 20h | 690.8 | 690.8 | assigned |
| 286 | 3.4.1.1.2 | Science Observations Simulation Tools | 22d? | 2007-07-26 | 2007-08-24 |  | 2007-05-01 | 2007-05-30 | 22d? | 118.14d |  | start no earlier than 2007-07-26 | McGraw [22.7%] | 40h | 1,381.6 | 1,381.6 | assigned |

Notes:
- 261: EJ
- 262: EJ
- 263: EJ
- 264: DG
- 265: DG
- 266: EJ
- 267: MR
- 269: VV
- 270: JM
- 271: DG
- 272: VV
- 273: CN
- 274: VV
- 275: VV
- 276: JC
- 277: JC
- 278: JC
- 279: JC
- 280: EJ
- 281: JC
- 282: DLM
- 283: DLM
- 284: DLM
- 285: EM
- 286: EM

| ID | WBS | Task | Duration | Start | Finish | Baseline start | Baseline finish | Baseline duration | Total slack | Constraint | Resources | Work | Cost | Baseline cost | Text1 |
| --- | --- | --- | --- | --- | --- | --- | --- | --- | --- | --- | --- | --- | --- | --- | --- |
| 287 | 3.4.1.2 | **Observing Interfaces** | 146d? | 2007-05-28 | 2007-12-14 | 2007-03-01 | 2007-12-14 | 207d? | 37.14d |  |  | 80h | 3,218.6 | 3,218.6 |  |
| 288 | 3.4.1.2.1 | Acquisition | 43d? | 2007-05-28 | 2007-07-25 | 2007-03-01 | 2007-04-30 | 43d? | 140.14d | finish no earlier than 2007-07-25 | McGraw [5.8%] | 20h | 690.8 | 690.8 | assigned |
| 289 | 3.4.1.2.2 | Observing Sequences | 43d? | 2007-05-28 | 2007-07-25 | 2007-03-01 | 2007-04-30 | 43d? | 140.14d | start no earlier than 2007-05-28 | McGraw [5.8%] | 20h | 690.8 | 690.8 | assigned |
| 290 | 3.4.1.2.3 | Instrument, AO & Telescope Observer Interfaces | 43d? | 2007-05-28 | 2007-07-25 | 2007-03-01 | 2007-04-30 | 43d? | 140.14d | start no earlier than 2007-05-28 | Johansson [5.8%] | 20h | 1,146.2 | 1,146.2 | assigned |
| 291 | 3.4.1.2.4 | Science Data Quality Monitoring | 43d? | 2007-10-17 | 2007-12-14 | 2007-10-17 | 2007-12-14 | 43d? | 37.14d | finish no earlier than 2007-12-14 | McGraw [5.8%] | 20h | 690.8 | 690.8 | assigned |
| 292 | 3.4.1.3 | **Post-Observing Interfaces** | 100d? | 2007-09-03 | 2008-01-17 | 2007-10-01 | 2007-11-27 | 42d? | 13.14d |  |  | 200h | 10,903.6 | 2,763.2 |  |
| 293 | 3.4.1.3.1 | Generic Data Products | 42d? | 2007-10-01 | 2007-11-27 | 2007-10-01 | 2007-11-27 | 42d? | 50.14d | start no earlier than 2007-10-01 | McGraw [6%] | 20h | 690.8 | 690.8 | assigned |
| 294 | 3.4.1.3.2 | Science Data Quality Assessment | 42d? | 2007-10-01 | 2007-11-27 | 2007-10-01 | 2007-11-27 | 42d? | 50.14d | start no earlier than 2007-10-01 | McGraw [6%] | 20h | 690.8 | 690.8 | assigned |
| 295 | 3.4.1.3.3 | Science Data Archiving | 42d? | 2007-10-01 | 2007-11-27 | 2007-10-01 | 2007-11-27 | 42d? | 50.14d | start no earlier than 2007-10-01 | McGraw [11.9%] | 40h | 1,381.6 | 1,381.6 | assigned |
| 296 | 3.4.1.3.4 | PSF Reconstruction | 100d? | 2007-09-03 | 2008-01-17 |  |  |  | 13.14d | start no earlier than 2007-09-03 | Le Mignant [10%]; Britton | 120h | 8,140.4 |  |  |
| 297 | 3.4.2 | **AO-Instrument Operations** | 115d? | 2007-05-22 | 2007-10-26 | 2007-01-02 | 2007-10-26 | 214d? | 72.14d |  |  | 450h | 24,423.3 | 24,423.3 |  |
| 298 | 3.4.2.1 | **AO-Instrument Operations Architecture** | 115d? | 2007-05-22 | 2007-10-26 | 2007-01-02 | 2007-10-26 | 214d? | 72.14d |  |  | 270h | 14,107.5 | 14,107.5 |  |
| 299 | 3.4.2.1.1 | AO-Instrument Observing Modes | 24d? | 2007-05-22 | 2007-06-22 | 2007-01-02 | 2007-02-02 | 24d? | 163.14d | start no earlier than 2007-05-22 | Le Mignant [20.8%]; McGraw [20.8%] | 80h | 3,674 | 3,674 | assigned |
| 300 | 3.4.2.1.2 | AO-Instrument Operations Support | 15d? | 2007-06-25 | 2007-07-13 | 2007-02-05 | 2007-05-30 | 83d? | 148.14d | finish no earlier than 2007-07-13 | Le Mignant [16.7%] | 20h | 1,146.2 | 1,146.2 | assigned |
| 301 | 3.4.2.1.3 | AO-Instrument Configuration & Setup | 83d? | 2007-07-05 | 2007-10-26 | 2007-07-04 | 2007-10-26 | 83d? | 72.14d | finish no earlier than 2007-10-26 | Le Mignant [3%] | 20h | 1,146.2 | 1,146.2 | assigned |
| 302 | 3.4.2.1.4 | AO-Instrument Calibrations | 83d? | 2007-06-04 | 2007-09-25 | 2007-06-04 | 2007-09-26 | 83d? | 95.14d | start no earlier than 2007-06-04 | van Dam [3%] | 20h | 1,146.2 | 1,146.2 | assigned |
| 303 | 3.4.2.1.5 | AO-Instrument Nighttime Operation Modes | 83d? | 2007-06-04 | 2007-09-25 | 2007-06-04 | 2007-09-26 | 83d? | 95.14d | start no earlier than 2007-06-04 | Le Mignant [3%] | 20h | 1,146.2 | 1,146.2 | assigned |
| 304 | 3.4.2.1.6 | AO-Instrument Science Acquisition & Control | 83d? | 2007-07-02 | 2007-10-23 | 2007-07-02 | 2007-10-24 | 83d? | 75.14d | start no earlier than 2007-07-02 | McGraw [3%] | 20h | 690.8 | 690.8 | assigned |
| 305 | 3.4.2.1.7 | AO-Instrument Health Monitoring & Automated Recovery | 83d? | 2007-06-11 | 2007-10-02 | 2007-06-11 | 2007-10-03 | 83d? | 90.14d | start no earlier than 2007-06-11 | Johansson [3%] | 20h | 1,146.2 | 1,146.2 | assigned |
| 306 | 3.4.2.1.8 | AO-Instrument Laser Traffic Control | 20d? | 2007-10-01 | 2007-10-26 | 2007-10-01 | 2007-10-26 | 20d? | 72.14d | start no earlier than 2007-10-01 | Summers [6.2%] | 10h | 573.1 | 573.1 |  |
| 307 | 3.4.2.1.9 | AO-Instrument User Interfaces | 20d? | 2007-10-01 | 2007-10-26 | 2007-10-01 | 2007-10-26 | 20d? | 72.14d | start no earlier than 2007-10-01 | Johansson [25%] | 40h | 2,292.4 | 2,292.4 | assigned |
| 308 | 3.4.2.1.10 | AO-Instrument Maintenance Plan | 20d? | 2007-10-01 | 2007-10-26 | 2007-10-01 | 2007-10-26 | 20d? | 72.14d | start no earlier than 2007-10-01 | Johansson [12.5%] | 20h | 1,146.2 | 1,146.2 | assigned |
| 309 | 3.4.2.2 | **AO-Instrument Operations Optimization** | 30d? | 2007-06-18 | 2007-07-27 | 2007-03-05 | 2007-05-04 | 45d? | 138.14d |  |  | 180h | 10,315.8 | 10,315.8 |  |
| 310 | 3.4.2.2.1 | AO-Instrument Performance Prediction | 30d? | 2007-06-18 | 2007-07-27 | 2007-03-05 | 2007-04-13 | 30d? | 138.14d | start no earlier than 2007-06-18 | Flicker [25%]; van Dam [8.3%] | 80h | 4,584.8 | 4,584.8 | assigned |
| 311 | 3.4.2.2.2 | AO-Instrument Real-Time Optimization | 30d? | 2007-06-18 | 2007-07-27 | 2007-03-05 | 2007-04-13 | 30d? | 138.14d | start no earlier than 2007-06-18 | Flicker [25%]; van Dam [8.3%] | 80h | 4,584.8 | 4,584.8 | assigned |
| 312 | 3.4.2.2.3 | AO-Instrument Environment Monitoring | 15d? | 2007-06-18 | 2007-07-06 | 2007-04-16 | 2007-05-04 | 15d? | 153.14d | start no earlier than 2007-06-18 | Johansson [16.7%] | 20h | 1,146.2 | 1,146.2 | assigned |

Notes:
- 287: DLM
- 288: EM
- 289: EM
- 290: EJ
- 291: EM
- 292: DLM
- 293: EM
- 294: EM
- 295: EM
- 296: DLM
- 297: DLM
- 298: DLM
- 299: DLM
- 300: DLM
- 301: DLM
- 302: MvD
- 303: DLM
- 304: EM
- 305: EJ
- 306: DS
- 307: EJ
- 308: EJ
- 309: DLM
- 310: MvD
- 311: MvD
- 312: EJ

| ID | WBS | Task | Duration | Start | Finish | Predecessors | Complete | Remaining | Baseline start | Baseline finish | Baseline duration | Total slack | Free slack | Constraint | Resources | Work | Actual work | Cost | Baseline cost | Actual cost |
| --- | --- | --- | --- | --- | --- | --- | --- | --- | --- | --- | --- | --- | --- | --- | --- | --- | --- | --- | --- | --- |
| 313 | 3.5 | **Science Instruments** | 386d? | 2006-10-02 A | 2008-03-21 |  | 2% | 377.2d? | 2006-10-02 | 2007-11-16 | 295d? | 17.33d |  |  |  | 865h | 10.98h | 56,615.49 | 93,446.34 | 629.53 |
| 314 | 3.5.1 | **Instrument Requirements & Initial Definitions** | 211d? | 2007-04-09 | 2008-01-25 |  |  |  |  |  |  | 57.33d |  |  |  | 132h |  | 7,564.92 |  |  |
| 315 | 3.5.1.1 | Top Level Instrument Requirements & Definitions | 20d? | 2007-04-09 | 2007-05-04 |  |  |  |  |  |  | 131.33d | 0d | finish no earlier than 2007-05-04 | Adkins [10%] | 16h |  | 916.96 |  |  |
| 316 | 3.5.1.2 | **Instrument Suite Version 1** | 13.5d? | 2007-05-07 | 2007-05-24 |  |  |  |  |  |  | 179.14d |  |  |  | 13h |  | 745.03 |  |  |
| 317 | 3.5.1.2.1 | Instrument Function Allocation Review with Science Team | 1d? | 2007-05-07 | 2007-05-07 | 315 |  |  |  |  |  | 179.14d | 0d | finish no earlier than 2007-05-07 | Adkins [37.5%] | 3h |  | 171.93 |  |  |
| 318 | 3.5.1.2.2 | Summary Descriptions of Instruments | 12.5d? | 2007-05-08 | 2007-05-24 | 317 |  |  |  |  |  | 234.83d |  | start no earlier than 2007-05-08 | Adkins [10%] | 10h |  | 573.1 |  |  |
| 319 | 3.5.1.3 | **Instrument Suite Version 2** | 12d? | 2008-01-10 | 2008-01-25 |  |  |  |  |  |  | 13.39d |  |  |  | 23h |  | 1,318.13 |  |  |
| 320 | 3.5.1.3.1 | Instrument Review with Science Team | 2d? | 2008-01-10 | 2008-01-11 |  |  |  |  |  |  | 13.39d | 0d | start no earlier than 2008-01-10 | Adkins [18.8%] | 3h |  | 171.93 |  |  |
| 321 | 3.5.1.3.2 | Revised Summary Descriptions of Instruments | 10d? | 2008-01-14 | 2008-01-25 | 320 |  |  |  |  |  | 57.33d |  | finish no earlier than 2008-01-25 | Adkins [25%] | 20h |  | 1,146.2 |  |  |
| 322 | 3.5.1.4 | **Instrument Interfaces** | 18d? | 2007-06-06 | 2007-06-29 |  |  |  |  |  |  | 208.33d |  |  |  | 80h |  | 4,584.8 |  |  |
| 323 | 3.5.1.4.1 | Hardware Instrument Interfaces | 13d? | 2007-06-06 | 2007-06-22 |  |  |  |  |  |  | 213.33d |  | start no earlier than 2007-06-06 | Adkins [19.2%]; Meguro | 40h |  | 2,292.4 |  |  |
| 324 | 3.5.1.4.2 | Software Instrument Interfaces | 14d? | 2007-06-12 | 2007-06-29 |  |  |  |  |  |  | 208.33d |  | start no earlier than 2007-06-12 | Adkins [17.9%]; Johansson | 40h |  | 2,292.4 |  |  |
| 325 | 3.5.2 | **Deployable NIR IFU (DNIRI)** | 221d? | 2007-05-07 | 2008-03-07 |  |  |  | 2007-02-01 | 2007-06-27 | 105d? | 27.33d |  |  |  | 278h |  | 20,890.24 | 33,076.2 |  |
| 326 | 3.5.2.1 | DNIRI Concept Development | 30d? | 2007-05-07 | 2007-06-15 |  |  |  |  |  |  | 101.14d | 0d | start no earlier than 2007-05-07 | Adkins [4.2%]; Mechanical Engineer 1; Optical Engineer 1 | 50h |  | 4,128.7 |  |  |
| 327 | 3.5.2.2 | **DNIRI AO Interface Issues** | 12d? | 2007-06-18 | 2007-07-03 |  |  |  |  |  |  | 101.14d |  |  |  | 40h |  | 3,271.38 |  |  |
| 328 | 3.5.2.2.1 | Object Selection for DNIRI | 10d? | 2007-06-18 | 2007-06-29 | 326 |  |  |  |  |  | 101.14d | 0d | finish no earlier than 2007-06-29 | Adkins [10%]; Mechanical Engineer 1; Optical Engineer 1; Moore | 32h |  | 2,591.84 |  |  |
| 329 | 3.5.2.2.2 | AO Design for DNIRI | 1d? | 2007-07-02 | 2007-07-02 | 328 |  |  |  |  |  | 101.14d | 0d | finish no earlier than 2007-07-02 | Moore [50%] | 4h |  | 355.56 |  |  |
| 330 | 3.5.2.2.3 | DNIRI AO Boundary | 1d? | 2007-07-03 | 2007-07-03 | 329 |  |  |  |  |  | 101.14d | 0d | finish no earlier than 2007-07-03 | Adkins [12.5%]; Mechanical Engineer 1; Optical Engineer 1; Moore | 4h |  | 323.98 |  |  |
| 331 | 3.5.2.3 | DNIRI Spectrograph Concepts | 25d? | 2007-07-04 | 2007-08-07 | 330 |  |  |  |  |  | 101.14d | 0d | finish no earlier than 2007-08-06 | Adkins [10%]; Mechanical Engineer 1; Optical Engineer 1 | 60h |  | 4,701.8 |  |  |
| 332 | 3.5.2.4 | DNIRI Imager Concepts | 25d? | 2007-07-04 | 2007-08-07 | 330 |  |  |  |  |  | 101.14d | 0d | finish no earlier than 2007-08-06 | Adkins [10%]; Mechanical Engineer 1; Optical Engineer 1 | 60h |  | 4,701.8 |  |  |
| 333 | 3.5.2.5 | DNIRI Concept Review with AO Team | 1d? | 2007-08-08 | 2007-08-08 | 331, 332 |  |  |  |  |  | 101.14d | 1d | finish no earlier than 2007-08-08 | Adkins [25%]; Mechanical Engineer 1; Optical Engineer 1; Moore | 8h |  | 647.96 |  |  |
| 334 | 3.5.2.6 | DNIRI Report ver 1 | 29d? | 2007-08-10 | 2007-09-18 | 333 |  |  |  |  |  | 100.14d | 97d | finish no earlier than 2007-09-18 | Adkins [17.2%] | 40h |  | 2,292.4 |  |  |
| 335 | 3.5.2.7 | DNIRI Report ver 2 | 31d? | 2008-01-25 | 2008-03-07 |  |  |  |  |  |  | 27.33d |  | start no earlier than 2008-01-25 | Adkins [8.1%] | 20h |  | 1,146.2 |  |  |
| 336 | 3.5.3 | **Single Object Imagers/Low Resolution Spectrographs (SOI/LRS)** | 222d? | 2007-05-07 | 2008-03-10 |  |  |  |  |  |  | 26.33d |  |  |  | 139h |  | 8,471.37 |  |  |
| 337 | 3.5.3.1 | SOI/LRS Coronagraph Requirements | 20d? | 2007-05-07 | 2007-06-01 | 315 |  |  |  |  |  | 131.33d | 0d | finish no earlier than 2007-06-01 | Adkins [12.5%] | 20h |  | 1,146.2 |  |  |
| 338 | 3.5.3.2 | SOI/LRS Spectrograph Requirements | 10d? | 2007-06-04 | 2007-06-15 | 337 |  |  |  |  |  | 131.33d | 0d | start no earlier than 2007-06-04 | Adkins [6.2%] | 5h |  | 286.55 |  |  |
| 339 | 3.5.3.3 | SOI/LRS Concept Development | 10d? | 2007-06-18 | 2007-06-29 | 338, 337 |  |  |  |  |  | 131.33d | 0d | finish no earlier than 2007-06-29 | Adkins [10%]; Mechanical Engineer 2; Optical Engineer 2 | 24h |  | 1,880.72 |  |  |

Notes:
- 313: SA
- 314: SA
- 315: SA
- 316: SA
- 317: SA
- 318: SA
- 319: SA
- 320: SA
- 321: SA
- 322: SA
- 323: SA
- 324: SA
- 325: SA
- 326: SA
- 327: SA
- 328: SA
- 329: SA
- 330: SA
- 331: SA
- 332: SA
- 333: SA
- 334: SA
- 335: SA
- 336: SA
- 337: SA
- 338: SA
- 339: SA

| ID | WBS | Task | Duration | Start | Finish | Predecessors | Complete | Remaining | Baseline start | Baseline finish | Baseline duration | Total slack | Free slack | Constraint | Resources | Work | Actual work | Cost | Baseline cost | Actual cost |
| --- | --- | --- | --- | --- | --- | --- | --- | --- | --- | --- | --- | --- | --- | --- | --- | --- | --- | --- | --- | --- |
| 340 | 3.5.3.4 | **SOI/LRS Concept Review** | 2d? | 2007-07-02 | 2007-07-03 |  |  |  |  |  |  | 131.33d |  |  |  | 6h |  | 343.86 |  |  |
| 341 | 3.5.3.4.1 | SOI/LRS Concept Review with Science Team | 1d? | 2007-07-02 | 2007-07-02 | 339 |  |  |  |  |  | 131.33d | 0d | finish no earlier than 2007-07-02 | Adkins [37.5%] | 3h |  | 171.93 |  |  |
| 342 | 3.5.3.4.2 | SOI/LRS Concept Review with AO Team | 1d? | 2007-07-03 | 2007-07-03 | 341, 339 |  |  |  |  |  | 131.33d | 1d | finish no earlier than 2007-07-03 | Adkins [37.5%] | 3h |  | 171.93 |  |  |
| 343 | 3.5.3.5 | **SOI/LRS Reports** | 179d? | 2007-07-05 | 2008-03-10 |  |  |  |  |  |  | 26.33d |  |  |  | 84h |  | 4,814.04 |  |  |
| 344 | 3.5.3.5.1 | SOI/LRS Near-IR ver 1 | 75d? | 2007-07-05 | 2007-10-16 | 342 |  |  |  |  |  | 130.33d |  | start no earlier than 2007-07-05 | Adkins [5%] | 30h |  | 1,719.3 |  |  |
| 345 | 3.5.3.5.2 | SOI/LRS Visibile ver 1 | 75d? | 2007-07-06 | 2007-10-17 | 342 |  |  |  |  |  | 129.33d |  | finish no earlier than 2007-10-17 | Adkins [5%] | 30h |  | 1,719.3 |  |  |
| 346 | 3.5.3.5.3 | SOI/LRS Near-IR ver 2 | 16d? | 2008-01-25 | 2008-02-15 |  |  |  |  |  |  | 26.33d | 0d | start no earlier than 2008-01-25 | Adkins [9.4%] | 12h |  | 687.72 |  |  |
| 347 | 3.5.3.5.4 | SOI/LRS Visible ver 2 | 16d? | 2008-02-18 | 2008-03-10 | 346 |  |  |  |  |  | 26.33d |  | finish no earlier than 2008-03-10 | Adkins [9.4%] | 12h |  | 687.72 |  |  |
| 348 | 3.5.4 | **Single Object IFUs (SOIFU)** | 221d? | 2007-04-30 | 2008-02-29 |  |  |  |  |  |  | 32.33d |  |  |  | 134h |  | 8,626.94 |  |  |
| 349 | 3.5.4.1 | Near-IR IFU Requirements Review | 10d? | 2007-04-30 | 2007-05-11 |  |  |  |  |  |  | 211.33d | 144d | start no earlier than 2007-04-30 | Adkins [6.2%] | 5h |  | 286.55 |  |  |
| 350 | 3.5.4.2 | Visible IFU Requirements Review | 21d? | 2007-09-18 | 2007-10-16 |  |  |  |  |  |  | 67.33d | 0d | start no earlier than 2007-09-18 | Adkins [4.8%] | 8h |  | 458.48 |  |  |
| 351 | 3.5.4.3 | Visible IFU Concept Development | 31d? | 2007-10-17 | 2007-11-28 | 350 |  |  |  |  |  | 67.33d | 0d | finish no earlier than 2007-11-28 | Adkins [6%]; Mechanical Engineer 3; Optical Engineer 3 | 45h |  | 3,526.35 |  |  |
| 352 | 3.5.4.4 | **SOIFU Concept Review** | 2d? | 2007-11-29 | 2007-11-30 |  |  |  |  |  |  | 67.33d |  |  |  | 6h |  | 343.86 |  |  |
| 353 | 3.5.4.4.1 | SOIFU Concept Review with Science Team | 1d? | 2007-11-29 | 2007-11-29 | 349, 351 |  |  |  |  |  | 67.33d | 0d | finish no earlier than 2007-11-29 | Adkins [37.5%] | 3h |  | 171.93 |  |  |
| 354 | 3.5.4.4.2 | SOIFU Concept Review with AO Team | 1d? | 2007-11-30 | 2007-11-30 | 353 |  |  |  |  |  | 67.33d | 0d | finish no earlier than 2007-11-30 | Adkins [37.5%] | 3h |  | 171.93 |  |  |
| 355 | 3.5.4.5 | **Single Object IFU Reports** | 65d? | 2007-12-03 | 2008-02-29 |  |  |  |  |  |  | 32.33d |  |  |  | 70h |  | 4,011.7 |  |  |
| 356 | 3.5.4.5.1 | SOIFU Near-IR ver 1 | 10d? | 2007-12-03 | 2007-12-14 | 354 |  |  |  |  |  | 67.33d | 0d | finish no earlier than 2007-12-14 | Adkins [15%] | 12h |  | 687.72 |  |  |
| 357 | 3.5.4.5.2 | SOIFU Visible ver 1 | 20d? | 2007-12-17 | 2008-01-11 | 356 |  |  |  |  |  | 67.33d |  | finish no earlier than 2008-01-11 | Adkins [18.8%] | 30h |  | 1,719.3 |  |  |
| 358 | 3.5.4.5.3 | SOIFU Near-IR ver 2 | 10d? | 2008-01-28 | 2008-02-08 |  |  |  |  |  |  | 47.33d |  | finish no earlier than 2008-02-08 | Adkins [10%] | 8h |  | 458.48 |  |  |
| 359 | 3.5.4.5.4 | SOIFU Visible ver 2 | 10d? | 2008-02-18 | 2008-02-29 |  |  |  |  |  |  | 32.33d |  | start no earlier than 2008-02-18 | Adkins [25%] | 20h |  | 1,146.2 |  |  |
| 360 | 3.5.5 | **Special Purpose High Contrast Instrument (HCI)** | 52d? | 2008-01-10 | 2008-03-21 |  |  |  |  |  |  | 17.33d |  |  |  | 61h |  | 4,127.51 |  |  |
| 361 | 3.5.5.1 | HCI Requirements Development | 31d? | 2008-01-10 | 2008-02-21 |  |  |  |  |  |  | 17.33d | 0d | start no earlier than 2008-01-10 | Adkins [5.2%] | 13h |  | 745.03 |  |  |
| 362 | 3.5.5.2 | HCI Concept Development | 20d? | 2008-02-22 | 2008-03-20 | 361 |  |  |  |  |  | 17.33d | 0d | finish no earlier than 2008-03-20 | Adkins [12.5%]; Mechanical Engineer 2; Optical Engineer 2 | 40h |  | 2,924 |  |  |
| 363 | 3.5.5.3 | HCI Concept & Need Review with Science Team | 1d? | 2008-03-21 | 2008-03-21 | 362 |  |  |  |  |  | 17.33d |  | finish no earlier than 2008-03-21 | Adkins | 8h |  | 458.48 |  |  |
| 364 | 3.5.6 | Interferometer | 68d | 2006-10-02 A | 2007-10-31 | 220 | 25% | 51d | 2006-10-02 | 2007-03-30 | 130d? | 119.47d |  | finish no earlier than 2007-10-30 | Neyman [10.2%]; Other [7.3%]; Wizinowich [2.5%] | 80h | 10.98h | 4,584.8 | 5,731 | 629.53 |
| 365 | 3.5.7 | OHANA | 50d? | 2007-08-22 | 2007-10-30 | 220 |  |  | 2007-02-01 | 2007-04-11 | 50d? | 120.47d |  | finish no earlier than 2007-04-11 | Neyman [2.5%]; Woillez [7.5%] | 40h |  | 2,292.4 | 2,292.4 |  |
| 366 | 3.5.8 | Thermal Near-IR Imager | 11.88d? | 2007-07-09 | 2007-07-24 |  |  |  | 2007-07-09 | 2007-11-16 | 95d? | 191.45d |  | start no earlier than 2007-07-09 | Adkins [1.1%]; Moore [5.5%] | 1h |  | 57.31 | 4,191.86 |  |

Notes:
- 340: SA
- 341: SA
- 342: SA
- 343: SA
- 344: SA
- 345: SA
- 346: SA
- 347: SA
- 348: SA
- 349: SA
- 350: SA
- 351: SA
- 352: SA
- 353: SA
- 354: SA
- 355: SA
- 356: SA
- 357: SA
- 358: SA
- 359: SA
- 360: SA
- 361: SA
- 362: SA
- 363: SA
- 364: CN
- 365: CN
- 366: Cancel

| ID | WBS | Task | Duration | Start | Finish | Predecessors | Complete | Remaining | Baseline start | Baseline finish | Baseline duration | Total slack | Free slack | Constraint | Resources | Work | Actual work | Cost | Baseline cost | Actual cost | Text1 |
| --- | --- | --- | --- | --- | --- | --- | --- | --- | --- | --- | --- | --- | --- | --- | --- | --- | --- | --- | --- | --- | --- |
| 367 | 3.6 | **System Design Manual (SDM)** | 126.33d? | 2007-08-22 | 2008-02-14 |  |  |  | 2008-01-01 | 2008-01-18 | 12.5d? | 3.14d |  |  |  | 80h |  | 6,290.2 | 6,290.2 |  |  |
| 368 | 3.6.1 | SDM v1 | 5.51d? | 2007-08-22 | 2007-08-30 | 220 |  |  |  |  |  | 123.96d |  |  | Wizinowich [34%]; Dekany | 25h |  | 1,748.55 |  |  |  |
| 369 | 3.6.2 | SDM v2 | 9.19d? | 2008-02-01 | 2008-02-14 | 164, 223, 235, 236, 268, 282, 334 |  |  |  |  |  | 3.14d |  |  | Wizinowich [34%]; Dekany; Gavel | 55h |  | 4,541.65 |  |  |  |
| 370 | 4 | **Systems Engineering Management Plan (SEMP)** | 252.33d? | 2007-03-05 A | 2008-02-19 |  | 4% | 243.35d? | 2007-03-05 | 2008-02-20 | 252.33d? | 0d |  |  |  | 1140h | 15.25h | 78,680.85 | 83,733.3 | 1,089.82 |  |
| 371 | 4.1 | **Project Plan** | 60.57d? | 2007-09-25 | 2007-12-19 |  |  |  | 2007-09-26 | 2007-12-20 | 60.57d? | 0d |  |  |  | 480h |  | 36,025.05 | 41,077.5 |  |  |
| 372 | 4.1.1 | WBS and Task Definition | 21.43d? | 2007-09-25 | 2007-10-24 | 22FS+55d |  |  | 2007-09-26 | 2007-10-25 | 21.43d? | 0d |  |  | Wizinowich [35%]; Dekany [35%]; Gavel [35%]; Max [35%] | 200h |  | 15,432 | 15,432 |  | moved earlier |
| 373 | 4.1.2 | Cost Estimation | 25.57d? | 2007-10-24 | 2007-11-29 | 372 |  |  | 2007-10-25 | 2007-11-30 | 25.57d? | 5.69d | 0d |  | Wizinowich [4.9%]; Dekany [14.7%]; Gavel [14.7%]; Bauman [14.7%]; Meguro [9.8%]; Johansson [9.8%]; Chin [9.8%]; Velur [14.7%]; Adkins [9.8%]; Le Mignant [4.9%] | 160h |  | 11,951.95 | 17,004.4 |  | assignment |
| 374 | 4.1.3 | Major Project Milestones | 6.57d? | 2007-10-24 | 2007-11-02 | 372 |  |  | 2007-10-25 | 2007-11-05 | 6.57d? | 63.83d |  |  | Wizinowich [19%]; Dekany [38%] | 30h |  | 2,350.9 | 2,350.9 |  |  |
| 375 | 4.1.4 | Develop Full Schedule (MS Project Plan) | 13.57d? | 2007-11-29 | 2007-12-19 | 373 |  |  | 2007-11-30 | 2007-12-20 | 13.57d? | 5.69d | 0d |  | Wizinowich [36.8%]; Dekany [18.4%]; Gavel [18.4%]; Max [9.2%] | 90h |  | 6,290.2 | 6,290.2 |  | end date |
| 376 | 4.2 | Risk Assessment & Management Plan | 34d? | 2007-09-25 | 2007-11-12 | 372SS |  |  | 2007-09-26 | 2007-11-13 | 34d? | 57.83d |  |  | Wizinowich [3.7%]; Dekany [5.5%]; Gavel [5.5%] | 40h |  | 3,571.45 | 3,571.45 |  | lead; people |
| 377 | 4.3 | **Preliminary Design Phase Plan** | 233.64d? | 2007-03-05 A | 2008-01-23 |  | 15% | 197.68d? | 2007-03-05 | 2008-01-24 | 233.64d? | 5.69d |  |  |  | 200h | 15.25h | 14,007.59 | 14,007.59 | 1,089.82 |  |
| 378 | 4.3.1 | Preliminary Design Phase Plan Version 1 (to Support Observatory FY08 Planning) | 55d? | 2007-03-05 A | 2007-05-18 |  | 25% | 41.25d? | 2007-03-05 | 2007-03-30 | 20d? | 184.33d |  | finish no earlier than 2007-05-18 | Wizinowich [9.4%]; Dekany [6.2%]; Gavel [6.2%]; Max [3.1%] | 40h | 15.25h | 2,858.55 | 2,858.55 | 1,089.82 | -2hr; later |
| 379 | 4.3.2 | Preliminary Design Phase Plan Version 2 | 18.75d? | 2007-10-24 | 2007-11-20 | 372 |  |  | 2007-10-25 | 2007-11-21 | 18.75d? | 51.65d |  | start no earlier than 2007-04-09 | Wizinowich [20%]; Dekany [20%]; Gavel [20%]; Max [20%] | 80h |  | 5,717.1 | 5,717.1 |  |  |
| 380 | 4.3.3 | Preliminary Design Phase Plan Final Version | 15.57d? | 2008-01-02 | 2008-01-23 | 375FS+2w |  |  | 2008-01-03 | 2008-01-24 | 15.57d? | 5.69d |  |  | Wizinowich [26.7%]; Dekany [14.4%]; Gavel [14.4%]; Max [10%] | 80h |  | 5,431.94 | 5,431.94 |  | -4hr |
| 381 | 4.4 | **Integration and Test Plans** | 70.4d? | 2007-10-24 | 2008-01-31 |  |  |  | 2007-10-25 | 2008-02-01 | 70.4d? | 0d |  |  |  | 180h |  | 10,315.8 | 10,315.8 |  |  |
| 382 | 4.4.1 | **Subsystem Testing Plans** | 70.4d? | 2007-10-24 | 2008-01-31 |  |  |  | 2007-10-25 | 2008-02-01 | 70.4d? | 0d |  |  |  | 80h |  | 4,584.8 | 4,584.8 |  |  |
| 383 | 4.4.1.1 | AO System Test Plan | 17.6d? | 2007-10-24 | 2007-11-19 | 372 |  |  | 2007-10-25 | 2007-11-20 | 17.6d? | 0d |  |  | Neyman [14.2%] | 20h |  | 1,146.2 | 1,146.2 |  |  |
| 384 | 4.4.1.2 | Laser System Test Plan | 17.6d? | 2007-11-19 | 2007-12-13 | 383 |  |  | 2007-11-20 | 2007-12-14 | 17.6d? | 0d |  |  | Neyman [14.2%] | 20h |  | 1,146.2 | 1,146.2 |  |  |
| 385 | 4.4.1.3 | Science Operations Test Plan | 17.6d? | 2007-12-13 | 2008-01-07 | 384 |  |  | 2007-12-14 | 2008-01-08 | 17.6d? | 0d |  |  | Le Mignant [14.2%] | 20h |  | 1,146.2 | 1,146.2 |  |  |
| 386 | 4.4.1.4 | Science Instruments Test Plan | 17.6d? | 2008-01-07 | 2008-01-31 | 385 |  |  | 2008-01-08 | 2008-02-01 | 17.6d? | 0d |  |  | Adkins [14.2%] | 20h |  | 1,146.2 | 1,146.2 |  |  |
| 387 | 4.4.2 | System Integration & Test Plans | 30d? | 2007-10-25 | 2007-12-05 | 372 |  |  | 2007-10-25 | 2007-12-06 | 30d? | 40.33d |  | finish no earlier than 2007-12-05 | Neyman [37.5%]; Wizinowich [34%] | 100h |  | 5,731 | 5,731 |  | assignment |
| 388 | 4.5 | Configuration Management Plan | 62.5d? | 2007-10-24 | 2008-01-21 | 372 |  |  | 2007-10-25 | 2008-01-22 | 62.5d? | 7.9d |  | start no earlier than 2007-01-15 | Johnson [10%]; Randolph [10%]; Chin [5%] | 80h |  | 4,584.8 | 4,584.8 |  | assignment |
| 389 | 4.6 | Project Management Plan | 20d? | 2007-12-19 | 2008-01-16 | 375 |  |  | 2007-12-20 | 2008-01-17 | 20d? | 11.26d |  | start no earlier than 2007-02-12 | Wizinowich [12.5%]; Dekany [12.5%]; Gavel [12.5%]; Max [12.5%] | 80h |  | 5,144 | 5,144 |  |  |
| 390 | 4.7 | SEMP Document | 13d? | 2008-01-31 | 2008-02-19 | 371, 377, 382, 387, 388, 389, 376 |  |  | 2008-02-01 | 2008-02-20 | 13d? | 0d |  |  | Wizinowich [30.8%]; Dekany [15.4%]; Gavel [15.4%]; Max [15.4%] | 80h |  | 5,032.16 | 5,032.16 |  |  |

Notes:
- 367: PW
- 368: PW
- 369: PW
- 370: PW
- 371: PW
- 372: PW
- 373: PW
- 374: PW
- 375: PW
- 376: DG
- 377: PW
- 378: PW
- 379: PW
- 380: PW
- 381: CN
- 382: CN
- 383: CN
- 384: CN
- 385: DLM
- 386: SA
- 387: CN
- 388: JJ
- 389: PW
- 390: PW
