# NGAO System Design Phase Schedule

Schedule from MS Project, 2006-06-21 to 2008-04-30, costs in $, A marks actual dates.
CARA

## Calendars

- Standard: Mon-Fri 08:00-12:00, 13:00-17:00; Sat-Sun off. Exceptions (off unless hours are given): 2007-09-15 08:00-12:00, 13:00-17:00.

## Resources

| Resource | Group | Rate | Notes |
| --- | --- | --- | --- |
| Flicker | WMKO | 57.31 | AO Modeller |
| Gavel | UCSC | 111 | EC |
| Neyman | WMKO | 57.31 | AO |
| Dekany | COO | 88.89 | EC |
| Bouchez | COO | 88.89 | AO Scientist |
| Max | UCSC |  | EC, Science |
| Wizinowich | WMKO | 57.31 | EC |
| Britton | COO | 88.89 | AO Modeller |
| Moore | COO | 88.89 | Instrum Sci |
| Velur | COO | 88.89 | AO Scientist |
| Chin | WMKO | 57.31 | EE |
| Johansson | WMKO | 57.31 | SE, EE |
| Meguro | WMKO | 57.31 | ME |
| Stomski | WMKO | 57.31 | SE |
| Clare | WMKO | 62 | AO Modeller |
| Adkins | WMKO | 57.31 | Instruments |
| Bell | WMKO | 57.31 | ME |
| Sweeney | WMKO | 57.31 | MD |
| Kellner | WMKO | 57.31 | AO Postdoc |
| Johnson | WMKO | 57.31 | SE |
| Bauman | UCSC | 87 | OE |
| Macintosh | UCSC | 97.3 | Science |
| Le Mignant | WMKO | 57.31 | Instrum Sci |
| McGrath | UCSC | 34.54 | Science postdoc |
| Other | WMKO | 57.31 | Unassigned |
| Cameron | COO |  | Grad student |
| Randolph | WMKO | 57.31 | MD |
| Summers | WMKO | 57.31 | SE |
| Woillez | WMKO | 57.31 | KI Scientist |
| Ammons | UCSC |  | Grad student |
| Kupke | UCSC | 57.5 | AO Postdoc |
| Lockwood | UCSC | 100.6 | ME |
| Reinig | UCSC | 57.5 | EE, ECE |
| Ireland | COO |  | Postdoc |
| Student1 |  |  | Grad student |
| Student2 |  |  | Grad student |
| Adkins(IPM) | WMKO |  | IPM |
| Mechanical Engineer 1 |  | 88.89 |  |
| Optical Engineer 1 |  | 88.89 |  |
| Mechanical Engineer 2 |  | 88.89 |  |
| Optical Engineer 2 |  | 88.89 |  |
| Mechanical Engineer 3 |  | 88.89 |  |
| Optical Engineer 3 |  | 88.89 |  |
| Le Mignat |  |  |  |

## Schedule

| ID | WBS | Task | Type | Duration | Start | Finish | Predecessors | Complete | Remaining | Baseline start | Baseline finish | Baseline duration | Total slack | Constraint | Resources | Work | Actual work | Cost | Baseline cost | Actual cost | Text1 |
| --- | --- | --- | --- | --- | --- | --- | --- | --- | --- | --- | --- | --- | --- | --- | --- | --- | --- | --- | --- | --- | --- |
| 1 | 1 | **SD Phase Management** |  | 486d? | 2006-06-21 A | 2008-04-30 |  | 85% | 71.3d? | 2006-06-21 | 2008-04-17 | 476.33d? | 0d |  |  | 2108h | 1667.5h | 134,056.12 | 137,250.21 | 109,242.74 |  |
| 2 | 1.1 | **Planning and Contracting** |  | 378.33d? | 2006-06-21 A | 2007-11-30 A |  | 100% |  | 2006-06-21 | 2007-11-14 | 365.26d? |  |  |  | 230h | 230h | 13,778.35 | 13,778.35 | 13,778.35 |  |
| 3 | 1.1.1 | NGAO Proposal to SSC | milestone | 0d | 2006-06-21 A | 2006-06-21 A |  | 100% |  | 2006-06-21 | 2006-06-21 | 0d |  | start no earlier than 2006-06-21 |  |  |  |  |  |  |  |
| 4 | 1.1.2 | Management Structure Decision by Directors | milestone | 0d | 2006-07-14 A | 2006-07-14 A | 3 | 100% |  | 2006-07-14 | 2006-07-14 | 0d |  | start no earlier than 2006-07-14 |  |  |  |  |  |  |  |
| 5 | 1.1.3 | SD Phase System Engineering Management Plan |  | 21d? | 2006-09-01 A | 2006-09-29 A | 4 | 100% |  | 2006-09-01 | 2006-09-29 | 21d? |  | finish no earlier than 2006-09-29 | Max [8.9%]; Gavel [8.9%]; Dekany [8.9%]; Wizinowich [20.8%] | 80h | 80h | 5,004.2 | 5,004.2 | 5,004.2 |  |
| 6 | 1.1.4 | SD Phase Contracts Generated |  | 23d? | 2006-09-27 A | 2006-10-27 A |  | 100% |  | 2006-09-27 | 2006-10-27 | 23d? |  | start no earlier than 2006-09-27 | Adkins(IPM) [16.7%]; Gavel [8.3%]; Dekany [8.3%] | 60h | 60h | 2,998.35 | 2,998.35 | 2,998.35 |  |
| 7 | 1.1.5 | Director Approval | milestone | 0d | 2006-10-09 A | 2006-10-09 A |  | 100% |  | 2006-10-09 | 2006-10-09 | 0d |  | start no earlier than 2006-10-09 |  |  |  |  |  |  |  |
| 8 | 1.1.6 | SD Partner Contracts Issued | milestone | 0d | 2006-10-27 A | 2006-10-27 A | 6, 7 | 100% |  | 2006-10-27 | 2006-10-27 | 0d |  | start no earlier than 2006-10-13 |  |  |  |  |  |  |  |
| 9 | 1.1.7 | Mid-year Replan |  | 7d | 2007-03-19 A | 2007-03-27 A |  | 100% |  | 2007-03-05 | 2007-03-16 | 10d |  | finish no earlier than 2007-03-27 | Wizinowich [56.2%]; Dekany [25%]; Gavel [25%]; Max [18.8%] | 40h | 40h | 2,630.7 | 2,630.7 | 2,630.7 |  |
| 10 | 1.1.8 | FY08 Replan |  | 13.33d | 2007-11-13 A | 2007-11-30 A | 367 | 100% |  | 2007-10-25 | 2007-11-14 | 13.33d |  |  | Wizinowich [28.1%]; Dekany [12.5%]; Gavel [12.5%]; Max [9.4%] | 50h | 50h | 3,145.1 | 3,145.1 | 3,145.1 | have new WBS; to help align FY08 work |
| 11 | 1.2 | **Project Meetings** |  | 467d | 2006-06-21 A | 2008-04-02 |  | 90% | 45.44d | 2006-06-21 | 2008-04-03 | 467d? | 19d |  |  | 1352h | 1316h | 92,259.2 | 90,597.68 | 89,944.4 |  |
| 12 | 1.2.1 | Executive Committee Telecons |  | 467d | 2006-06-21 A | 2008-04-02 |  | 90% | 46.7d | 2006-06-21 | 2008-04-03 | 467d | 19d |  | Wizinowich [2.4%]; Dekany [2.4%]; Gavel [2.4%]; Max [2.4%] | 360h | 324h | 23,148 | 23,148 | 20,833.2 | ch end & time |
| 13 | 1.2.2 | **Team Meetings** |  | 356d | 2006-09-14 A | 2008-01-23 A |  | 100% |  | 2006-09-14 | 2008-01-09 | 344.5d |  |  |  | 992h | 992h | 69,111.2 | 67,449.68 | 69,111.2 |  |
| 14 | 1.2.2.1 | Team Meeting #1 (mgmt, science & technical - Irvine) |  | 1d | 2006-09-14 A | 2006-09-14 A |  | 100% |  | 2006-09-14 | 2006-09-14 | 1d |  | start no earlier than 2006-09-14 | Wizinowich; Dekany; Gavel; Max; Bauman; Bouchez; Velur; Flicker; Neyman; Britton; Le Mignant | 68h | 68h | 4,618.48 | 4,618.48 | 4,618.48 |  |
| 15 | 1.2.2.2 | Team Meeting #2 (CIT) |  | 1d | 2006-11-14 A | 2006-11-14 A |  | 100% |  | 2006-11-14 | 2006-11-14 | 1d |  | start no earlier than 2006-11-14 | Wizinowich; Dekany; Gavel; Max; Bauman; Bouchez; Velur; Flicker; Neyman; Britton; Le Mignant | 80h | 80h | 5,677.6 | 5,677.6 | 5,677.6 |  |
| 16 | 1.2.2.3 | Team Videocon #3 |  | 0.5d | 2006-12-13 A | 2006-12-13 A |  | 100% |  | 2006-12-13 | 2006-12-13 | 0.5d |  | start no earlier than 2006-12-13 | Wizinowich; Dekany; Gavel; Max; Bauman; Bouchez; Velur; Flicker; Neyman; Britton; Le Mignant | 44h | 44h | 3,131.2 | 3,131.2 | 3,131.2 |  |
| 17 | 1.2.2.4 | Team Meeting #4 (Keck) |  | 1d | 2007-01-22 A | 2007-01-22 A |  | 100% |  | 2007-01-22 | 2007-01-22 | 1d |  | start no earlier than 2007-01-22 | Wizinowich; Dekany; Gavel; Max; Bauman; Bouchez; Velur; Flicker; Neyman; Britton; Le Mignant | 80h | 80h | 5,677.6 | 5,677.6 | 5,677.6 |  |
| 18 | 1.2.2.5 | Team Videocon #5 |  | 0.5d | 2007-03-07 A | 2007-03-07 A |  | 100% |  | 2007-03-07 | 2007-03-07 | 0.5d |  | start no earlier than 2007-03-07 | Wizinowich; Dekany; Gavel; Max; Bauman; Bouchez; Velur; Flicker; Neyman; Britton; Le Mignant | 44h | 44h | 3,131.2 | 3,131.2 | 3,131.2 |  |
| 19 | 1.2.2.6 | Team Meeting #6 (UCSC) |  | 2d | 2007-04-25 A | 2007-04-26 A |  | 100% |  | 2007-04-18 | 2007-04-18 | 1d |  | finish no earlier than 2007-04-26 | Wizinowich [50%]; Dekany [50%]; Gavel [50%]; Max [50%]; Bauman [50%]; Bouchez; Velur [50%]; Flicker [50%]; Neyman [50%]; Britton [50%]; Le Mignant | 80h | 80h | 5,677.6 | 5,677.6 | 5,677.6 |  |
| 20 | 1.2.2.7 | Team Videocon #7 |  | 0.5d | 2007-05-30 A | 2007-05-30 A |  | 100% |  | 2007-05-30 | 2007-05-30 | 0.5d |  | finish no earlier than 2007-05-30 | Wizinowich; Dekany; Gavel; Max; Bauman; Bouchez; Velur; Flicker; Neyman; Britton; Le Mignant | 44h | 44h | 3,131.2 | 3,131.2 | 3,131.2 |  |
| 21 | 1.2.2.8 | Team Retreat #8 (UCSC) |  | 2.5d | 2007-07-09 A | 2007-07-11 A |  | 100% |  | 2007-07-09 | 2007-07-11 | 2.5d |  | start no earlier than 2007-07-09 | Wizinowich; Dekany; Gavel; Max; Bauman; Bouchez; Velur; Flicker; Neyman; Britton; Le Mignant | 220h | 220h | 15,656 | 15,656 | 15,656 |  |
| 22 | 1.2.2.9 | Team Videocon #9 |  | 0.5d | 2007-08-22 A | 2007-08-22 A |  | 100% |  | 2007-08-22 | 2007-08-22 | 0.5d |  | start no earlier than 2007-08-22 | Wizinowich; Dekany; Gavel; Max; Bauman; Bouchez; Velur; Flicker; Neyman; Britton; Le Mignant | 44h | 44h | 3,131.2 | 3,131.2 | 3,131.2 |  |
| 23 | 1.2.2.10 | Team Meeting #10 (CIT) |  | 1d | 2007-09-11 A | 2007-09-11 A |  | 100% |  | 2007-09-11 | 2007-09-11 | 1d |  | start no earlier than 2007-09-11 | Wizinowich; Dekany; Gavel; Max; Bauman; Bouchez; Velur; Flicker; Neyman; Britton; Le Mignant | 80h | 80h | 5,677.6 | 5,677.6 | 5,677.6 |  |
| 24 | 1.2.2.11 | Team Videocon #11 |  | 0.5d | 2007-11-05 A | 2007-11-05 A |  | 100% |  | 2007-11-05 | 2007-11-05 | 0.5d |  | start no earlier than 2007-11-05 | Wizinowich; Dekany; Gavel; Max; Bauman; Bouchez; Velur; Flicker; Neyman; Britton; Le Mignant | 44h | 44h | 3,131.2 | 3,131.2 | 3,131.2 |  |
| 25 | 1.2.2.12 | Team Meeting #12 |  | 1d | 2007-12-13 A | 2007-12-13 A |  | 100% |  | 2007-12-12 | 2007-12-12 | 1d |  | start no earlier than 2007-12-13 | Wizinowich; Dekany; Gavel; Max; Bauman; Bouchez; Velur; Flicker; Neyman; Britton; Le Mignant; McGrath; Johansson; Kupke; Lockwood; Reinig; Bell | 92h | 92h | 5,867.68 | 5,677.6 | 5,867.68 |  |
| 26 | 1.2.2.13 | Team Videocon #13 |  | 1d | 2008-01-23 A | 2008-01-23 A |  | 100% |  | 2008-01-09 | 2008-01-09 | 0.5d |  | start no earlier than 2008-01-23 | Wizinowich; Dekany; Gavel; Max; Adkins; Johansson; Velur; Flicker; Neyman; Britton; Le Mignant | 72h | 72h | 4,602.64 | 3,131.2 | 4,602.64 |  |

Notes:
- 1: PW
- 2: PW
- 5: PW
- 6: PW
- 8: PW
- 9: PW
- 10: PW
- 12: PW / 1 hr per week x 4 persons for duration of SD phase is about 400 wk-hours total - RD

| ID | WBS | Task | Type | Duration | Start | Finish | Predecessors | Complete | Remaining | Baseline start | Baseline finish | Baseline duration | Total slack | Free slack | Constraint | Resources | Work | Actual work | Cost | Baseline cost | Actual cost | Text1 |
| --- | --- | --- | --- | --- | --- | --- | --- | --- | --- | --- | --- | --- | --- | --- | --- | --- | --- | --- | --- | --- | --- | --- |
| 27 | 1.3 | **Tracking and Reporting** |  | 423d? | 2006-09-16 A | 2008-04-30 |  | 85% | 63.45d? | 2006-09-16 | 2008-04-03 | 404d? | 0d |  |  |  | 120h | 112.5h | 5,863.85 | 5,863.85 | 5,434.03 |  |
| 28 | 1.3.1 | Report Preparation/Presentation |  | 312.5d? | 2006-10-02 A | 2007-12-11 |  | 85% | 46.88d? | 2006-10-02 | 2007-12-12 | 312.5d? | 0d |  | start no earlier than 2006-10-02 | Wizinowich [2%]; Dekany [2%]; Gavel [2%]; Max [2%] | 120h | 112.5h | 5,863.85 | 5,863.85 | 5,434.03 |  |
| 29 | 1.3.2 | Keck Science Meeting 06 (UCI) | milestone | 0d | 2006-09-16 A | 2006-09-16 A |  | 100% |  | 2006-09-16 | 2006-09-16 | 0d |  |  | finish no earlier than 2006-09-16 |  |  |  |  |  |  |  |
| 30 | 1.3.3 | SSC meeting (UCLA) | milestone | 0d | 2006-11-06 A | 2006-11-06 A |  | 100% |  | 2006-11-06 | 2006-11-06 | 0d |  |  | start no earlier than 2006-11-06 |  |  |  |  |  |  |  |
| 31 | 1.3.4 | SSC meeting (Keck) | milestone | 0d | 2007-01-24 A | 2007-01-24 A |  | 100% |  | 2007-01-24 | 2007-01-24 | 0d |  |  | start no earlier than 2007-01-24 |  |  |  |  |  |  |  |
| 32 | 1.3.5 | SSC meeting (CA) | milestone | 0d | 2007-04-03 A | 2007-04-03 A |  | 100% |  | 2007-04-03 | 2007-04-03 | 0d |  |  | start no earlier than 2007-04-03 |  |  |  |  |  |  |  |
| 33 | 1.3.6 | SSC meeting (Keck) | milestone | 0d | 2007-06-20 A | 2007-06-20 A |  | 100% |  | 2007-06-20 | 2007-06-20 | 0d |  |  | start no earlier than 2007-06-20 |  |  |  |  |  |  |  |
| 34 | 1.3.7 | Keck Science Meeting 07 | milestone | 0d | 2007-09-15 A | 2007-09-15 A |  | 100% |  | 2007-09-22 | 2007-09-22 | 0d |  |  | start no earlier than 2007-09-15 |  |  |  |  |  |  |  |
| 35 | 1.3.8 | SSC meeting (CA) | milestone | 0d | 2007-11-06 A | 2007-11-06 A |  | 100% |  | 2007-11-06 | 2007-11-06 | 0d |  |  | start no earlier than 2007-11-06 |  |  |  |  |  |  |  |
| 36 | 1.3.9 | SSC meeting (Keck) | milestone | 0d | 2008-02-20 | 2008-02-20 |  |  |  | 2008-01-24 | 2008-01-24 | 0d | 50d |  | start no earlier than 2008-02-20 |  |  |  |  |  |  |  |
| 37 | 1.3.10 | SSC meeting (CA) | milestone | 0d | 2008-04-30 | 2008-04-30 |  |  |  | 2008-04-03 | 2008-04-03 | 0d | 0d |  | start no earlier than 2008-04-30 |  |  |  |  |  |  |  |
| 38 | 1.4 | **Proposals & Fundraising** |  | 45d? | 2006-10-27 | 2007-01-01 |  |  |  | 2006-10-27 | 2007-01-01 | 45d? | 348d |  |  |  |  |  |  |  |  |  |
| 39 | 1.4.1 | Dates & deliverables identified by Directors | milestone | 0d | 2006-10-27 | 2006-10-27 | 7FS+3w |  |  | 2006-10-27 | 2006-10-27 | 0d | 393d | 45d |  |  |  |  |  |  |  |  |
| 40 | 1.4.2 | Support Advancement Office | milestone | 0d? | 2007-01-01 | 2007-01-01 | 39 |  |  | 2007-01-01 | 2007-01-01 | 0d? | 348d |  | start no earlier than 2007-01-01 | Wizinowich [2.9%]; Max [3.8%]; Gavel [0.5%]; Dekany [0.5%] |  |  |  |  |  | lead gone |
| 41 | 1.5 | **System Design Report & Review** |  | 146d? | 2007-10-01 A | 2008-04-21 |  | 48% | 75.97d? | 2007-10-01 | 2008-04-17 | 143.33d? | 6d |  |  |  | 406h | 9h | 22,154.72 | 27,010.33 | 85.97 |  |
| 42 | 1.5.1 | System Design Report |  | 5d | 2008-03-03 | 2008-03-07 | 385, 362 |  |  | 2008-02-20 | 2008-03-03 | 8d? | 6d | 0d | finish no earlier than 2008-03-07 | Wizinowich [50%]; Gavel [12.5%]; Dekany [12.5%]; Adkins [12.5%]; Max [12.5%] | 40h |  | 2,432.2 | 2,432.2 |  |  |
| 43 | 1.5.2 | **System Design Review** |  | 146d? | 2007-10-01 A | 2008-04-21 |  | 51% | 71.64d? | 2007-10-01 | 2008-04-17 | 143.33d? | 6d |  |  |  | 366h | 9h | 19,722.52 | 24,578.13 | 85.97 |  |
| 44 | 1.5.2.1 | Identify Reviewers |  | 55d? | 2007-10-01 A | 2007-12-14 |  | 75% | 13.75d? | 2007-10-01 | 2007-12-14 | 55d? | 69d | 60d | start no earlier than 2007-10-01 | Adkins(IPM) [2.3%]; Wizinowich [0.5%] | 12h | 9h | 114.62 | 314.51 | 85.97 |  |
| 45 | 1.5.2.2 | Review Package Distributed |  | 1d | 2008-03-10 | 2008-03-10 | 42, 44 |  |  | 2008-03-03 | 2008-03-04 | 1d | 9d | 0d | start no earlier than 2008-01-14 | Adkins(IPM) | 8h |  |  |  |  |  |
| 46 | 1.5.2.3 | Reviewer Comments Addressed |  | 4d? | 2008-03-25 | 2008-03-28 | 45FS+10d |  |  | 2008-03-18 | 2008-03-25 | 5d? | 9d | 3d | finish no earlier than 2008-03-28 | Wizinowich [93.8%]; Dekany [75%]; Gavel [75%]; Max [81.2%]; Adkins(IPM) [50%] | 120h |  | 6,516.66 | 6,516.66 |  |  |
| 47 | 1.5.2.4 | System Design Review Support |  | 18d? | 2008-03-07 | 2008-04-02 | 42 |  |  | 2008-03-03 | 2008-03-31 | 20d? | 6d | 0d | finish no earlier than 2008-04-02 | Wizinowich [16.7%]; Dekany [16.7%]; Gavel [16.7%]; Max [16.7%]; Bauman [7.5%]; Bouchez [2.5%]; Velur [11.1%]; Flicker [10%]; Neyman [18.1%]; Le Mignant [11.1%]; Johansson [11.1%]; Adkins(IPM) [11.1%]; Chin [5%]; Kellner [5%]; Moore [10%] | 186h |  | 10,919.02 | 15,574.74 |  |  |
| 48 | 1.5.2.5 | System Design Review Meeting | milestone | 0d | 2008-04-02 | 2008-04-02 | 47, 46 |  |  | 2008-03-31 | 2008-03-31 | 0d | 6d | 0d | start no earlier than 2008-02-06 |  |  |  |  |  |  |  |
| 49 | 1.5.2.6 | Reviewer Report Received | milestone | 0d | 2008-04-16 | 2008-04-16 | 48FS+10d |  |  | 2008-04-14 | 2008-04-14 | 0d | 6d | 0d | start no earlier than 2008-02-15 |  |  |  |  |  |  |  |
| 50 | 1.5.2.7 | Response to Reviewer Report & Distribution |  | 3d? | 2008-04-17 | 2008-04-21 | 49 |  |  | 2008-04-14 | 2008-04-17 | 3d? | 6d |  | start no earlier than 2008-02-18 | Wizinowich [41.7%]; Dekany [33.3%]; Gavel [33.3%]; Max [41.7%]; Adkins(IPM) [16.7%] | 40h |  | 2,172.22 | 2,172.22 |  |  |

Notes:
- 27: PW
- 28: PW
- 41: SA
- 42: PW
- 43: PW
- 44: SA
- 45: SA
- 46: PW
- 47: PW
- 48: SA
- 50: PW

| ID | WBS | Task | Duration | Start | Finish | Complete | Remaining | Baseline start | Baseline finish | Baseline duration | Total slack | Constraint | Resources | Work | Actual work | Cost | Baseline cost | Actual cost |
| --- | --- | --- | --- | --- | --- | --- | --- | --- | --- | --- | --- | --- | --- | --- | --- | --- | --- | --- |
| 51 | 2 | **System Requirements** | 376d? | 2006-10-02 A | 2008-03-07 | 54% | 174.26d? | 2006-10-02 | 2007-11-02 | 285d? | 37d |  |  | 959.2h | 700.57h | 31,543.21 | 121,852.62 | 23,460.08 |
| 52 | 2.1 | **Science Requirements** | 370d? | 2006-10-02 A | 2008-02-28 | 54% | 170.01d? | 2006-10-02 | 2007-10-15 | 271d? | 43d |  |  | 705.2h | 509.57h | 16,481.19 | 96,474.8 | 12,008.6 |
| 53 | 2.1.1 | **Solar System Science Requirements** | 325d? | 2006-12-04 A | 2008-02-28 | 81% | 63.1d? | 2006-10-02 | 2007-04-06 | 135d? | 43d |  |  | 165.2h | 152.97h | 7,951.13 | 20,150 | 7,278.91 |
| 54 | 2.1.1.1 | **Multiplicity of Minor Planets (Key)** | 325d? | 2006-12-04 A | 2008-02-28 | 88% | 40.59d? | 2006-10-02 | 2007-01-12 | 75d? | 43d |  |  | 100h | 97.5h | 4,592.5 | 7,750 | 4,477.69 |
| 55 | 2.1.1.1.1 | **Minor Planets Survey Requirements** | 325d? | 2006-12-04 A | 2008-02-28 | 75% | 81.18d? |  |  |  | 43d |  |  | 50h | 47.5h | 2,296.25 |  | 2,181.44 |
| 56 | 2.1.1.1.1.1 | MP Survey Science Requirements | 325d? | 2006-12-04 A | 2008-02-28 | 75% | 81.18d? |  |  |  | 43d | finish no earlier than 2008-02-28 | McGrath [468.8%] | 12.5h | 11.88h | 431.75 |  | 410.16 |
| 57 | 2.1.1.1.1.2 | MP Survey AO Requirements | 325d? | 2006-12-04 A | 2008-02-28 | 75% | 81.18d? |  |  |  | 43d | finish no earlier than 2008-02-28 | Le Mignant [468.8%] | 12.5h | 11.88h | 716.38 |  | 680.56 |
| 58 | 2.1.1.1.1.3 | MP Survey Observing Requirements | 325d? | 2006-12-04 A | 2008-02-28 | 75% | 81.18d? |  |  |  | 43d | finish no earlier than 2008-02-28 | Le Mignant [468.8%] | 12.5h | 11.88h | 716.38 |  | 680.56 |
| 59 | 2.1.1.1.1.4 | MP Survey Instrument Requirements | 325d? | 2006-12-04 A | 2008-02-28 | 75% | 81.18d? |  |  |  | 43d | finish no earlier than 2008-02-28 | McGrath [468.8%] | 12.5h | 11.88h | 431.75 |  | 410.16 |
| 60 | 2.1.1.1.2 | **Minor Planet Orbit Determination Requirements** | 325d? | 2006-12-04 A | 2008-02-28 A | 100% |  |  |  |  |  |  |  | 50h | 50h | 2,296.25 |  | 2,296.25 |
| 61 | 2.1.1.1.2.1 | MP Orbit Science Requirements | 325d? | 2006-12-04 A | 2008-02-28 A | 100% |  |  |  |  |  | finish no earlier than 2008-02-28 | McGrath [468.8%] | 12.5h | 12.5h | 431.75 |  | 431.75 |
| 62 | 2.1.1.1.2.2 | MP Orbit AO Requirements | 325d? | 2006-12-04 A | 2008-02-28 A | 100% |  |  |  |  |  | finish no earlier than 2008-02-28 | Le Mignant [468.8%] | 12.5h | 12.5h | 716.38 |  | 716.38 |
| 63 | 2.1.1.1.2.3 | MP Orbit Observing Requirements | 325d? | 2006-12-04 A | 2008-02-28 A | 100% |  |  |  |  |  | finish no earlier than 2008-02-28 | Le Mignant [468.8%] | 12.5h | 12.5h | 716.38 |  | 716.38 |
| 64 | 2.1.1.1.2.4 | MP Orbit Instrument Requirements | 325d? | 2006-12-04 A | 2008-02-28 A | 100% |  |  |  |  |  | finish no earlier than 2008-02-28 | McGrath [468.8%] | 12.5h | 12.5h | 431.75 |  | 431.75 |
| 65 | 2.1.1.2 | **Giant Planets & Their Moons** | 325d? | 2006-12-04 A | 2008-02-28 | 80% | 65.06d? | 2006-12-04 | 2007-03-09 | 70d? | 43d |  |  | 32h | 25.59h | 1,833.92 | 4,650 | 1,466.78 |
| 66 | 2.1.1.2.1 | **Giant Planet Requirements** | 325d? | 2006-12-04 A | 2008-02-28 | 80% | 65.17d? |  |  |  | 43d |  |  | 12h | 9.59h | 687.72 |  | 549.82 |
| 67 | 2.1.1.2.1.1 | GP Science Requirements | 0.08d? | 2006-12-04 A | 2008-02-28 | 80% | 0.02d? |  |  |  | 43d | finish no earlier than 2008-02-28 | Le Mignant [468.8%] | 3h | 2.4h | 171.93 |  | 137.45 |
| 68 | 2.1.1.2.1.2 | GP AO Requirements | 0.08d? | 2006-12-04 A | 2008-02-28 | 80% | 0.02d? |  |  |  | 43d | finish no earlier than 2008-02-28 | Le Mignant [468.8%] | 3h | 2.4h | 171.93 |  | 137.45 |
| 69 | 2.1.1.2.1.3 | GP Observing Requirements | 0.08d? | 2006-12-04 A | 2008-02-28 | 80% | 0.02d? |  |  |  | 43d | finish no earlier than 2008-02-28 | Le Mignant [468.8%] | 3h | 2.4h | 171.93 |  | 137.45 |
| 70 | 2.1.1.2.1.4 | GP Instrument Requirements | 0.08d? | 2006-12-04 A | 2008-02-28 | 80% | 0.02d? |  |  |  | 43d | finish no earlier than 2008-02-28 | Le Mignant [468.8%] | 3h | 2.4h | 171.93 |  | 137.45 |
| 71 | 2.1.1.2.2 | **Giant Planet Moons Requirements** | 325d? | 2006-12-04 A | 2008-02-28 | 80% | 65d? |  |  |  | 43d |  |  | 20h | 16h | 1,146.2 |  | 916.96 |
| 72 | 2.1.1.2.2.1 | GP Moons Science Requirements | 0.13d? | 2006-12-04 A | 2008-02-28 | 80% | 0.03d? |  |  |  | 43d | finish no earlier than 2008-02-28 | Le Mignant [468.8%] | 5h | 4h | 286.55 |  | 229.24 |
| 73 | 2.1.1.2.2.2 | GP Moons AO Requirements | 0.13d? | 2006-12-04 A | 2008-02-28 | 80% | 0.03d? |  |  |  | 43d | finish no earlier than 2008-02-28 | Le Mignant [468.8%] | 5h | 4h | 286.55 |  | 229.24 |
| 74 | 2.1.1.2.2.3 | GP Moons Observing Requirements | 0.13d? | 2006-12-04 A | 2008-02-28 | 80% | 0.03d? |  |  |  | 43d | finish no earlier than 2008-02-28 | Le Mignant [468.8%] | 5h | 4h | 286.55 |  | 229.24 |
| 75 | 2.1.1.2.2.4 | GP Moons Instrument Requirements | 0.13d? | 2006-12-04 A | 2008-02-28 | 80% | 0.03d? |  |  |  | 43d | finish no earlier than 2008-02-28 | Le Mignant [468.8%] | 5h | 4h | 286.55 |  | 229.24 |

Notes:
- 51: PW
- 52: CM
- 53: FM
- 54: FM
- 65: IdP

| ID | WBS | Task | Duration | Start | Finish | Complete | Remaining | Baseline start | Baseline finish | Baseline duration | Total slack | Constraint | Resources | Work | Actual work | Cost | Baseline cost | Actual cost | Text1 |
| --- | --- | --- | --- | --- | --- | --- | --- | --- | --- | --- | --- | --- | --- | --- | --- | --- | --- | --- | --- |
| 76 | 2.1.1.3 | **Shape & Size of Asteroids** | 325d? | 2006-12-04 A | 2008-02-28 | 67% | 108.13d? | 2007-01-29 | 2007-04-06 | 50d? | 0d |  |  | 33.2h | 29.88h | 1,524.71 | 7,750 | 1,334.44 |  |
| 77 | 2.1.1.3.1 | Asteroids Science Requirements | 325d? | 2006-12-04 A | 2008-02-28 | 67% | 108.12d? |  |  |  | 0d | finish no earlier than 2008-02-28 | Le Mignant [35%]; McGrath | 8.3h | 7.47h | 382.32 |  | 334.75 |  |
| 78 | 2.1.1.3.2 | Asteroids AO Requirements | 325d? | 2006-12-04 A | 2008-02-28 | 67% | 108.14d? |  |  |  | 0d | finish no earlier than 2008-02-28 | Le Mignant [35%]; McGrath | 8.3h | 7.47h | 380.04 |  | 332.47 |  |
| 79 | 2.1.1.3.3 | Asteroids Observing Requirements | 325d? | 2006-12-04 A | 2008-02-28 | 67% | 108.12d? |  |  |  | 0d | finish no earlier than 2008-02-28 | Le Mignant [35%]; McGrath | 8.3h | 7.47h | 382.32 |  | 334.75 |  |
| 80 | 2.1.1.3.4 | Asteroids Instrument Requirements | 325d? | 2006-12-04 A | 2008-02-28 | 67% | 108.14d? |  |  |  | 0d | finish no earlier than 2008-02-28 | Le Mignant [35%]; McGrath | 8.3h | 7.47h | 380.04 |  | 332.47 |  |
| 81 | 2.1.2 | **Galactic Science Requirements** | 330d? | 2006-11-27 A | 2008-02-28 | 46% | 178.56d? | 2006-10-02 | 2007-04-06 | 135d? | 43d |  |  | 144h | 73.8h | 1,263.9 | 37,200 | 21.2 |  |
| 82 | 2.1.2.1 | **General Relativity at the Galactic Center (Key)** | 325d? | 2006-12-04 A | 2008-02-28 | 70% | 97.02d? | 2006-10-02 | 2007-01-12 | 75d? | 43d |  |  | 60h | 49h |  | 6,200 |  |  |
| 83 | 2.1.2.1.1 | **GR Astrometry Requirements** | 325d? | 2006-12-04 A | 2008-02-28 | 50% | 161.62d? | 2006-10-02 | 2006-12-08 | 50d? | 43d |  |  | 40h | 30h |  | 4,650 |  | mv into FY07 |
| 84 | 2.1.2.1.1.1 | GR Astrometry Science Requirements | 325d? | 2006-12-04 A | 2008-02-28 | 50% | 161.62d? |  |  |  | 43d | finish no earlier than 2008-02-28 | Max [35%] | 10h | 7.5h |  |  |  |  |
| 85 | 2.1.2.1.1.2 | GR Astrometry AO Requirements | 325d? | 2006-12-04 A | 2008-02-28 | 50% | 161.62d? |  |  |  | 43d | finish no earlier than 2008-02-28 | Max [35%] | 10h | 7.5h |  |  |  |  |
| 86 | 2.1.2.1.1.3 | GR Astrometry Observing Requirements | 325d? | 2006-12-04 A | 2008-02-28 | 50% | 161.62d? |  |  |  | 43d | finish no earlier than 2008-02-28 | Max [35%] | 10h | 7.5h |  |  |  |  |
| 87 | 2.1.2.1.1.4 | GR Astrometry Instrument Requirements | 325d? | 2006-12-04 A | 2008-02-28 | 50% | 161.62d? |  |  |  | 43d | finish no earlier than 2008-02-28 | Max [35%] | 10h | 7.5h |  |  |  |  |
| 88 | 2.1.2.1.2 | **GR Radial Velocity Requirements** | 325d? | 2006-12-04 A | 2008-02-28 | 90% | 32.41d? | 2006-11-27 | 2007-01-12 | 35d? | 43d |  |  | 20h | 19h |  | 775 |  |  |
| 89 | 2.1.2.1.2.1 | GR RV Science Requirements | 325d? | 2006-12-04 A | 2008-02-28 | 90% | 32.41d? |  |  |  | 43d | finish no earlier than 2008-02-28 | Max [35%] | 5h | 4.75h |  |  |  |  |
| 90 | 2.1.2.1.2.2 | GR RV AO Requirements | 325d? | 2006-12-04 A | 2008-02-28 | 90% | 32.41d? |  |  |  | 43d | finish no earlier than 2008-02-28 | Max [35%] | 5h | 4.75h |  |  |  |  |
| 91 | 2.1.2.1.2.3 | GR RV Observing Requirements | 325d? | 2006-12-04 A | 2008-02-28 | 90% | 32.41d? |  |  |  | 43d | finish no earlier than 2008-02-28 | Max [35%] | 5h | 4.75h |  |  |  |  |
| 92 | 2.1.2.1.2.4 | GR RV Instrument Requirements | 325d? | 2006-12-04 A | 2008-02-28 | 90% | 32.41d? |  |  |  | 43d | finish no earlier than 2008-02-28 | Max [35%] | 5h | 4.75h |  |  |  |  |
| 93 | 2.1.2.2 | Resolved Stellar Populations at the Galactic Center | 1d? | 2006-11-27 A | 2006-11-27 | 13% | 0.87d? | 2006-11-27 | 2007-03-09 | 75d? | 372d |  |  |  |  |  | 6,200 |  |  |
| 94 | 2.1.2.3 | Galactic Center Nature of Sgr A*: 3-5 um Color & 2 um Polarimetry Variability | 1d? | 2007-01-29 A | 2007-01-29 | 10% | 0.9d? | 2007-01-29 | 2007-04-06 | 50d? | 327d |  |  |  |  |  | 6,200 |  |  |
| 95 | 2.1.2.4 | **Planets around Low Mass Stars & Brown Dwarfs: Companion Sensitivity (Key)** | 325d? | 2006-12-04 A | 2008-02-28 | 88% | 40.23d? | 2006-10-02 | 2007-01-12 | 75d? | 43d |  |  | 24h | 22.8h |  | 6,200 |  |  |
| 96 | 2.1.2.4.1 | Companion Sensitivity Science Requirements | 325d? | 2006-12-04 A | 2008-02-28 | 88% | 40.48d? | 2006-10-02 | 2006-12-08 | 50d? | 43d | finish no earlier than 2008-02-28 | Max [37.5%] | 6h | 5.7h |  | 4,650 |  | mv into FY07 |
| 97 | 2.1.2.4.2 | Companion Sensitivy AO Requirements | 325d? | 2006-12-04 A | 2008-02-28 | 88% | 40.47d? |  |  |  | 43d | finish no earlier than 2008-02-28 | Max [35%] | 6h | 5.7h |  |  |  |  |
| 98 | 2.1.2.4.3 | Companion Sensitivity Observing Requirements | 325d? | 2006-12-04 A | 2008-02-28 | 88% | 39.99d? | 2006-11-27 | 2007-01-12 | 35d? | 43d | finish no earlier than 2008-02-28 | Max [8.9%] | 6h | 5.7h |  | 775 |  |  |
| 99 | 2.1.2.4.4 | Companion Sensitivity Instrument Requirements | 325d? | 2006-12-04 A | 2008-02-28 | 88% | 39.99d? | 2006-11-27 | 2007-01-12 | 35d? | 43d | finish no earlier than 2008-02-28 | Max [8.9%] | 6h | 5.7h |  | 775 |  |  |

Notes:
- 76: FM
- 81: ML
- 82: AG
- 83: AG
- 88: AG
- 93: PDR
- 94: Cancel
- 95: ML

| ID | WBS | Task | Duration | Start | Finish | Complete | Remaining | Baseline start | Baseline finish | Baseline duration | Total slack | Constraint | Resources | Work | Actual work | Cost | Baseline cost | Actual cost | Text1 |
| --- | --- | --- | --- | --- | --- | --- | --- | --- | --- | --- | --- | --- | --- | --- | --- | --- | --- | --- | --- |
| 100 | 2.1.2.5 | **Debris & Protoplanetary Disks** | 325d? | 2006-12-04 A | 2008-02-28 |  | 324.71d? | 2007-01-29 | 2007-04-06 | 50d? | 43d |  |  | 20h | 2h | 573.1 | 6,200 | 21.2 |  |
| 101 | 2.1.2.5.1 | Disk Science Requirements | 282.58d? | 2006-12-04 A | 2008-02-28 |  | 282.5d? | 2007-01-29 | 2007-03-02 | 25d? | 43d | finish no earlier than 2008-02-28 | Max [75%]; Le Mignant [0.1%] | 5h | 0.5h | 143.28 | 4,650 |  |  |
| 102 | 2.1.2.5.2 | Disk AO Requirements | 325d? | 2006-12-04 A | 2008-02-28 |  | 324.95d? |  |  |  | 43d | finish no earlier than 2008-02-28 | Max [35%]; Le Mignant | 5h | 0.5h | 143.28 |  | 21.2 |  |
| 103 | 2.1.2.5.3 | Disk Observing Requirements | 325d? | 2006-12-04 A | 2008-02-28 |  | 324.5d? | 2007-03-05 | 2007-04-06 | 25d? | 43d | finish no earlier than 2008-02-28 | Max [12.5%]; Le Mignant [0.1%] | 5h | 0.5h | 143.28 | 775 |  |  |
| 104 | 2.1.2.5.4 | Disk Instrument Requirements | 325d? | 2006-12-04 A | 2008-02-28 |  | 324.5d? | 2007-03-05 | 2007-04-06 | 25d? | 43d | finish no earlier than 2008-02-28 | Max [12.5%]; Le Mignant [0.1%] | 5h | 0.5h | 143.28 | 775 |  |  |
| 105 | 2.1.2.6 | **Young Stellar Objects** | 325d? | 2006-12-04 | 2008-02-28 |  |  | 2006-11-27 | 2007-03-09 | 75d? | 43d |  |  | 40h |  | 690.8 | 6,200 |  |  |
| 106 | 2.1.2.6.1 | YSO Science Requirements | 325d? | 2006-12-04 | 2008-02-28 |  |  | 2006-11-27 | 2007-01-26 | 45d? | 43d | start no earlier than 2006-12-04 | Max [0.2%]; McGrath | 10h |  | 172.7 | 4,650 |  |  |
| 107 | 2.1.2.6.2 | YSO AO Requirements | 325d? | 2006-12-04 | 2008-02-28 |  |  |  |  |  | 43d | finish no earlier than 2008-02-28 | Max [0.2%]; McGrath | 10h |  | 172.7 |  |  |  |
| 108 | 2.1.2.6.3 | YSO Observing Requirements | 325d? | 2006-12-04 | 2008-02-28 |  |  | 2007-01-29 | 2007-03-09 | 30d? | 43d | finish no earlier than 2008-02-28 | Max [0.2%]; McGrath | 10h |  | 172.7 | 775 |  |  |
| 109 | 2.1.2.6.4 | YSO Instrument Requirements | 325d? | 2006-12-04 | 2008-02-28 |  |  | 2007-01-29 | 2007-03-09 | 30d? | 43d | finish no earlier than 2008-02-28 | Max [0.2%]; McGrath | 10h |  | 172.7 | 775 |  |  |
| 110 | 2.1.3 | **Extragalactic Science Requirements** | 325d? | 2006-12-04 A | 2008-02-28 | 45% | 179.47d? | 2006-10-02 | 2007-04-27 | 150d? | 43d |  |  | 196h | 116.8h | 4,282.96 | 34,540 | 2,312.46 |  |
| 111 | 2.1.3.1 | **Resolved Stellar Populations in Crowded Fields** | 325d? | 2006-12-04 A | 2008-02-28 |  | 323.82d? | 2006-10-02 | 2007-02-02 | 90d? | 43d |  |  | 52h | 5.2h | 1,381.6 | 10,362 | 157.17 |  |
| 112 | 2.1.3.1.1 | Stellar Populations Science Requirements | 290.4d? | 2006-12-04 A | 2008-02-28 |  | 290.09d? | 2006-10-02 | 2006-12-22 | 60d? | 43d | finish no earlier than 2008-02-28 | McGrath [52.1%]; Max [0.1%] | 13h | 1.3h | 345.4 | 8,635 | 44.91 | mv into FY07 |
| 113 | 2.1.3.1.2 | Stellar Populations AO Requirements | 325d? | 2006-12-04 A | 2008-02-28 |  | 324.92d? |  |  |  | 43d | finish no earlier than 2008-02-28 | McGrath; Max | 13h | 1.3h | 345.4 |  | 22.45 |  |
| 114 | 2.1.3.1.3 | Stellar Populations Observing Requirements | 316d? | 2006-12-04 A | 2008-02-28 | 1% | 313.92d? | 2006-12-11 | 2007-02-02 | 40d? | 43d | finish no earlier than 2008-02-28 | McGrath [7.8%]; Max [0.1%] | 13h | 1.3h | 345.4 | 863.5 | 44.9 |  |
| 115 | 2.1.3.1.4 | Stellar Populations Instrument Requirements | 320d? | 2006-12-04 A | 2008-02-28 | 1% | 317.92d? | 2006-12-11 | 2007-02-02 | 40d? | 43d | finish no earlier than 2008-02-28 | McGrath [7.8%]; Max [0.1%] | 13h | 1.3h | 345.4 | 863.5 | 44.9 |  |
| 116 | 2.1.3.2 | **High Redshift Galaxies (Key)** | 325d? | 2006-12-04 A | 2008-02-28 | 84% | 53.39d? | 2006-10-02 | 2007-02-02 | 90d? | 0d |  |  | 56h | 53.2h | 967.12 | 10,362 | 967.12 |  |
| 117 | 2.1.3.2.1 | High Redshift Science Requirements | 285.1d? | 2006-12-04 A | 2008-02-28 | 84% | 47d? | 2006-10-02 | 2006-12-22 | 60d? | 0d | finish no earlier than 2008-02-28 | McGrath [41.7%]; Max [35%] | 14h | 13.3h | 241.78 | 6,908 | 241.78 | mv into FY07 |
| 118 | 2.1.3.2.2 | High Redshift AO Requirements | 325d? | 2006-12-04 A | 2008-02-28 | 83% | 54d? |  |  |  | 0d | finish no earlier than 2008-02-28 | Max [35%]; McGrath | 14h | 13.3h | 241.78 |  | 241.78 |  |
| 119 | 2.1.3.2.3 | High Redshift Observing Requirements | 297.6d? | 2006-12-04 A | 2008-02-28 | 84% | 48.5d? | 2006-12-11 | 2007-02-02 | 40d? | 0d | finish no earlier than 2008-02-28 | McGrath [15.6%]; Max [35%] | 14h | 13.3h | 241.78 | 1,727 | 241.78 |  |
| 120 | 2.1.3.2.4 | High Redshift Instrument Requirements | 301.6d? | 2006-12-04 A | 2008-02-28 | 84% | 49.17d? | 2006-12-11 | 2007-02-02 | 40d? | 0d | finish no earlier than 2008-02-28 | McGrath [15.6%]; Max [35%] | 14h | 13.3h | 241.78 | 1,727 | 241.78 |  |
| 121 | 2.1.3.3 | **Nearby Active Galactic Nuclei (Key)** | 325d? | 2006-12-04 A | 2008-02-28 | 55% | 146.84d? | 2006-12-11 | 2007-04-27 | 100d? | 43d |  |  | 32h | 24h |  | 6,908 |  |  |
| 122 | 2.1.3.3.1 | AGN Science Requirements | 325d? | 2006-12-04 A | 2008-02-28 | 58% | 134.88d? | 2006-12-11 | 2007-03-02 | 60d? | 43d | finish no earlier than 2008-02-28 | Max [31.2%] | 8h | 6h |  | 5,181 |  |  |
| 123 | 2.1.3.3.2 | AGN AO Requirements | 325d? | 2006-12-04 A | 2008-02-28 | 58% | 134.95d? |  |  |  | 43d | finish no earlier than 2008-02-28 | Max [35%] | 8h | 6h |  |  |  |  |
| 124 | 2.1.3.3.3 | AGN Observing Requirements | 325d? | 2006-12-04 A | 2008-02-28 | 43% | 184.26d? | 2007-03-05 | 2007-04-27 | 40d? | 43d | finish no earlier than 2008-02-28 | Max [7.8%] | 8h | 6h |  | 863.5 |  |  |
| 125 | 2.1.3.3.4 | AGN Instrument Requirements | 325d? | 2006-12-04 A | 2008-02-28 | 59% | 133.28d? | 2007-03-05 | 2007-04-27 | 40d? | 43d | finish no earlier than 2008-02-28 | Max [7.8%] | 8h | 6h |  | 863.5 |  |  |

Notes:
- 100: MF,PK
- 105: MP,JE
- 110: CM
- 111: CM
- 116: CM
- 121: CM

| ID | WBS | Task | Duration | Start | Finish | Predecessors | Complete | Remaining | Baseline start | Baseline finish | Baseline duration | Total slack | Free slack | Constraint | Resources | Work | Actual work | Cost | Baseline cost | Actual cost | Text1 |
| --- | --- | --- | --- | --- | --- | --- | --- | --- | --- | --- | --- | --- | --- | --- | --- | --- | --- | --- | --- | --- | --- |
| 126 | 2.1.3.4 | **Gravitational Lensing** | 325d? | 2006-12-04 A | 2008-02-28 |  | 49% | 166.85d? | 2006-12-11 | 2007-04-27 | 100d? | 43d |  |  |  | 32h | 22.4h | 1,105.28 | 6,908 | 773.7 |  |
| 127 | 2.1.3.4.1 | Lensing Science Requirements | 325d? | 2006-12-04 A | 2008-02-28 |  | 50% | 161.86d? | 2006-12-11 | 2007-03-02 | 60d? | 43d |  | finish no earlier than 2008-02-28 | McGrath [31.2%] | 8h | 5.6h | 276.32 | 5,181 | 193.42 |  |
| 128 | 2.1.3.4.2 | Lensing AO Requirements | 325d? | 2006-12-04 A | 2008-02-28 |  | 50% | 162.3d? |  |  |  | 43d |  | finish no earlier than 2008-02-28 | McGrath | 8h | 5.6h | 276.32 |  | 193.42 |  |
| 129 | 2.1.3.4.3 | Lensing Observing Requirements | 325d? | 2006-12-04 A | 2008-02-28 |  | 44% | 183.31d? | 2007-03-05 | 2007-04-27 | 40d? | 43d |  | finish no earlier than 2008-02-28 | McGrath [7.8%] | 8h | 5.6h | 276.32 | 863.5 | 193.42 |  |
| 130 | 2.1.3.4.4 | Lensing Instrument Requirements | 325d? | 2006-12-04 A | 2008-02-28 |  | 51% | 159.94d? | 2007-03-05 | 2007-04-27 | 40d? | 43d |  | finish no earlier than 2008-02-28 | McGrath [7.8%] | 8h | 5.6h | 276.32 | 863.5 | 193.42 |  |
| 131 | 2.1.3.5 | **QSO Host Galaxies** | 325d? | 2006-12-04 A | 2008-02-28 |  | 38% | 203.03d? |  |  |  | 43d |  |  |  | 24h | 12h | 828.96 |  | 414.48 |  |
| 132 | 2.1.3.5.1 | QSO Science Requirements | 325d? | 2006-12-04 A | 2008-02-28 |  | 38% | 203.03d? |  |  |  | 43d |  | finish no earlier than 2008-02-28 | McGrath | 6h | 3h | 207.24 |  | 103.62 |  |
| 133 | 2.1.3.5.2 | QSO AO Requirements | 325d? | 2006-12-04 A | 2008-02-28 |  | 38% | 203.03d? |  |  |  | 43d |  | finish no earlier than 2008-02-28 | McGrath | 6h | 3h | 207.24 |  | 103.62 |  |
| 134 | 2.1.3.5.3 | QSO Observing Requirements | 325d? | 2006-12-04 A | 2008-02-28 |  | 38% | 203.03d? |  |  |  | 43d |  | finish no earlier than 2008-02-28 | McGrath | 6h | 3h | 207.24 |  | 103.62 |  |
| 135 | 2.1.3.5.4 | QSO Instrument Requirements | 325d? | 2006-12-04 A | 2008-02-28 |  | 38% | 203.03d? |  |  |  | 43d |  | finish no earlier than 2008-02-28 | McGrath | 6h | 3h | 207.24 |  | 103.62 |  |
| 136 | 2.1.4 | **Science Case Requirements Document** | 361d? | 2006-10-02 A | 2008-02-15 |  | 89% | 39.34d? | 2006-10-02 | 2007-10-15 | 271d? | 37d |  |  |  | 200h | 166h | 2,983.2 | 4,584.8 | 2,396.02 |  |
| 137 | 2.1.4.1 | Science Case Requirements Doc Rev 1 | 14d? | 2006-10-02 A | 2006-10-19 A |  | 100% |  | 2006-10-02 | 2006-10-19 | 14d? |  |  | finish no earlier than 2006-10-19 | Max [17.9%]; Wizinowich [17.9%] | 40h | 40h | 1,146.2 | 1,146.2 | 1,146.2 |  |
| 138 | 2.1.4.2 | Science Case Requirements Doc Rev 2 | 190d? | 2007-04-02 A | 2007-12-20 A |  | 100% |  | 2007-02-13 | 2007-03-02 | 14d? |  |  | finish no earlier than 2007-12-20 | Max [27.8%]; Wizinowich [5.6%] | 120h | 120h | 1,146.2 | 1,146.2 | 1,146.2 | assignment |
| 139 | 2.1.4.3 | Science Case Requirements Doc Rev 3 | 30d? | 2008-01-07 A | 2008-02-15 |  | 15% | 25.5d? | 2007-06-05 | 2007-06-22 | 13.89d? | 37d | 0d | finish no earlier than 2008-02-15 | Max [8.3%]; McGrath [8.3%] | 40h | 6h | 690.8 | 1,146.2 | 103.62 |  |
| 140 | 2.2 | **Observatory Requirements** | 320d? | 2006-10-02 A | 2007-12-20 |  | 32% | 218.82d? | 2006-10-02 | 2007-09-07 | 245d? | 0d |  |  |  | 174h | 139h | 10,477.22 | 13,342.72 | 8,471.37 |  |
| 141 | 2.2.1 | Development Requirements | 40d? | 2006-10-02 A | 2006-11-24 A |  | 100% |  | 2006-10-02 | 2006-11-24 | 40d? |  |  | start no earlier than 2006-10-02 | Neyman [2.5%]; Wizinowich [2.5%] | 16h | 16h | 916.96 | 916.96 | 916.96 |  |
| 142 | 2.2.2 | Observatory Interface Requirements | 20d? | 2006-10-02 A | 2006-10-27 A |  | 100% |  | 2006-10-02 | 2006-10-27 | 20d? |  |  | start no earlier than 2006-10-02 | Neyman [5%]; Wizinowich [5%]; Adkins [5%] | 24h | 24h | 1,375.44 | 1,375.44 | 1,375.44 |  |
| 143 | 2.2.3 | Science Operations Requirements | 40d? | 2006-10-02 A | 2006-11-24 A |  | 100% |  | 2006-10-02 | 2006-11-24 | 40d? |  |  | finish no earlier than 2006-11-24 | Le Mignant [10%]; Wizinowich [5%]; Bouchez [5%] | 64h | 64h | 4,173.12 | 4,173.12 | 4,173.12 |  |
| 144 | 2.2.4 | Observatory Requirements Rev 2 | 240d? | 2007-01-22 A | 2007-12-20 | 141FS+8w, 142FS+8w, 143FS+8w | 3% | 232.5d? | 2007-01-22 | 2007-02-09 | 15d? | 0d |  | finish no earlier than 2007-12-20 | Neyman [20%]; Bell [8.3%]; Le Mignant [13.3%]; Adkins [8.3%]; Johansson [8.3%]; Chin [8.3%] | 70h | 35h | 4,011.7 | 4,584.8 | 2,005.85 | assignments |
| 145 | 2.3 | **System Requirements Document** | 371d? | 2006-10-09 A | 2008-03-07 |  | 65% | 131.17d? | 2006-10-09 | 2007-11-02 | 280d? | 37d |  |  |  | 80h | 52h | 4,584.8 | 12,035.1 | 2,980.12 |  |
| 146 | 2.3.1 | **Traceability Matrix** | 102d? | 2006-10-09 A | 2007-02-27 |  | 73% | 27.82d? | 2006-10-09 | 2007-10-20 | 270d? | 302.61d |  |  |  | 20h | 15h | 1,146.2 | 7,450.3 | 859.65 |  |
| 147 | 2.3.1.1 | Traceability Matrix Rev 1 | 10d? | 2006-10-09 A | 2006-10-20 A |  | 100% |  | 2006-10-09 | 2006-10-20 | 10d? |  |  | finish no earlier than 2006-10-20 | Neyman [12.5%] | 10h | 10h | 573.1 | 573.1 | 573.1 |  |
| 148 | 2.3.1.2 | Traceability Matrix Rev 2 | 12d? | 2007-02-12 A | 2007-02-27 |  | 50% | 6d? | 2007-02-12 | 2007-02-27 | 12d? | 302.61d | 33d | finish no earlier than 2007-02-27 | Wizinowich [10.4%] | 10h | 5h | 573.1 | 4,584.8 | 286.55 |  |
| 149 | 2.3.2 | **System Requirements Document** | 336d | 2006-11-27 A | 2008-03-07 |  | 61% | 131.5d | 2006-11-27 | 2007-11-02 | 245d | 37d |  |  |  | 60h | 37h | 3,438.6 | 4,584.8 | 2,120.47 |  |
| 150 | 2.3.2.1 | SRD Rev 1 | 10d | 2006-11-27 A | 2006-12-08 A | 137, 147, 141, 142 | 100% |  | 2006-11-27 | 2006-12-08 | 10d |  |  | start no earlier than 2006-11-27 | Wizinowich [25%] | 20h | 20h | 1,146.2 | 1,146.2 | 1,146.2 |  |
| 151 | 2.3.2.2 | SRD Rev 2 | 22d | 2007-04-16 A | 2007-12-28 | 148, 144, 137 | 85% | 3.39d | 2007-03-09 | 2007-03-22 | 10d | 87.34d |  | finish no earlier than 2007-05-15 | Wizinowich [25%] | 20h | 17h | 1,146.2 | 1,146.2 | 974.27 |  |
| 152 | 2.3.2.3 | SRD Rev 3 | 15d | 2008-02-18 | 2008-03-07 | 139 |  |  | 2007-06-29 | 2007-07-12 | 10d | 37d |  | finish no earlier than 2007-08-31 | Wizinowich [16.7%] | 20h |  | 1,146.2 | 1,146.2 |  |  |

Notes:
- 126: EM
- 131: EM
- 136: CM
- 140: CN
- 141: CN
- 142: CN
- 143: DLM
- 144: PW
- 146: CN
- 147: CN
- 148: PW
- 149: PW
- 150: PW
- 151: PW
- 152: PW

| ID | WBS | Task | Type | Duration | Start | Finish | Predecessors | Complete | Remaining | Baseline start | Baseline finish | Baseline duration | Total slack | Free slack | Constraint | Resources | Work | Actual work | Cost | Baseline cost | Actual cost | Text1 |
| --- | --- | --- | --- | --- | --- | --- | --- | --- | --- | --- | --- | --- | --- | --- | --- | --- | --- | --- | --- | --- | --- | --- |
| 153 | 3 | **System Design** |  | 403d? | 2006-08-14 A | 2008-02-26 |  | 64% | 146.48d? | 2006-08-14 | 2008-01-18 | 375d? | 45d |  |  |  | 7337h | 5853.03h | 505,333.14 | 654,913.28 | 411,151.52 |  |
| 154 | 3.1 | **Systems Engineering** |  | 403d? | 2006-08-14 A | 2008-02-26 |  | 77% | 91.46d? | 2006-08-14 | 2007-12-28 | 360d? | 45d |  |  |  | 4585h | 4201h | 318,810.75 | 347,903.94 | 291,556.36 |  |
| 155 | 3.1.1 | **Performance Budgets** |  | 403d? | 2006-08-14 A | 2008-02-26 |  | 75% | 101.79d? | 2006-08-14 | 2007-12-12 | 348d? | 45d |  |  |  | 1699h | 1531h | 103,358.23 | 138,258.26 | 91,018.93 |  |
| 156 | 3.1.1.1 | **Model Assumptions** |  | 278.43d? | 2006-08-14 A | 2007-09-06 |  | 99% | 1.15d? | 2006-08-14 | 2007-06-29 | 230d? | 169.57d |  |  |  | 288h | 280h | 17,831.72 | 15,974.4 | 17,246.92 |  |
| 157 | 3.1.1.1.1 | **TMT site monitoring data mining** |  | 230d? | 2006-08-14 A | 2007-06-29 A |  | 100% |  | 2006-08-14 | 2007-06-29 | 230d? |  |  |  |  | 80h | 80h | 4,584.8 | 4,584.8 | 4,584.8 |  |
| 158 | 3.1.1.1.1.1 | Tools in place & 1st release |  | 24d? | 2006-08-14 A | 2006-09-14 A |  | 100% |  | 2006-08-14 | 2006-09-14 | 24d? |  |  | finish no earlier than 2006-09-14 | Flicker [20.8%] | 40h | 40h | 2,292.4 | 2,292.4 | 2,292.4 |  |
| 159 | 3.1.1.1.1.2 | Release updated data (every two months) |  | 205d? | 2006-09-18 A | 2007-06-29 A | 158 | 100% |  | 2006-09-18 | 2007-06-29 | 205d? |  |  | finish no earlier than 2007-06-29 | Flicker [2.4%] | 40h | 40h | 2,292.4 | 2,292.4 | 2,292.4 |  |
| 160 | 3.1.1.1.2 | Telescope dynamic performance data |  | 44d? | 2006-10-02 A | 2006-11-30 A |  | 100% |  | 2006-10-02 | 2006-11-30 | 44d? |  |  | start no earlier than 2006-10-02 | Neyman [17%]; Flicker [17%] | 120h | 120h | 6,877.2 | 6,877.2 | 6,877.2 |  |
| 161 | 3.1.1.1.3 | Telescope static wavefront errors |  | 44d? | 2006-10-02 A | 2006-11-30 A |  | 100% |  | 2006-10-02 | 2006-11-30 | 44d? |  |  | finish no earlier than 2006-11-30 | Neyman [5.7%] | 20h | 20h | 1,146.2 | 1,146.2 | 1,146.2 |  |
| 162 | 3.1.1.1.4 | Sodium return vs laser format |  | 22d? | 2006-11-01 A | 2006-11-30 A |  | 100% |  | 2006-11-01 | 2006-11-30 | 22d? |  |  | start no earlier than 2006-11-01 | Gavel [11.4%]; Neyman [11.4%] | 40h | 40h | 3,366.2 | 3,366.2 | 3,366.2 |  |
| 163 | 3.1.1.1.5 | **Evaluate & Adopt New Model Assumptions** |  | 63.43d? | 2007-06-11 A | 2007-09-06 |  | 78% | 14.1d? |  |  |  | 169.57d |  |  |  | 28h | 20h | 1,857.32 |  | 1,272.52 |  |
| 164 | 3.1.1.1.5.1 | New Model Assumptions Rev 1 |  | 5d? | 2007-06-11 A | 2007-06-15 A |  | 100% |  |  |  |  |  |  | finish no earlier than 2007-06-15 | Dekany [35%]; Flicker [30%]; Neyman | 20h | 20h | 1,272.52 |  | 1,272.52 |  |
| 165 | 3.1.1.1.5.2 | New Model Assumptions Rev 2 |  | 1.43d? | 2007-09-05 | 2007-09-06 |  |  |  |  |  |  | 169.57d |  | start no earlier than 2007-09-05 | Dekany [35%]; Flicker; Neyman | 8h |  | 584.8 |  |  |  |
| 166 | 3.1.1.2 | **Model/Tool Validation** |  | 230d? | 2006-08-14 A | 2007-06-29 |  | 55% | 104.24d? | 2006-08-14 | 2006-12-15 | 90d? | 218d |  |  |  | 294h | 264h | 14,129.48 | 11,821.88 | 12,410.18 |  |
| 167 | 3.1.1.2.1 | Agreement between Tomography Codes |  | 35d? | 2006-08-14 A | 2006-09-29 A |  | 100% |  | 2006-08-14 | 2006-09-29 | 35d? |  |  | start no earlier than 2006-08-14 | Flicker [5.4%]; Gavel [3.6%]; Neyman [5.4%] | 40h | 40h | 2,829.3 | 2,829.3 | 2,829.3 |  |
| 168 | 3.1.1.2.2 | Agreement between Sky Coverage Codes |  | 15d? | 2006-10-16 A | 2006-11-03 A |  | 100% |  | 2006-10-16 | 2006-11-03 | 15d? |  |  | start no earlier than 2006-10-16 | Dekany [10%]; Gavel [10%]; Clare [13.3%] | 40h | 40h | 3,390.68 | 3,390.68 | 3,390.68 | mv into FY07 |
| 169 | 3.1.1.2.3 | Anchor to Keck II LGS AO PSFs |  | 195d? | 2006-10-02 A | 2007-06-29 |  | 3% | 189.75d? | 2006-10-02 | 2006-10-30 | 21d? | 218d |  | finish no earlier than 2007-06-29 | Neyman [23.8%] | 40h | 10h | 2,292.4 | 2,292.4 | 573.1 |  |
| 170 | 3.1.1.2.4 | Anchor to On-sky MGSU Experiments |  | 3.67d? | 2006-11-10 A | 2006-11-15 A |  | 100% |  | 2006-11-10 | 2006-11-15 | 3.67d? |  |  | finish no earlier than 2006-11-15 | Flicker [34.1%] | 10h | 10h | 573.1 | 573.1 | 573.1 |  |
| 171 | 3.1.1.2.5 | Anchor to LAO Lab Experiments |  | 170d? | 2006-11-06 A | 2007-06-29 A |  | 100% |  | 2006-11-06 | 2006-12-15 | 30d? |  |  | finish no earlier than 2007-06-29 | Gavel [1.7%]; Dekany [16.7%]; Kupke [33.3%]; Ammons [33.3%] | 164h | 164h | 5,044 | 2,736.4 | 5,044 |  |
| 172 | 3.1.1.3 | Throughput |  | 165d? | 2006-10-02 A | 2007-05-18 A |  | 100% |  | 2006-10-02 | 2006-12-29 | 65d? |  |  | finish no earlier than 2007-05-18 | Bouchez [6.2%] | 32h | 32h | 2,844.48 | 2,844.48 | 2,844.48 | mv into FY07 |
| 173 | 3.1.1.4 | **Background** |  | 165d? | 2006-10-02 A | 2007-05-18 A |  | 100% |  | 2006-10-02 | 2007-01-09 | 71.5d? |  |  |  |  | 40h | 40h | 3,555.6 | 4,444.5 | 3,555.6 |  |
| 174 | 3.1.1.4.1 | Document Proposal Analysis | milestone | 0d? | 2006-10-02 A | 2006-10-02 A |  | 100% |  | 2006-10-02 | 2006-10-12 | 9d? |  |  | start no earlier than 2006-10-02 | Bouchez [13.9%] |  |  |  | 888.9 |  |  |
| 175 | 3.1.1.4.2 | Develop Background Performance Budget |  | 156d? | 2006-10-02 A | 2007-05-18 A |  | 100% |  | 2006-10-02 | 2007-01-09 | 62.5d? |  |  | finish no earlier than 2007-05-18 | Bouchez [8%] | 40h | 40h | 3,555.6 | 3,555.6 | 3,555.6 |  |
| 176 | 3.1.1.5 | **Wavefront Error vs Sky Coverage** |  | 353d? | 2006-10-02 A | 2008-02-05 |  | 70% | 106.54d? | 2006-10-02 | 2007-01-30 | 87d? | 45d | 0d |  |  | 115h | 55h | 10,222.35 | 8,830.5 | 4,888.95 |  |
| 177 | 3.1.1.5.1 | Document WFE Budget Rev 1 |  | 155d? | 2006-10-02 A | 2007-05-04 A |  | 100% |  | 2006-10-02 | 2006-12-08 | 50d? |  |  | finish no earlier than 2007-05-04 | Dekany [10%]; Britton [40%] | 55h | 55h | 4,888.95 | 3,555.6 | 4,888.95 |  |
| 178 | 3.1.1.5.2 | Document WFE Budget Rev 2 |  | 67d? | 2007-11-05 | 2008-02-05 | 158, 162, 201, 167, 168 |  |  | 2006-12-27 | 2007-01-30 | 25d? | 45d | 0d | finish no earlier than 2008-02-05 | Dekany [7.5%]; Britton [17%] | 60h |  | 5,333.4 | 5,274.9 |  |  |
| 179 | 3.1.1.6 | Encircled Energy vs Sky Coverage |  | 50d? | 2006-10-23 A | 2006-12-29 A |  | 100% |  | 2006-10-23 | 2006-12-29 | 50d? |  |  | finish no earlier than 2007-05-04 | Dekany [17.5%]; Gavel [17.5%] | 110h | 110h | 10,662.3 | 11,325.6 | 10,662.3 |  |
| 180 | 3.1.1.7 | Photometric Accuracy |  | 75d? | 2006-10-16 A | 2007-01-26 A |  | 100% |  | 2006-10-16 | 2007-01-26 | 75d? |  |  | start no earlier than 2006-10-16 | Britton [20%]; Neyman [10%]; Flicker [10%] | 240h | 240h | 17,544 | 17,544 | 17,544 |  |
| 181 | 3.1.1.8 | Astrometric Accuracy |  | 165d? | 2006-11-13 A | 2007-06-29 A |  | 100% |  | 2006-11-13 | 2007-06-29 | 165d? |  |  | start no earlier than 2006-11-13 | Britton [13.6%]; Cameron [13.6%] | 240h | 240h | 5,333.4 | 5,333.4 | 5,333.4 |  |
| 182 | 3.1.1.9 | Polarimetric Accuracy |  | 80d? | 2007-02-05 A | 2007-05-25 |  | 23% | 61.25d? | 2007-02-05 | 2007-03-09 | 25d? | 228d | 183d | finish no earlier than 2007-05-25 | Ireland [20%] | 40h | 30h |  |  |  |  |
| 183 | 3.1.1.10 | Companion Sensitivity |  | 140d? | 2006-11-13 A | 2007-05-25 A |  | 100% |  | 2006-11-13 | 2007-01-09 | 41.25d? |  |  | finish no earlier than 2007-05-25 | Macintosh [30.3%]; Neyman [24.2%]; Flicker [26.7%]; Dekany [35%] | 180h | 180h | 11,831.3 | 17,753.4 | 11,831.3 | assignment |
| 184 | 3.1.1.11 | Observing Efficiency |  | 171d? | 2007-02-05 A | 2007-09-28 |  | 9% | 156d? | 2007-02-05 | 2007-03-16 | 30d? | 0d |  | finish no earlier than 2007-09-28 | Le Mignant [8.3%]; Other [33.3%] | 20h | 10h | 1,146.2 | 5,731 | 573.1 | 160->100 |
| 185 | 3.1.1.12 | Observing Uptime |  | 26d? | 2007-08-27 A | 2007-09-28 |  | 27% | 19d? | 2007-11-05 | 2007-12-12 | 28d? | 0d |  | finish no earlier than 2007-09-28 | Chin [17.9%]; Johansson [17.9%] | 20h | 10h | 1,146.2 | 4,584.8 | 573.1 |  |

Notes:
- 153: PW
- 154: RD
- 155: RD
- 156: CN
- 157: RF
- 158: RF
- 159: RF
- 160: CN
- 161: CN
- 162: DG
- 163: RD
- 164: RD
- 165: RD
- 166: CN
- 167: DG
- 168: RD
- 169: CN
- 170: RF
- 171: DG
- 172: AB
- 173: AB
- 174: AB
- 175: AB
- 176: RD
- 177: RD
- 178: RD
- 179: DG
- 180: MB
- 181: BC
- 182: MI
- 183: RF
- 184: DLM
- 185: EJ

| ID | WBS | Task | Type | Duration | Start | Finish | Predecessors | Complete | Remaining | Baseline start | Baseline finish | Baseline duration | Total slack | Free slack | Constraint | Resources | Work | Actual work | Cost | Baseline cost | Actual cost | Text1 |
| --- | --- | --- | --- | --- | --- | --- | --- | --- | --- | --- | --- | --- | --- | --- | --- | --- | --- | --- | --- | --- | --- | --- |
| 186 | 3.1.1.13 | **Performance Budgets Summary** |  | 198d? | 2007-05-28 A | 2008-02-26 |  | 40% | 118.8d? | 2007-01-31 | 2007-07-20 | 123d? | 45d |  |  |  | 60h | 40h | 5,333.4 | 11,064.4 | 3,555.6 |  |
| 187 | 3.1.1.13.1 | Performance Budgets Summary Ver 1 |  | 10d? | 2007-05-28 A | 2007-06-08 A | 179, 180, 183, 177 | 100% |  | 2007-01-31 | 2007-02-27 | 20d? |  |  | start no earlier than 2007-05-28 | Britton [50%] | 40h | 40h | 3,555.6 | 6,994.2 | 3,555.6 |  |
| 188 | 3.1.1.13.2 | Performance Budgets Summary Ver 2 |  | 15d? | 2008-02-05 | 2008-02-26 | 176, 179, 180, 181, 182, 183, 184, 172, 173, 185 |  |  | 2007-07-02 | 2007-07-20 | 15d? | 45d |  | start no earlier than 2008-01-07 | Dekany [16.7%]; Britton [33.3%] | 20h |  | 1,777.8 | 4,070.2 |  |  |
| 189 | 3.1.1.14 | **Science Products** |  | 7.5d? | 2008-02-05 | 2008-02-15 |  |  |  | 2007-07-23 | 2007-10-19 | 65d? | 52.5d |  |  |  | 20h |  | 1,777.8 | 21,005.9 |  |  |
| 190 | 3.1.1.14.1 | All-In Science Simulations (cancelled) | milestone | 0d? | 2008-02-05 | 2008-02-05 | 178 |  |  | 2007-07-23 | 2007-08-17 | 20d? | 52.5d | 0d | finish no earlier than 2007-10-31 | Neyman [21.7%]; Flicker [21.7%] |  |  |  | 9,169.6 |  |  |
| 191 | 3.1.1.14.2 | **Additional Science Characterization Results** |  | 7.5d? | 2008-02-06 | 2008-02-15 |  |  |  | 2007-08-20 | 2007-10-19 | 45d? | 52.5d |  |  |  | 20h |  | 1,777.8 | 11,836.3 |  |  |
| 192 | 3.1.1.14.2.1 | Point Source Sensitivities |  | 7.5d? | 2008-02-06 | 2008-02-15 | 190 |  |  | 2007-08-20 | 2007-09-13 | 18.75d? | 52.5d |  | start no earlier than 2008-01-21 | Bouchez [33.3%] | 20h |  | 1,777.8 | 2,666.7 |  |  |
| 193 | 3.1.2 | **Trade Studies** |  | 306d? | 2006-10-16 A | 2007-12-14 |  | 86% | 43.81d? | 2006-10-16 | 2007-05-25 | 160d? | 0d |  |  |  | 1330h | 1274h | 97,286.67 | 131,430.06 | 92,308.84 |  |
| 194 | 3.1.2.1 | **System Architecture Trade Studies** |  | 155d? | 2006-10-16 A | 2007-05-18 A |  | 100% |  | 2006-10-16 | 2007-03-30 | 120d? |  |  |  |  | 616h | 616h | 42,124.56 | 48,341.26 | 42,124.56 |  |
| 195 | 3.1.2.1.1 | MOAO & MCAO TS |  | 25d? | 2006-11-13 A | 2006-12-15 A |  | 100% |  | 2006-11-13 | 2006-12-15 | 25d? |  |  | finish no earlier than 2006-12-15 | Gavel [40%] | 80h | 80h | 8,880 | 8,880 | 8,880 | assigned |
| 196 | 3.1.2.1.2 | NGAO versus Keck AO upgrades TS (meeting 5) |  | 20d? | 2007-02-05 A | 2007-03-02 A |  | 100% |  | 2007-02-05 | 2007-03-02 | 20d? |  |  | start no earlier than 2007-02-05 | Neyman [37.5%]; Wizinowich [25%] | 100h | 100h | 5,731 | 5,731 | 5,731 |  |
| 197 | 3.1.2.1.3 | Adaptive Secondary Mirror option TS (m5) |  | 17d? | 2007-04-06 A | 2007-04-30 A |  | 100% |  | 2007-03-05 | 2007-03-30 | 20d? |  |  | finish no earlier than 2007-04-30 | Bauman [15%]; Wizinowich [12.5%] | 16h | 16h | 916.96 | 3,004.96 | 916.96 | assignment |
| 198 | 3.1.2.1.4 | Keck Interferometer Support TS (m5) |  | 100d? | 2006-10-16 A | 2007-03-02 A |  | 100% |  | 2006-10-16 | 2007-03-02 | 100d? |  |  | start no earlier than 2006-10-16 | Neyman [22.5%]; Wizinowich [2.5%] | 120h | 120h | 6,877.2 | 6,877.2 | 6,877.2 |  |
| 199 | 3.1.2.1.5 | GLAO for non-NGAO Instruments TS (m5) |  | 20d? | 2007-02-05 A | 2007-03-02 A |  | 100% |  | 2007-02-05 | 2007-03-02 | 20d? |  |  | start no earlier than 2007-02-05 | Flicker [12.5%] | 20h | 20h | 1,146.2 | 1,146.2 | 1,146.2 |  |
| 200 | 3.1.2.1.6 | Science Instrument Re-use Cost/Benefit TS (m3) |  | 135d? | 2006-11-13 A | 2007-05-18 A |  | 100% |  | 2006-11-13 | 2006-12-08 | 20d? |  |  | finish no earlier than 2007-05-18 | Adkins [25%]; Moore [50%] | 120h | 120h | 9,403.6 | 9,403.6 | 9,403.6 |  |
| 201 | 3.1.2.1.7 | Telescope Wavefront Errors TS |  | 13d? | 2006-12-04 A | 2006-12-20 A | 160, 161 | 100% |  | 2006-12-04 | 2006-12-20 | 13d? |  |  | finish no earlier than 2006-12-20 | Neyman [38.5%]; Flicker [38.5%] | 80h | 80h | 4,584.8 | 4,584.8 | 4,584.8 |  |
| 202 | 3.1.2.1.8 | Observing Model TS |  | 125d? | 2006-11-13 A | 2007-05-04 A |  | 100% |  | 2006-11-13 | 2007-01-12 | 45d? |  |  | finish no earlier than 2007-05-04 | Le Mignant [22.2%] | 80h | 80h | 4,584.8 | 4,584.8 | 4,584.8 |  |
| 203 | 3.1.2.2 | **Adaptive Optics System Trade Studies** |  | 296d? | 2006-10-30 A | 2007-12-14 |  | 67% | 98.26d? | 2006-10-30 | 2007-05-25 | 150d? | 0d |  |  |  | 514h | 458h | 38,173.41 | 67,322.6 | 33,195.58 |  |
| 204 | 3.1.2.2.1 | Rayleigh Rejection TS (m3) |  | 54d? | 2006-10-30 A | 2007-05-09 A |  | 100% |  | 2006-10-30 | 2006-12-08 | 30d? |  |  | finish no earlier than 2007-05-09 | Velur [16.7%] | 72h | 72h | 6,400.08 | 2,292.4 | 6,400.08 |  |
| 205 | 3.1.2.2.2 | LGS WFS Type TS (m4) |  | 35d? | 2006-12-04 A | 2007-01-19 A |  | 100% |  | 2006-12-04 | 2007-01-19 | 35d? |  |  | start no earlier than 2006-12-04 | Velur [10.7%] | 30h | 30h | 2,666.7 | 2,666.7 | 2,666.7 |  |
| 206 | 3.1.2.2.3 | LGS WFS number of subapertures TS (m4) |  | 35d? | 2006-12-04 A | 2007-01-19 A |  | 100% |  | 2006-12-04 | 2007-01-19 | 35d? |  |  | start no earlier than 2006-12-04 | Velur [7.1%] | 20h | 20h | 1,777.8 | 1,777.8 | 1,777.8 |  |
| 207 | 3.1.2.2.4 | LOWFS Architecture TS |  | 80.5d? | 2006-12-04 A | 2007-05-09 A |  | 100% |  | 2006-12-04 | 2007-02-09 | 50d? |  |  | finish no earlier than 2007-05-09 | Flicker [71.4%]; Velur [20%]; Kellner [18.8%] | 220h | 220h | 13,239.8 | 11,696 | 13,239.8 |  |
| 208 | 3.1.2.2.5 | Number & Type of LOWFS TS (m4) |  | 40d? | 2006-12-04 A | 2007-01-26 A |  | 100% |  | 2006-12-04 | 2007-01-26 | 40d? |  |  | start no earlier than 2006-12-04 | Kellner [21.4%]; Velur [9.4%] | 60h | 60h | 4,386 | 4,386 | 4,386 |  |
| 209 | 3.1.2.2.6 | d-IFU & LOWFS AO & Object Selection TS |  | 146d? | 2007-05-28 A | 2007-12-14 |  | 11% | 129.64d? |  |  |  | 0d |  | finish no earlier than 2007-12-14 | Moore [24.4%]; Adkins [10%]; Dekany [35%]; Velur [60%] | 112h | 56h | 9,703.03 |  | 4,725.2 |  |

Notes:
- 187: MB
- 188: MB
- 190: CN
- 192: AB
- 193: RD
- 195: DG
- 196: PW
- 197: PW
- 198: CN
- 199: RF
- 200: AM
- 201: CN
- 202: DLM
- 204: VV
- 205: VV
- 206: VV
- 207: RF
- 208: RC
- 209: AM

| ID | WBS | Task | Type | Duration | Start | Finish | Predecessors | Complete | Remaining | Baseline start | Baseline finish | Baseline duration | Total slack | Constraint | Resources | Work | Actual work | Cost | Baseline cost | Actual cost | Text1 |
| --- | --- | --- | --- | --- | --- | --- | --- | --- | --- | --- | --- | --- | --- | --- | --- | --- | --- | --- | --- | --- | --- |
| 210 | 3.1.2.3 | **Laser Facility Trade Studies** |  | 180d? | 2006-10-16 A | 2007-06-22 A |  | 100% |  | 2006-10-16 | 2007-03-05 | 101d? |  |  |  | 140h | 140h | 12,697.4 | 15,766.2 | 12,697.4 |  |
| 211 | 3.1.2.3.1 | LGS Asterism Geometry & Size TS (m2) |  | 5d? | 2006-10-23 A | 2006-10-27 A |  | 100% |  | 2006-10-23 | 2006-10-27 | 5d? |  | finish no earlier than 2006-10-27 | Flicker [50%] | 20h | 20h | 1,146.2 | 1,146.2 | 1,146.2 |  |
| 212 | 3.1.2.3.2 | Variable vs fixed LGS Asterism Cost/Benefit TS (m2) |  | 10d? | 2006-10-16 A | 2006-10-27 A |  | 100% |  | 2006-10-16 | 2006-10-27 | 10d? |  | finish no earlier than 2006-10-27 | Velur [25%] | 20h | 20h | 1,777.8 | 1,777.8 | 1,777.8 |  |
| 213 | 3.1.2.3.3 | Uplink compensation |  | 25d? | 2007-05-21 A | 2007-06-22 A |  | 100% |  |  |  |  |  | finish no earlier than 2007-06-22 | Gavel [20%]; Velur | 100h | 100h | 9,773.4 |  | 9,773.4 |  |
| 214 | 3.1.2.4 | Trade Study Conclusions Summary |  | 20d? | 2007-05-14 A | 2007-06-08 A |  | 100% |  |  |  |  |  | start no earlier than 2007-05-14 | Neyman [18.8%]; Wizinowich; Gavel; Dekany | 60h | 60h | 4,291.3 |  | 4,291.3 |  |
| 215 | 3.1.3 | **System Architecture** |  | 205d? | 2007-05-08 A | 2008-02-15 |  | 68% | 65.23d? | 2007-02-28 | 2007-12-28 | 218d? | 52d |  |  | 1556h | 1396h | 118,165.85 | 78,215.62 | 108,228.58 |  |
| 216 | 3.1.3.1 | **Candidate Subsystems** |  | 30d? | 2007-05-21 A | 2007-06-29 A |  | 100% |  | 2007-02-28 | 2007-04-18 | 36d? |  |  |  | 480h | 480h | 37,794.38 | 7,142.9 | 37,794.38 |  |
| 217 | 3.1.3.1.1 | Define Candidate Subsystems |  | 10d? | 2007-05-21 A | 2007-06-01 A |  | 100% |  |  |  |  |  | finish no earlier than 2007-06-01 | Bauman [30%]; Dekany [60%]; Gavel; Neyman; Velur; Wizinowich; Other [75%] | 228h | 228h | 17,341.56 |  | 17,341.56 |  |
| 218 | 3.1.3.1.2 | Subsystems Performance Evaluation |  | 10d? | 2007-06-04 A | 2007-06-15 A | 217 | 100% |  |  |  |  |  | finish no earlier than 2007-06-15 | Dekany [30%]; Gavel; Wizinowich | 72h | 72h | 6,172.8 |  | 6,172.8 |  |
| 219 | 3.1.3.1.3 | Subsystems Cost Evaluation |  | 10d? | 2007-06-04 A | 2007-06-15 A | 217 | 100% |  |  |  |  |  | finish no earlier than 2007-06-15 | Bauman [30%]; Neyman; Velur | 72h | 72h | 5,596.8 |  | 5,596.8 |  |
| 220 | 3.1.3.1.4 | Subsystems Risk Analysis |  | 5d? | 2007-06-18 A | 2007-06-22 A | 217 | 100% |  |  |  |  |  | finish no earlier than 2007-06-22 | Bauman [35%]; Neyman [30%]; Velur | 36h | 36h | 2,798.42 |  | 2,798.42 |  |
| 221 | 3.1.3.1.5 | Organize Candidate Subsystems |  | 5d? | 2007-06-25 A | 2007-06-29 A |  | 100% |  |  |  |  |  | start no earlier than 2007-06-25 | Dekany [30%]; Gavel; Neyman; Wizinowich; Bauman [40%]; Velur [60%] | 72h | 72h | 5,884.8 |  | 5,884.8 |  |
| 222 | 3.1.3.2 | **Candidate Architectures** |  | 30d? | 2007-07-09 A | 2007-08-17 A |  | 100% |  |  |  |  |  |  |  | 556h | 556h | 44,902.62 |  | 44,902.62 |  |
| 223 | 3.1.3.2.1 | Define Candidate Architectures |  | 10d? | 2007-07-09 A | 2007-07-20 A |  | 100% |  |  |  |  |  | start no earlier than 2007-07-09 | Dekany [85%]; Bauman; Gavel; Neyman; Velur; Wizinowich | 328h | 328h | 26,923.04 |  | 26,923.04 |  |
| 224 | 3.1.3.2.2 | Architectures Performance Evaluation |  | 10d? | 2007-07-23 A | 2007-08-03 A | 223 | 100% |  |  |  |  |  | finish no earlier than 2007-08-03 | Dekany [22.5%]; Gavel; Wizinowich; Flicker | 72h | 72h | 5,661.18 |  | 5,661.18 |  |
| 225 | 3.1.3.2.3 | Architectures Cost Evaluation |  | 10d? | 2007-07-23 A | 2007-08-03 A | 223 | 100% |  |  |  |  |  | start no earlier than 2007-07-23 | Bauman [30%]; Neyman; Velur | 72h | 72h | 5,596.8 |  | 5,596.8 |  |
| 226 | 3.1.3.2.4 | Architecture Risk Analysis |  | 5d? | 2007-08-06 A | 2007-08-10 A | 225 | 100% |  |  |  |  |  | start no earlier than 2007-08-06 | Bauman [30%]; Neyman; Velur | 36h | 36h | 2,798.4 |  | 2,798.4 |  |
| 227 | 3.1.3.2.5 | Adopt Baseline Architecture(s) |  | 5d? | 2007-08-13 A | 2007-08-17 A | 226 | 100% |  |  |  |  |  | start no earlier than 2007-08-13 | Bauman [20%]; Dekany; Gavel; Neyman; Velur; Wizinowich | 48h | 48h | 3,923.2 |  | 3,923.2 |  |
| 228 | 3.1.3.3 | **Functional Requirements** |  | 205d? | 2007-05-08 A | 2008-02-15 |  | 53% | 95.55d? | 2007-04-19 | 2007-11-30 | 162d? | 52d |  |  | 480h | 340h | 33,005.91 | 56,474.4 | 24,214.84 |  |
| 229 | 3.1.3.3.1 | Draft Functional Requirements Document |  | 7.35d? | 2007-05-22 A | 2007-05-31 A |  | 100% |  |  |  |  |  | finish no earlier than 2007-05-31 | Wizinowich [34%] | 20h | 20h | 1,146.2 |  | 1,146.2 |  |
| 230 | 3.1.3.3.2 | AO System Functional Requirements Ver 1 |  | 30d? | 2007-07-09 A | 2007-08-17 A | 216 | 100% |  | 2007-04-19 | 2007-05-14 | 17.25d? |  | finish no earlier than 2007-08-17 | Neyman [54.3%]; Dekany [13.3%]; Gavel [13.3%]; Johansson [13.3%]; Wizinowich [34%] | 160h | 160h | 11,898.23 | 12,204.25 | 11,898.23 |  |
| 231 | 3.1.3.3.3 | AO System Functional Requirements Ver 2 |  | 25d? | 2007-10-29 A | 2007-11-30 |  | 50% | 12.5d? | 2007-10-29 | 2007-11-30 | 25d? | 107d | finish no earlier than 2007-11-30 | Neyman [8%]; Dekany [8%]; Gavel [8%]; Wizinowich [8%]; Johansson [8%] | 80h | 40h | 5,949.12 | 6,176.35 | 2,974.56 |  |
| 232 | 3.1.3.3.4 | Laser System Functional Requirements Ver 1 |  | 20d? | 2007-07-09 A | 2007-08-03 A | 216 | 100% |  | 2007-04-19 | 2007-05-16 | 20d? |  | finish no earlier than 2007-08-03 | Chin [34.4%]; Velur [34.4%]; Johansson [20%] | 96h | 96h | 6,512.32 | 9,473.75 | 6,512.32 |  |
| 233 | 3.1.3.3.5 | Laser System Functional Requirements Ver 2 |  | 25d? | 2007-10-29 A | 2007-11-30 |  | 39% | 15.24d? | 2007-10-29 | 2007-11-30 | 25d? | 0d | finish no earlier than 2007-11-30 | Neyman [12.5%]; Velur [12.5%]; Johansson [8%] | 48h | 24h | 3,508.8 | 4,514.65 | 1,683.53 |  |
| 234 | 3.1.3.3.6 | Science Operations Functional Requirements Ver 1 |  | 10d? | 2007-12-03 | 2007-12-14 | 216 |  |  | 2007-04-19 | 2007-05-22 | 24d? | 97d | start no earlier than 2007-12-03 | Le Mignant [25%]; Wizinowich [31.2%]; McGrath | 30h |  | 1,582.68 | 5,731 |  |  |
| 235 | 3.1.3.3.7 | Science Operations Functional Requirements Ver 2 |  | 10d? | 2008-02-04 | 2008-02-15 |  |  |  | 2007-10-29 | 2007-11-30 | 25d? | 52d | finish no earlier than 2008-02-15 | Le Mignant [25%]; McGrath [30%] | 30h |  | 1,491.6 | 5,731 |  |  |
| 236 | 3.1.3.3.8 | Science Instruments Function Allocation Ver 1 |  | 18d? | 2007-05-08 | 2007-05-31 | 322 |  |  | 2007-04-19 | 2007-05-14 | 18d? | 239d | finish no earlier than 2007-05-31 | Adkins [4.2%]; Wizinowich [34.7%] | 8h |  | 458.48 | 6,163.8 |  | Moore |
| 237 | 3.1.3.3.9 | Science Instruments Function Allocation Ver 2 |  | 3.75d? | 2008-01-14 | 2008-01-17 | 325 |  |  | 2007-10-29 | 2007-11-14 | 12.5d? | 73.25d | finish no earlier than 2007-06-29 | Adkins [20%]; Wizinowich [60%] | 8h |  | 458.48 | 6,479.6 |  | Moore |
| 238 | 3.1.3.4 | Technology Drivers Summary | milestone | 0d? | 2007-10-25 | 2007-10-25 |  |  |  | 2007-07-23 | 2007-07-26 | 3.63d? | 133d | finish no earlier than 2007-10-25 | Gavel [55.1%] |  |  |  | 3,151.44 |  |  |
| 239 | 3.1.3.5 | Technical Risk Analysis Ver 1 |  | 15d? | 2007-08-27 A | 2007-09-14 A |  | 100% |  | 2007-07-26 | 2007-08-28 | 23d? |  | finish no earlier than 2007-09-14 | Neyman [8.3%]; Wizinowich [34%]; Dekany [35%]; Gavel [35%] | 20h | 20h | 1,316.74 | 3,151.44 | 1,316.74 |  |
| 240 | 3.1.3.6 | Technical Risk Analysis Ver 2 |  | 12d? | 2008-01-16 | 2008-01-31 |  |  |  | 2007-12-03 | 2007-12-28 | 20d? | 63d | finish no earlier than 2008-01-31 | Neyman [10.4%]; Wizinowich [40%] | 20h |  | 1,146.2 | 3,151.44 |  |  |

Notes:
- 211: RF
- 212: VV
- 213: DG
- 214: CN
- 215: RD
- 216: RD
- 217: RD
- 218: RD
- 219: CN
- 220: CN
- 221: RD
- 222: RD
- 223: RD
- 224: RD
- 225: CN
- 226: CN
- 227: RD
- 228: PW
- 229: PW
- 230: CN
- 231: CN
- 232: JC
- 233: CN
- 234: DLM
- 235: DLM
- 236: SA
- 237: SA
- 238: Cancel
- 239: CN
- 240: CN

| ID | WBS | Task | Duration | Start | Finish | Predecessors | Complete | Remaining | Baseline start | Baseline finish | Baseline duration | Total slack | Free slack | Constraint | Resources | Work | Actual work | Cost | Baseline cost | Actual cost | Text1 |
| --- | --- | --- | --- | --- | --- | --- | --- | --- | --- | --- | --- | --- | --- | --- | --- | --- | --- | --- | --- | --- | --- |
| 241 | 3.2 | **AO System** | 145d? | 2007-05-29 A | 2007-12-14 |  | 68% | 46.94d? | 2007-03-05 | 2007-12-14 | 205d? | 97d |  |  |  | 1269h | 925.02h | 90,060.37 | 122,338.8 | 68,176.6 |  |
| 242 | 3.2.1 | AO System Architecture | 60d? | 2007-09-04 A | 2007-11-23 A |  | 100% |  | 2007-04-19 | 2007-06-20 | 45d? |  |  | start no earlier than 2007-09-04 | Gavel [8.3%] | 40h | 40h | 4,440 | 18,447.5 | 4,440 | let's discuss |
| 243 | 3.2.2 | AO Enclosure | 28d? | 2007-10-01 A | 2007-11-07 |  | 75% | 7d? | 2007-05-14 | 2007-08-17 | 70d? | 124d |  | start no earlier than 2007-10-01 | Meguro [17.9%] | 40h | 30h | 2,292.4 | 5,731 | 1,719.3 |  |
| 244 | 3.2.3 | **Opto-mechanical** | 145d? | 2007-05-29 A | 2007-12-14 |  | 72% | 40.35d? | 2007-04-02 | 2007-12-14 | 185d? | 97d |  |  |  | 781h | 603.52h | 58,854.6 | 54,627.7 | 46,709.8 |  |
| 245 | 3.2.3.1 | Field Rotation | 45d? | 2007-09-04 A | 2007-11-02 |  | 90% | 4.5d? | 2007-04-16 | 2007-08-08 | 82.5d? | 18.84d | 8d | start no earlier than 2007-09-04 | Kupke [8.3%]; Lockwood [4.2%] | 45h | 40.5h | 3,234 | 4,119 | 2,910.6 |  |
| 246 | 3.2.3.2 | Optical Relay | 45d? | 2007-09-04 A | 2007-11-02 |  | 88% | 5.4d? | 2007-04-16 | 2007-08-15 | 88d? | 0d |  | start no earlier than 2007-09-04 | Kupke [11.1%]; Lockwood [3.4%]; Dekany [2.8%] | 60h | 54h | 4,194.9 | 5,374.9 | 3,812.23 |  |
| 247 | 3.2.3.3 | Optical Switchyard | 45d? | 2007-09-04 A | 2007-11-02 |  | 90% | 4.5d? | 2007-04-16 | 2007-06-29 | 55d? | 18.84d | 8d | start no earlier than 2007-09-04 | Kupke [6.9%]; Lockwood [6.9%] | 50h | 45h | 3,952.5 | 4,690 | 3,557.25 |  |
| 248 | 3.2.3.4 | Optical Support Structure | 12d? | 2007-11-15 A | 2007-11-30 | 245, 246, 247 | 90% | 1.16d? | 2007-10-01 | 2007-11-16 | 35d? | 0d |  | finish no earlier than 2007-11-30 | Lockwood [32.4%]; Bauman [9.4%] | 30h | 27h | 3,018 | 4,323 | 2,716.19 |  |
| 249 | 3.2.3.5 | **Wavefront Sensors** | 63.14d? | 2007-08-22 A | 2007-11-16 |  | 89% | 6.84d? | 2007-05-07 | 2007-12-12 | 158d? | 117d |  |  |  | 240h | 216h | 18,491.4 | 17,228.2 | 16,663.31 |  |
| 250 | 3.2.3.5.1 | High Order LGS Wavefront Sensors | 63.14d? | 2007-08-22 A | 2007-11-16 | 205, 206 | 90% | 6.31d? | 2007-05-07 | 2007-12-12 | 158d? | 117d |  | finish no earlier than 2007-11-16 | Velur [11.9%]; Bell [4%] | 80h | 72h | 6,479.6 | 6,479.6 | 5,831.63 |  |
| 251 | 3.2.3.5.2 | High Order NGS Wavefront Sensor | 63.14d? | 2007-08-22 A | 2007-11-16 |  | 90% | 6.31d? | 2007-05-07 | 2007-12-12 | 158d? | 117d |  | finish no earlier than 2007-11-16 | Velur [5.9%]; Bell [2%] | 40h | 36h | 3,239.8 | 3,239.8 | 2,915.81 |  |
| 252 | 3.2.3.5.3 | Low Order NGS Wavefront Sensors | 63.14d? | 2007-08-22 A | 2007-11-16 | 207, 208 | 87% | 8.42d? | 2007-05-07 | 2007-12-12 | 158d? | 117d |  | finish no earlier than 2007-11-16 | Kellner [3.2%]; Bell [4%]; Velur [7.9%]; Moore [40%] | 80h | 72h | 6,479.6 | 5,216.4 | 5,852.7 |  |
| 253 | 3.2.3.5.4 | Calibration Wavefront Sensor | 63.14d? | 2007-08-22 A | 2007-11-16 |  | 90% | 6.31d? | 2007-05-28 | 2007-12-12 | 143d? | 117d |  | finish no earlier than 2007-11-16 | Neyman [7.9%] | 40h | 36h | 2,292.4 | 2,292.4 | 2,063.16 |  |
| 254 | 3.2.3.6 | **Wavefront Correctors** | 81d? | 2007-08-13 A | 2007-11-30 |  | 40% | 48.97d? | 2007-04-02 | 2007-11-30 | 175d? | 0d |  |  |  | 75h | 10.27h | 4,566.7 | 10,752.2 | 611.75 |  |
| 255 | 3.2.3.6.1 | Tip/Tilt Corrector | 45d? | 2007-10-01 A | 2007-11-30 | 257 | 90% | 4.5d? | 2007-10-01 | 2007-11-30 | 45d? | 0d |  | start no earlier than 2007-10-01 | Neyman [2.8%]; Bauman [2.8%] | 10h | 9h | 573.1 | 1,443.1 | 515.79 |  |
| 256 | 3.2.3.6.2 | Deformable Mirror | 31d? | 2007-08-13 A | 2007-09-21 |  | 2% | 30.38d? | 2007-04-02 | 2007-06-29 | 65d? | 0d |  | start no earlier than 2007-08-13 | Neyman [16.1%]; Bauman [11.8%] | 40h | 0.8h | 2,292.4 | 9,309.1 | 45.85 |  |
| 257 | 3.2.3.6.3 | Tip/tilt Vibration Mitigation | 28.14d? | 2007-08-22 A | 2007-09-28 |  |  | 28.09d? |  |  |  | 0d |  | finish no earlier than 2007-09-28 | Neyman [8.9%]; Johansson; Gavel | 25h | 0.47h | 1,701.2 |  | 50.11 |  |
| 258 | 3.2.3.7 | **Acquisition Cameras** | 20d? | 2007-10-01 A | 2007-10-26 |  | 75% | 5d? | 2007-10-01 | 2007-10-26 | 20d? | 132d |  |  |  | 40h | 30h | 2,292.4 | 3,555.6 | 1,719.3 |  |
| 259 | 3.2.3.7.1 | NGS Acquisition Camera | 20d? | 2007-10-01 A | 2007-10-26 |  | 75% | 5d? | 2007-10-01 | 2007-10-26 | 20d? | 132d |  | finish no earlier than 2007-10-26 | Neyman [12.5%] | 20h | 15h | 1,146.2 | 1,777.8 | 859.65 |  |
| 260 | 3.2.3.7.2 | LGS Acquisition Camera | 20d? | 2007-10-01 A | 2007-10-26 |  | 75% | 5d? | 2007-10-01 | 2007-10-26 | 20d? | 132d |  | finish no earlier than 2007-10-26 | Neyman [12.5%] | 20h | 15h | 1,146.2 | 1,777.8 | 859.65 |  |
| 261 | 3.2.3.8 | Atmospheric Dispersion Correction | 85d? | 2007-08-21 A | 2007-12-14 |  | 40% | 51d? | 2007-08-20 | 2007-12-14 | 85d? | 0d |  | finish no earlier than 2007-12-14 | Bauman [2.9%]; Dekany [35%] | 24h | 12h | 2,095.55 | 1,146.2 | 1,051.56 |  |
| 262 | 3.2.3.9 | Alignment, Calibration, Diagnostics, Metrology and Monitoring | 48d? | 2007-05-29 A | 2007-08-02 |  | 38% | 30d? | 2007-04-02 | 2007-06-29 | 65d? | 0d |  | finish no earlier than 2007-06-29 | Neyman [10.4%]; Flicker [10.4%]; Le Mignant [10.4%] | 60h | 30h | 3,438.6 | 3,438.6 | 1,719.3 |  |
| 263 | 3.2.3.10 | Atmospheric Profiler | 2.41d? | 2007-08-22 A | 2007-10-02 A |  | 100% |  |  |  |  |  |  | finish no earlier than 2007-10-02 | Britton [20.7%]; Gavel [35%]; Neyman [83%] | 12h | 12h | 1,028.8 |  | 1,028.8 |  |
| 264 | 3.2.3.11 | d-IFU & LOWFS AO & Object Selection | 82.93d? | 2007-08-23 A | 2007-12-14 |  | 83% | 13.82d? |  |  |  | 0d |  | finish no earlier than 2007-12-14 | Moore [10.9%]; Gavel; Bell; Velur [75%] | 120h | 108h | 10,477.4 |  | 9,410.72 |  |
| 265 | 3.2.3.12 | PSF Monitoring Camera | 40d? | 2007-10-01 A | 2007-11-23 |  | 69% | 12.5d? |  |  |  | 0d |  | start no earlier than 2007-10-01 | Britton [6.2%]; Neyman | 25h | 18.75h | 2,064.35 |  | 1,508.79 |  |

Notes:
- 241: DG
- 242: DG
- 243: JM
- 244: BB
- 245: CL
- 246: RK
- 247: RK
- 248: CL
- 249: VV
- 250: VV
- 251: VV
- 252: VV
- 253: CN
- 254: CN
- 255: CN
- 256: CN
- 257: CN
- 258: CN
- 259: CN
- 260: CN
- 261: RD
- 262: CN
- 263: MB
- 264: DG
- 265: MB

| ID | WBS | Task | Duration | Start | Finish | Predecessors | Complete | Remaining | Baseline start | Baseline finish | Baseline duration | Total slack | Constraint | Resources | Work | Actual work | Cost | Baseline cost | Actual cost | Text1 |
| --- | --- | --- | --- | --- | --- | --- | --- | --- | --- | --- | --- | --- | --- | --- | --- | --- | --- | --- | --- | --- |
| 266 | 3.2.4 | **Non-real-time Control** | 110d? | 2007-06-25 A | 2007-11-22 |  | 10% | 98.48d? | 2007-06-25 | 2007-11-23 | 110d? | 0d |  |  | 178h | 44.5h | 10,201.17 | 22,943 | 2,550.29 |  |
| 267 | 3.2.4.1 | Non-RTC Software | 50d? | 2007-06-25 A | 2007-08-31 |  | 18% | 41.13d? | 2007-06-25 | 2007-08-31 | 50d? | 0d | finish no earlier than 2007-08-31 | Johansson [20%]; Stomski [20%]; Johnson [10%] | 106h | 26.5h | 6,074.86 | 11,462 | 1,518.71 |  |
| 268 | 3.2.4.2 | Non-RTC Electronics | 90d? | 2007-07-23 A | 2007-11-22 |  | 6% | 84.21d? | 2007-07-23 | 2007-11-23 | 90d? | 0d | finish no earlier than 2007-11-22 | Chin [8.3%]; Reinig [8.3%]; Johansson [33%] | 72h | 18h | 4,126.31 | 11,481 | 1,031.58 |  |
| 269 | 3.2.5 | **Real-time Control** | 90d? | 2007-08-01 A | 2007-12-03 |  | 82% | 16.5d? | 2007-03-05 | 2007-08-07 | 112d? | 0d |  |  | 230h | 207h | 14,272.2 | 20,589.6 | 12,757.21 |  |
| 270 | 3.2.5.1 | RTC Architecture Analysis and Design Study | 23d? | 2007-08-01 A | 2007-08-31 |  | 82% | 4.21d? | 2007-03-05 | 2007-05-04 | 45d? | 0d | finish no earlier than 2007-08-31 | Gavel [10.9%]; Johansson [21.7%]; Flicker [21.7%]; Reinig [43.5%] | 110h | 99h | 7,387.4 | 11,404.8 | 6,560.13 |  |
| 271 | 3.2.5.2 | RTC Software Module Definition | 67d? | 2007-09-03 A | 2007-12-03 | 270 | 88% | 7.82d? | 2007-05-07 | 2007-08-07 | 67d? | 0d | finish no earlier than 2007-11-19 | Johansson [11.2%]; Reinig [3.7%] | 70h | 63h | 4,013.6 | 4,588.6 | 3,612.43 |  |
| 272 | 3.2.5.3 | RTC Hardware Module Definition | 67d? | 2007-09-03 A | 2007-12-03 | 270 | 75% | 16.75d? | 2007-05-07 | 2007-08-07 | 67d? | 0d | finish no earlier than 2007-11-19 | Johansson [3.7%]; Reinig [11.2%] | 50h | 45h | 2,871.2 | 4,596.2 | 2,584.65 |  |
| 273 | 3.3 | **Laser Facility** | 99d? | 2007-08-06 A | 2007-12-19 |  | 58% | 41.27d? | 2007-03-06 | 2007-12-14 | 204d? | 94d |  |  | 465h | 293.75h | 32,522.92 | 52,456.5 | 21,516.51 | Discuss; JC? |
| 274 | 3.3.1 | Laser System Architecture | 41d? | 2007-08-27 A | 2007-10-19 A | 179, 210, 177 | 100% |  | 2007-03-06 | 2007-05-14 | 50d? |  | finish no earlier than 2007-10-19 | Velur [24.4%] | 80h | 80h | 7,111.2 | 7,111.2 | 7,111.2 |  |
| 275 | 3.3.2 | Laser Enclosure | 43d? | 2007-10-22 A | 2007-12-19 | 274 | 72% | 12.09d? | 2007-05-15 | 2007-07-12 | 43d? | 94d | finish no earlier than 2007-12-19 | Bell [23.3%] | 40h | 30h | 2,292.4 | 4,584.8 | 1,719.3 |  |
| 276 | 3.3.3 | Laser | 35d? | 2007-10-22 A | 2007-12-07 | 274 | 50% | 17.5d? | 2007-05-15 | 2007-07-02 | 35d? | 102d | finish no earlier than 2007-09-27 | Velur [7.1%] | 20h | 10h | 1,777.8 | 8,889 | 888.9 |  |
| 277 | 3.3.4 | **Laser Launch Facility** | 25d? | 2007-08-06 A | 2007-09-07 |  | 70% | 7.55d? | 2007-04-09 | 2007-06-01 | 40d? | 0d |  |  | 171h | 128.25h | 12,515.89 | 20,982.6 | 9,189.54 | ch name back |
| 278 | 3.3.4.1 | Laser Beam Transport | 25d? | 2007-08-06 A | 2007-09-07 |  | 75% | 6.25d? | 2007-04-09 | 2007-06-01 | 40d? | 0d | finish no earlier than 2007-09-07 | Neyman [15%]; Velur [8%]; Chin [2%] | 46h | 34.5h | 3,141.54 | 3,438.6 | 2,356.16 |  |
| 279 | 3.3.4.2 | Laser Pointing & Diagnostics | 25d? | 2007-08-06 A | 2007-09-07 |  | 59% | 10.16d? | 2007-04-09 | 2007-06-01 | 40d? | 0d | start no earlier than 2007-08-06 | Velur [20%]; Neyman [21.9%]; Chin [6.2%]; Bauman [22%] | 65h | 48.75h | 4,988.35 | 9,087.8 | 3,543.89 | add AM |
| 280 | 3.3.4.3 | Laser Launch Telescope | 25d? | 2007-08-06 A | 2007-09-07 | 211 | 75% | 6.25d? | 2007-04-09 | 2007-06-01 | 40d? | 0d | start no earlier than 2007-08-06 | Velur [15%]; Neyman [15%]; Chin [11.1%] | 60h | 45h | 4,386 | 8,456.2 | 3,289.5 |  |
| 281 | 3.3.5 | **Laser Safety Systems** | 20d? | 2007-10-08 A | 2007-11-02 |  | 68% | 6.44d? | 2007-10-08 | 2007-11-02 | 20d? | 127d |  |  | 14h | 10.5h | 802.3 | 2,292.4 | 601.74 |  |
| 282 | 3.3.5.1 | Personnel and Equipment Safety Systems | 6d? | 2007-10-08 A | 2007-11-02 |  | 75% | 1.5d? | 2007-10-08 | 2007-11-02 | 20d? | 127d | finish no earlier than 2007-11-02 | Neyman [12.5%] | 6h | 4.5h | 343.86 | 1,146.2 | 257.89 |  |
| 283 | 3.3.5.2 | Aircraft, Satellite & Laser Traffic Control Safety Systems | 2d? | 2007-10-08 A | 2007-11-02 |  | 46% | 1.07d? | 2007-10-08 | 2007-11-02 | 20d? | 127d | finish no earlier than 2007-11-02 | Summers [12.5%]; Neyman [83%] | 8h | 6h | 458.44 | 1,146.2 | 343.85 |  |
| 284 | 3.3.6 | **Laser System Control** | 55d? | 2007-10-01 A | 2007-12-14 |  | 21% | 43.49d? | 2007-10-01 | 2007-12-14 | 55d? | 97d |  |  | 140h | 35h | 8,023.33 | 8,596.5 | 2,005.82 |  |
| 285 | 3.3.6.1 | Laser System Software | 55d? | 2007-10-01 A | 2007-12-14 |  | 25% | 41.25d? | 2007-10-01 | 2007-12-14 | 55d? | 97d | finish no earlier than 2007-12-14 | Johansson [9.1%]; Stomski [9.1%] | 80h | 20h | 4,584.8 | 4,584.8 | 1,146.2 |  |
| 286 | 3.3.6.2 | Laser System Electronics | 23.57d? | 2007-10-01 A | 2007-12-14 |  | 11% | 20.88d? | 2007-10-01 | 2007-12-14 | 55d? | 97d | finish no earlier than 2007-12-14 | Chin [15.9%]; Neyman [83%] | 60h | 15h | 3,438.53 | 4,011.7 | 859.62 |  |
| 287 | 3.4 | **Science Operations** | 150d? | 2007-05-22 A | 2007-12-14 |  | 5% | 141.94d? | 2007-01-02 | 2007-12-14 | 249d? | 97d |  |  | 390h | 34h | 20,198.59 | 32,477.5 | 1,329.47 |  |
| 288 | 3.4.1 | **Astronomical Observations Operations** | 146d? | 2007-05-28 A | 2007-12-14 |  | 10% | 132.09d? | 2007-03-01 | 2007-12-14 | 207d? | 97d |  |  | 230h | 30.6h | 12,167.5 | 8,054.2 | 1,157.39 |  |
| 289 | 3.4.1.1 | **Pre-Observing Interfaces** | 22d? | 2007-07-26 A | 2007-08-24 |  | 50% | 11d? | 2007-05-01 | 2007-05-30 | 22d? | 178d |  |  | 60h | 24h | 2,072.4 | 2,072.4 | 828.96 |  |
| 290 | 3.4.1.1.1 | AO Guide Star Interface | 22d? | 2007-07-26 A | 2007-08-24 |  | 80% | 4.4d? | 2007-05-01 | 2007-05-30 | 22d? | 178d | start no earlier than 2007-07-26 | McGrath [11.4%] | 20h | 16h | 690.8 | 690.8 | 552.64 | assigned |
| 291 | 3.4.1.1.2 | Science Observations Simulation Tools | 22d? | 2007-07-26 A | 2007-08-24 |  | 20% | 17.6d? | 2007-05-01 | 2007-05-30 | 22d? | 178d | start no earlier than 2007-07-26 | McGrath [22.7%] | 40h | 8h | 1,381.6 | 1,381.6 | 276.32 | assigned |

Notes:
- 266: EJ
- 267: EJ
- 268: EJ
- 269: DG
- 270: DG
- 271: EJ
- 272: MR
- 273: CN
- 274: VV
- 275: JB
- 276: DG
- 277: VV
- 278: CN
- 279: VV
- 280: VV
- 281: CN
- 282: CN
- 283: CN
- 284: JC
- 285: EJ
- 286: CN
- 287: DLM
- 288: DLM
- 289: DLM
- 290: EM
- 291: EM

| ID | WBS | Task | Type | Duration | Start | Finish | Complete | Remaining | Baseline start | Baseline finish | Baseline duration | Total slack | Constraint | Resources | Work | Actual work | Cost | Baseline cost | Actual cost | Text1 |
| --- | --- | --- | --- | --- | --- | --- | --- | --- | --- | --- | --- | --- | --- | --- | --- | --- | --- | --- | --- | --- |
| 292 | 3.4.1.2 | **Observing Interfaces** |  | 146d? | 2007-05-28 A | 2007-12-14 | 6% | 136.82d? | 2007-03-01 | 2007-12-14 | 207d? | 97d |  |  | 60h | 4.4h | 2,527.8 | 3,218.6 | 161.08 |  |
| 293 | 3.4.1.2.1 | Acquisition |  | 43d? | 2007-05-28 A | 2007-07-25 | 10% | 38.7d? | 2007-03-01 | 2007-04-30 | 43d? | 200d | finish no earlier than 2007-07-25 | McGrath [5.8%] | 20h | 2h | 690.8 | 690.8 | 69.08 | assigned |
| 294 | 3.4.1.2.2 | Observing Sequences |  | 43d? | 2007-05-28 A | 2007-07-25 | 10% | 38.7d? | 2007-03-01 | 2007-04-30 | 43d? | 200d | start no earlier than 2007-05-28 | McGrath [5.8%] | 20h | 2h | 690.8 | 690.8 | 69.08 | assigned |
| 295 | 3.4.1.2.3 | Instrument, AO & Telescope Observer Interfaces |  | 43d? | 2007-05-28 A | 2007-07-25 | 1% | 42.57d? | 2007-03-01 | 2007-04-30 | 43d? | 200d | finish no earlier than 2007-07-25 | Le Mignant [5.8%] | 10h | 0.2h | 573.1 | 1,146.2 | 11.46 | assigned |
| 296 | 3.4.1.2.4 | Science Data Quality Monitoring |  | 21.5d? | 2007-10-17 A | 2007-12-14 | 2% | 21.07d? | 2007-10-17 | 2007-12-14 | 43d? | 97d | finish no earlier than 2007-12-14 | Le Mignant [5.8%] | 10h | 0.2h | 573.1 | 690.8 | 11.46 | assigned |
| 297 | 3.4.1.3 | **Post-Observing Interfaces** |  | 45d? | 2007-10-01 A | 2007-11-30 | 1% | 44.63d? | 2007-10-01 | 2007-11-27 | 42d? | 107d |  |  | 110h | 2.2h | 7,567.3 | 2,763.2 | 167.35 |  |
| 298 | 3.4.1.3.1 | Generic Data Products |  | 42d? | 2007-10-01 A | 2007-11-27 | 1% | 41.58d? | 2007-10-01 | 2007-11-27 | 42d? | 110d | finish no earlier than 2007-11-27 | Le Mignant [6%] | 10h | 0.2h | 573.1 | 690.8 | 11.46 | assigned |
| 299 | 3.4.1.3.2 | Science Data Quality Assessment |  | 42d? | 2007-10-01 A | 2007-11-27 | 1% | 41.58d? | 2007-10-01 | 2007-11-27 | 42d? | 110d | finish no earlier than 2007-11-27 | Le Mignant [6%] | 10h | 0.2h | 573.1 | 690.8 | 11.46 | assigned |
| 300 | 3.4.1.3.3 | Science Data Archiving |  | 42d? | 2007-10-01 A | 2007-11-27 | 1% | 41.79d? | 2007-10-01 | 2007-11-27 | 42d? | 110d | finish no earlier than 2007-11-27 | Le Mignant [11.9%] | 10h | 0.2h | 573.1 | 1,381.6 | 11.46 | assigned |
| 301 | 3.4.1.3.4 | PSF Reconstruction |  | 22.5d? | 2007-10-01 A | 2007-11-30 | 1% | 22.34d? |  |  |  | 107d | finish no earlier than 2007-11-30 | Le Mignant [22.2%]; Britton | 80h | 1.6h | 5,848 |  | 132.96 |  |
| 302 | 3.4.2 | **AO-Instrument Operations** |  | 115d? | 2007-05-22 A | 2007-10-26 | 2% | 113.24d? | 2007-01-02 | 2007-10-26 | 214d? | 132d |  |  | 160h | 3.4h | 8,031.09 | 24,423.3 | 172.08 |  |
| 303 | 3.4.2.1 | **AO-Instrument Operations Architecture** |  | 115d? | 2007-05-22 A | 2007-10-26 | 2% | 113.05d? | 2007-01-02 | 2007-10-26 | 214d? | 132d |  |  | 140h | 3h | 6,884.89 | 14,107.5 | 149.16 |  |
| 304 | 3.4.2.1.1 | AO-Instrument Observing Modes |  | 24d? | 2007-05-22 A | 2007-06-22 | 2% | 23.64d? | 2007-01-02 | 2007-02-02 | 24d? | 223d | finish no earlier than 2007-06-22 | Le Mignant [20.8%]; McGrath [20.8%] | 50h | 1.2h | 2,182.4 | 3,674 | 55.11 | assigned |
| 305 | 3.4.2.1.2 | AO-Instrument Operations Support |  | 7.5d? | 2007-06-25 A | 2007-07-13 | 2% | 7.35d? | 2007-02-05 | 2007-05-30 | 83d? | 208d | finish no earlier than 2007-07-13 | Le Mignant [16.7%] | 10h | 0.2h | 573.1 | 1,146.2 | 11.46 | assigned |
| 306 | 3.4.2.1.3 | AO-Instrument Configuration & Setup |  | 41.5d? | 2007-07-05 A | 2007-10-26 | 2% | 40.67d? | 2007-07-04 | 2007-10-26 | 83d? | 132d | finish no earlier than 2007-10-26 | Le Mignant [3%] | 10h | 0.2h | 573.1 | 1,146.2 | 11.46 | assigned |
| 307 | 3.4.2.1.4 | AO-Instrument Calibrations |  | 83d? | 2007-06-04 A | 2007-09-25 | 1% | 82.17d? | 2007-06-04 | 2007-09-26 | 83d? | 155d | finish no earlier than 2007-09-25 | Le Mignant [3%] | 10h | 0.2h | 573.1 | 1,146.2 | 11.46 | assigned |
| 308 | 3.4.2.1.5 | AO-Instrument Nighttime Operation Modes |  | 41.5d? | 2007-06-04 A | 2007-09-25 | 2% | 40.67d? | 2007-06-04 | 2007-09-26 | 83d? | 155d | finish no earlier than 2007-09-25 | Le Mignant [3%] | 10h | 0.2h | 573.1 | 1,146.2 | 11.46 | assigned |
| 309 | 3.4.2.1.6 | AO-Instrument Science Acquisition & Control |  | 83d? | 2007-07-02 A | 2007-10-23 | 2% | 81.34d? | 2007-07-02 | 2007-10-24 | 83d? | 135d | finish no earlier than 2007-10-23 | McGrath [3%] | 20h | 0.4h | 690.8 | 690.8 | 13.82 | assigned |
| 310 | 3.4.2.1.7 | AO-Instrument Health Monitoring & Automated Recovery | milestone | 0d? | 2007-10-02 | 2007-10-02 |  |  | 2007-06-11 | 2007-10-03 | 83d? | 150d | finish no earlier than 2007-10-02 | Johansson [3%] |  |  |  | 1,146.2 |  | assigned |
| 311 | 3.4.2.1.8 | AO-Instrument Laser Traffic Control |  | 20d? | 2007-10-01 A | 2007-10-26 | 2% | 19.6d? | 2007-10-01 | 2007-10-26 | 20d? | 132d | start no earlier than 2007-10-01 | Summers [6.2%] | 10h | 0.2h | 573.1 | 573.1 | 11.46 |  |
| 312 | 3.4.2.1.9 | AO-Instrument User Interfaces |  | 10d? | 2007-10-01 A | 2007-10-26 | 2% | 9.8d? | 2007-10-01 | 2007-10-26 | 20d? | 132d | finish no earlier than 2007-10-26 | Johansson [25%] | 20h | 0.4h | 1,146.2 | 2,292.4 | 22.92 | assigned |
| 313 | 3.4.2.1.10 | AO-Instrument Maintenance Plan | milestone | 0d? | 2007-10-26 | 2007-10-26 |  |  | 2007-10-01 | 2007-10-26 | 20d? | 132d | finish no earlier than 2007-10-26 | Johansson [12.5%] |  |  |  | 1,146.2 |  | assigned |
| 314 | 3.4.2.2 | **AO-Instrument Operations Optimization** |  | 30d? | 2007-06-18 A | 2007-07-27 | 1% | 29.8d? | 2007-03-05 | 2007-05-04 | 45d? | 198d |  |  | 20h | 0.4h | 1,146.2 | 10,315.8 | 22.92 |  |
| 315 | 3.4.2.2.1 | AO-Instrument Performance Prediction |  | 30d? | 2007-06-18 A | 2007-07-27 |  | 29.9d? | 2007-03-05 | 2007-04-13 | 30d? | 0d | finish no earlier than 2007-07-27 | Le Mignant [25%]; Johansson [8.3%] | 10h | 0.2h | 573.1 | 4,584.8 | 11.46 | assigned |
| 316 | 3.4.2.2.2 | AO-Instrument Real-Time Optimization |  | 30d? | 2007-06-18 A | 2007-07-27 | 1% | 29.7d? | 2007-03-05 | 2007-04-13 | 30d? | 198d | finish no earlier than 2007-07-27 | Johansson [25%]; Le Mignant [8.3%] | 10h | 0.2h | 573.1 | 4,584.8 | 11.46 | assigned |
| 317 | 3.4.2.2.3 | AO-Instrument Environment Monitoring | milestone | 0d? | 2007-07-06 | 2007-07-06 |  |  | 2007-04-16 | 2007-05-04 | 15d? | 213d | finish no earlier than 2007-07-06 | Johansson [16.7%] |  |  |  | 1,146.2 |  | assigned |

Notes:
- 292: DLM
- 293: EM
- 294: EM
- 295: DLM
- 296: DLM
- 297: DLM
- 298: DLM
- 299: DLM
- 300: DLM
- 301: DLM
- 302: DLM
- 303: DLM
- 304: DLM
- 305: DLM
- 306: DLM
- 307: DLM
- 308: DLM
- 309: EM
- 310: Cancel
- 311: DS
- 312: EJ
- 313: Cancel
- 314: DLM
- 315: DLM
- 316: DLM
- 317: Cancel

| ID | WBS | Task | Duration | Start | Finish | Predecessors | Complete | Remaining | Baseline start | Baseline finish | Baseline duration | Total slack | Free slack | Constraint | Resources | Work | Actual work | Cost | Baseline cost | Actual cost |
| --- | --- | --- | --- | --- | --- | --- | --- | --- | --- | --- | --- | --- | --- | --- | --- | --- | --- | --- | --- | --- |
| 318 | 3.5 | **Science Instruments** | 346d? | 2006-10-02 A | 2008-01-25 |  | 54% | 158.16d? | 2006-10-02 | 2007-11-16 | 295d? | 67d |  |  |  | 488h | 339.26h | 32,906.4 | 93,446.34 | 24,186.58 |
| 319 | 3.5.1 | **Instrument Requirements & Initial Definitions** | 211d? | 2007-04-09 A | 2008-01-25 |  | 43% | 119.53d? |  |  |  | 67d |  |  |  | 72h | 32.4h | 4,126.32 |  | 1,856.83 |
| 320 | 3.5.1.1 | Top Level Instrument Requirements & Definitions | 20d? | 2007-04-09 A | 2007-05-04 |  | 75% | 5d? |  |  |  | 239d | 0d | finish no earlier than 2007-05-04 | Adkins [10%] | 16h | 12h | 916.96 |  | 687.72 |
| 321 | 3.5.1.2 | **Instrument Suite Version 1** | 13.5d? | 2007-05-07 A | 2007-05-24 |  | 93% | 1d? |  |  |  | 226.5d |  |  |  | 13h | 10h | 745.03 |  | 573.1 |
| 322 | 3.5.1.2.1 | Instrument Function Allocation Review with Science Team | 1d? | 2007-05-07 | 2007-05-07 | 320 |  |  |  |  |  | 239d | 0d | finish no earlier than 2007-05-07 | Adkins [37.5%] | 3h |  | 171.93 |  |  |
| 323 | 3.5.1.2.2 | Summary Descriptions of Instruments | 12.5d? | 2007-05-08 A | 2007-05-24 A | 322 | 100% |  |  |  |  |  |  | start no earlier than 2007-05-08 | Adkins [10%] | 10h | 10h | 573.1 |  | 573.1 |
| 324 | 3.5.1.3 | **Instrument Suite Version 2** | 12d? | 2008-01-10 A | 2008-01-25 |  | 25% | 9d? |  |  |  | 67d |  |  |  | 11h | 2.4h | 630.41 |  | 137.54 |
| 325 | 3.5.1.3.1 | Instrument Review with Science Team | 2d? | 2008-01-10 | 2008-01-11 |  |  |  |  |  |  | 67d | 0d | start no earlier than 2008-01-10 | Adkins [18.8%] | 3h |  | 171.93 |  |  |
| 326 | 3.5.1.3.2 | Revised Summary Descriptions of Instruments | 10d? | 2008-01-14 A | 2008-01-25 | 325 | 30% | 7d? |  |  |  | 67d |  | start no earlier than 2008-01-14 | Adkins [10%] | 8h | 2.4h | 458.48 |  | 137.54 |
| 327 | 3.5.1.4 | **Instrument Interfaces** | 18d? | 2007-06-06 A | 2007-06-29 |  | 3% | 17.38d? |  |  |  | 218d |  |  |  | 32h | 8h | 1,833.92 |  | 458.47 |
| 328 | 3.5.1.4.1 | Hardware Instrument Interfaces | 13d? | 2007-06-06 A | 2007-06-22 |  | 7% | 12.07d? |  |  |  | 223d |  | start no earlier than 2007-06-06 | Adkins [7.7%]; Meguro | 16h | 8h | 916.96 |  | 458.47 |
| 329 | 3.5.1.4.2 | Software Instrument Interfaces | 14d? | 2007-06-12 | 2007-06-29 |  |  |  |  |  |  | 218d |  | start no earlier than 2007-06-12 | Adkins [7.1%]; Johansson | 16h |  | 916.96 |  |  |
| 330 | 3.5.2 | **Deployable NIR IFU (DNIRI)** | 98d? | 2007-05-07 A | 2007-09-18 |  | 84% | 15.58d? | 2007-02-01 | 2007-06-27 | 105d? | 160d |  |  |  | 258h | 224.4h | 19,725.1 | 33,076.2 | 17,603.68 |
| 331 | 3.5.2.1 | DNIRI Concept Development | 30d? | 2007-05-07 A | 2007-06-15 A |  | 100% |  |  |  |  |  |  | start no earlier than 2007-05-07 | Adkins [4.2%]; Mechanical Engineer 1; Optical Engineer 1 | 50h | 50h | 4,128.7 |  | 4,128.7 |
| 332 | 3.5.2.2 | **DNIRI AO Interface Issues** | 12d? | 2007-06-18 A | 2007-07-03 |  | 92% | 1d? |  |  |  | 0d |  |  |  | 40h | 38.4h | 3,271.38 |  | 3,154.42 |
| 333 | 3.5.2.2.1 | Object Selection for DNIRI | 10d? | 2007-06-18 A | 2007-06-29 A | 331 | 100% |  |  |  |  |  |  | finish no earlier than 2007-06-29 | Adkins [10%]; Mechanical Engineer 1; Optical Engineer 1; Moore | 32h | 32h | 2,591.84 |  | 2,591.84 |
| 334 | 3.5.2.2.2 | AO Design for DNIRI | 1d? | 2007-07-02 A | 2007-07-02 | 333 | 80% | 0.2d? |  |  |  | 0.2d | 0d | finish no earlier than 2007-07-02 | Moore [50%] | 4h | 3.2h | 355.56 |  | 284.45 |
| 335 | 3.5.2.2.3 | DNIRI AO Boundary | 1d? | 2007-07-03 A | 2007-07-03 | 334 | 20% | 0.8d? |  |  |  | 0d |  | finish no earlier than 2007-07-03 | Adkins [12.5%]; Mechanical Engineer 1; Optical Engineer 1; Moore | 4h | 3.2h | 323.98 |  | 278.13 |
| 336 | 3.5.2.3 | DNIRI Spectrograph Concepts | 25d? | 2007-07-04 A | 2007-08-07 A | 335 | 100% |  |  |  |  |  |  | finish no earlier than 2007-08-06 | Adkins [10%]; Mechanical Engineer 1; Optical Engineer 1 | 60h | 60h | 4,701.8 |  | 4,701.8 |
| 337 | 3.5.2.4 | DNIRI Imager Concepts | 25d? | 2007-07-04 A | 2007-08-07 A | 335 | 100% |  |  |  |  |  |  | finish no earlier than 2007-08-06 | Adkins [10%]; Mechanical Engineer 1; Optical Engineer 1 | 60h | 60h | 4,701.8 |  | 4,701.8 |
| 338 | 3.5.2.5 | DNIRI Concept Review with AO Team | 1d? | 2007-08-08 | 2007-08-08 | 336, 337 |  |  |  |  |  | 161d | 1d | finish no earlier than 2007-08-08 | Adkins [25%]; Bell; Gavel; Moore | 8h |  | 629.02 |  |  |
| 339 | 3.5.2.6 | DNIRI Report ver 1 | 29d? | 2007-08-10 A | 2007-09-18 | 338 | 40% | 17.4d? |  |  |  | 160d |  | finish no earlier than 2007-09-18 | Adkins [17.2%] | 40h | 16h | 2,292.4 |  | 916.96 |
| 340 | 3.5.3 | **Single Object Imagers/Low Resolution Spectrographs (SOI/LRS)** | 119d? | 2007-05-07 A | 2007-10-17 |  | 71% | 34.85d? |  |  |  | 139d |  |  |  | 95h | 68.05h | 5,444.45 |  | 3,899.95 |
| 341 | 3.5.3.1 | SOI/LRS Coronagraph Requirements | 10d? | 2007-05-07 A | 2007-06-01 A | 320 | 100% |  |  |  |  |  |  | finish no earlier than 2007-06-01 | Adkins [12.5%] | 10h | 10h | 573.1 |  | 573.1 |
| 342 | 3.5.3.2 | SOI/LRS Spectrograph Requirements | 10d? | 2007-06-04 A | 2007-06-15 | 341 | 75% | 2.5d? |  |  |  | 11d | 0d | start no earlier than 2007-06-04 | Adkins [6.2%] | 5h | 3.75h | 286.55 |  | 214.91 |
| 343 | 3.5.3.3 | SOI/LRS Concept Development | 20d? | 2007-06-18 A | 2007-07-13 | 342, 341 | 55% | 9d? |  |  |  | 0d |  | finish no earlier than 2007-06-29 | Adkins [10%]; Bell; Optical Engineer 2 | 24h | 16.8h | 1,375.44 |  | 962.81 |

Notes:
- 318: SA
- 319: SA
- 320: SA
- 321: SA
- 322: SA
- 323: SA
- 324: SA
- 325: SA
- 326: SA
- 327: SA
- 328: SA
- 329: SA
- 330: SA
- 331: SA
- 332: SA
- 333: SA
- 334: SA
- 335: SA
- 336: SA
- 337: SA
- 338: SA
- 339: SA
- 340: SA
- 341: SA
- 342: SA
- 343: SA

| ID | WBS | Task | Type | Duration | Start | Finish | Predecessors | Complete | Remaining | Baseline start | Baseline finish | Baseline duration | Total slack | Free slack | Constraint | Resources | Work | Actual work | Cost | Baseline cost | Actual cost | Text1 |
| --- | --- | --- | --- | --- | --- | --- | --- | --- | --- | --- | --- | --- | --- | --- | --- | --- | --- | --- | --- | --- | --- | --- |
| 344 | 3.5.3.4 | **SOI/LRS Concept Review** |  | 2d? | 2007-07-16 | 2007-07-17 |  |  |  |  |  |  | 181d |  |  |  | 6h |  | 343.86 |  |  |  |
| 345 | 3.5.3.4.1 | SOI/LRS Concept Review with Science Team |  | 1d? | 2007-07-16 | 2007-07-16 | 343 |  |  |  |  |  | 181d | 0d | finish no earlier than 2007-07-02 | Adkins [37.5%] | 3h |  | 171.93 |  |  |  |
| 346 | 3.5.3.4.2 | SOI/LRS Concept Review with AO Team |  | 1d? | 2007-07-17 | 2007-07-17 | 345, 343 |  |  |  |  |  | 181d | 0d | finish no earlier than 2007-07-03 | Adkins [37.5%] | 3h |  | 171.93 |  |  |  |
| 347 | 3.5.3.5 | **SOI/LRS Reports** |  | 76d? | 2007-07-05 A | 2007-10-17 |  | 72% | 21.59d? |  |  |  | 139d |  |  |  | 50h | 37.5h | 2,865.5 |  | 2,149.12 |  |
| 348 | 3.5.3.5.1 | SOI/LRS Near-IR ver 1 |  | 75d? | 2007-07-05 A | 2007-10-16 | 346 | 69% | 23.44d? |  |  |  | 140d |  | finish no earlier than 2007-10-16 | Adkins [5%] | 25h | 18.75h | 1,432.75 |  | 1,074.56 |  |
| 349 | 3.5.3.5.2 | SOI/LRS Visibile ver 1 |  | 62.5d? | 2007-07-06 A | 2007-10-17 | 346 | 75% | 15.62d? |  |  |  | 139d |  | finish no earlier than 2007-10-17 | Adkins [5%] | 25h | 18.75h | 1,432.75 |  | 1,074.56 |  |
| 350 | 3.5.4 | **Single Object IFUs (SOIFU)** |  | 186d? | 2007-04-30 A | 2008-01-11 |  | 10% | 167.58d? |  |  |  | 77d |  |  |  | 17h | 2.5h | 974.27 |  | 143.28 |  |
| 351 | 3.5.4.1 | Near-IR IFU Requirements Review |  | 10d? | 2007-04-30 A | 2007-05-11 |  | 50% | 5d? |  |  |  | 223d | 145d | start no earlier than 2007-04-30 | Adkins [6.2%] | 5h | 2.5h | 286.55 |  | 143.28 |  |
| 352 | 3.5.4.2 | Visible IFU Requirements Review |  | 10.5d? | 2007-09-18 | 2007-10-02 |  |  |  |  |  |  | 120.5d | 41.5d | start no earlier than 2007-09-18 | Adkins [4.8%] | 4h |  | 229.24 |  |  |  |
| 353 | 3.5.4.3 | Visible IFU Concept Development | milestone | 0d? | 2007-11-28 | 2007-11-28 | 352 |  |  |  |  |  | 79d | 1d | finish no earlier than 2007-11-28 | Adkins [6%]; Mechanical Engineer 3; Optical Engineer 3 |  |  |  |  |  |  |
| 354 | 3.5.4.4 | **SOIFU Concept Review** |  | 1d? | 2007-11-29 | 2007-11-30 |  |  |  |  |  |  | 77d |  |  |  |  |  |  |  |  |  |
| 355 | 3.5.4.4.1 | SOIFU Concept Review with Science Team | milestone | 0d? | 2007-11-29 | 2007-11-29 | 351, 353 |  |  |  |  |  | 78d | 1d | finish no earlier than 2007-11-29 | Adkins [37.5%] |  |  |  |  |  |  |
| 356 | 3.5.4.4.2 | SOIFU Concept Review with AO Team | milestone | 0d? | 2007-11-30 | 2007-11-30 | 355 |  |  |  |  |  | 77d | 0d | finish no earlier than 2007-11-30 | Adkins [37.5%] |  |  |  |  |  |  |
| 357 | 3.5.4.5 | **Single Object IFU Reports** |  | 30d? | 2007-12-03 | 2008-01-11 |  |  |  |  |  |  | 77d |  |  |  | 8h |  | 458.48 |  |  |  |
| 358 | 3.5.4.5.1 | SOIFU Near-IR ver 1 |  | 10d? | 2007-12-03 | 2007-12-14 | 356 |  |  |  |  |  | 77d | 0d | start no earlier than 2007-12-03 | Adkins [7.5%] | 6h |  | 343.86 |  |  |  |
| 359 | 3.5.4.5.2 | SOIFU Visible ver 1 |  | 20d? | 2007-12-17 | 2008-01-11 | 358 |  |  |  |  |  | 77d |  | finish no earlier than 2008-01-11 | Adkins [1.2%] | 2h |  | 114.62 |  |  |  |
| 360 | 3.5.5 | Interferometer |  | 68d | 2006-10-02 A | 2007-10-30 |  | 42% | 39.44d | 2006-10-02 | 2007-03-30 | 130d? | 0d |  | finish no earlier than 2007-10-30 | Neyman [7.7%]; Other [4.1%]; Wizinowich [2.5%] | 36h | 11.92h | 2,063.16 | 5,731 | 682.85 |  |
| 361 | 3.5.6 | OHANA |  | 50d? | 2007-02-01 | 2007-04-11 |  |  |  | 2007-02-01 | 2007-04-11 | 50d? | 275d |  | start no earlier than 2007-02-01 | Neyman [1.5%]; Woillez [7.5%] | 10h |  | 573.1 | 2,292.4 |  |  |
| 362 | 3.6 | **System Design Manual (SDM)** |  | 136d? | 2007-08-13 A | 2008-02-15 |  | 56% | 60.44d? | 2008-01-01 | 2008-01-18 | 12.5d? | 16d | 10d |  |  | 140h | 60h | 10,834.1 | 6,290.2 | 4,386 |  |
| 363 | 3.6.1 | SDM v1 |  | 25d? | 2007-08-13 A | 2007-09-14 A |  | 100% |  |  |  |  |  |  | finish no earlier than 2007-09-14 | Wizinowich [15%]; Dekany | 60h | 60h | 4,386 |  | 4,386 |  |
| 364 | 3.6.2 | SDM v2 |  | 20d? | 2008-01-21 | 2008-02-15 | 241, 273, 287, 339 |  |  |  |  |  | 16d |  | finish no earlier than 2008-02-15 | Wizinowich [21.9%]; Dekany; Gavel | 80h |  | 6,448.1 |  |  |  |
| 365 | 4 | **Systems Engineering Management Plan (SEMP)** |  | 261d? | 2007-03-05 A | 2008-02-29 |  | 19% | 211.11d? | 2007-03-05 | 2008-02-20 | 252.33d? | 6d |  |  |  | 986h | 134h | 67,777.99 | 83,733.3 | 8,886.5 |  |
| 366 | 4.1 | **Project Plan** |  | 92.6d? | 2007-10-04 A | 2008-02-11 |  | 14% | 79.54d? | 2007-09-26 | 2007-12-20 | 60.57d? | 13.35d | 7d |  |  | 410h | 70h | 29,992.15 | 41,077.5 | 4,490.34 |  |
| 367 | 4.1.1 | WBS and Task Definition |  | 27.6d? | 2007-10-04 A | 2007-11-12 | 21FS+55d | 18% | 22.7d? | 2007-09-26 | 2007-10-25 | 21.43d? | 62.73d | 0d | finish no earlier than 2007-11-12 | Wizinowich [18.1%]; Dekany [18.1%]; Gavel [18.1%]; Max [35%] | 140h | 35h | 10,288 | 15,432 | 1,825.25 | moved earlier |
| 368 | 4.1.2 | Cost Estimation |  | 26d? | 2008-01-07 A | 2008-02-11 |  | 8% | 24.05d? | 2007-10-25 | 2007-11-30 | 25.57d? | 13.35d |  | finish no earlier than 2008-02-11 | Wizinowich [9.6%]; Dekany [14.7%]; Gavel [14.7%]; Bauman [14.7%]; Bell [9.8%]; Johansson [9.8%]; Chin [9.8%]; Velur [14.7%]; Adkins [9.8%]; Le Mignant [4.9%] | 160h | 16h | 11,951.95 | 17,004.4 | 1,252.49 | assignment |
| 369 | 4.1.3 | Major Project Milestones |  | 6.57d? | 2007-10-26 A | 2007-11-05 |  | 33% | 4.38d? | 2007-10-25 | 2007-11-05 | 6.57d? | 83.78d |  | start no earlier than 2007-10-26 | Wizinowich [19%]; Dekany [38%] | 20h | 10h | 1,462 | 2,350.9 | 783.61 |  |
| 370 | 4.1.4 | Develop Full Schedule (MS Project Plan) |  | 13.57d? | 2008-01-14 A | 2008-01-31 |  | 10% | 12.21d? | 2007-11-30 | 2007-12-20 | 13.57d? | 6.72d | 0d | start no earlier than 2008-01-14 | Wizinowich [36.8%]; Dekany [18.4%]; Gavel [18.4%]; Max [9.2%] | 90h | 9h | 6,290.2 | 6,290.2 | 628.99 | end date |
| 371 | 4.2 | Risk Assessment & Management Plan |  | 34d? | 2007-09-25 | 2007-11-09 |  |  |  | 2007-09-26 | 2007-11-13 | 34d? | 79.35d | 73d | start no earlier than 2007-09-25 | Wizinowich [3.7%]; Dekany [5.5%]; Gavel [5.5%] | 40h |  | 3,571.45 | 3,571.45 |  | lead; people |

Notes:
- 344: SA
- 345: SA
- 346: SA
- 347: SA
- 348: SA
- 349: SA
- 350: SA
- 351: SA
- 352: SA
- 353: SA
- 354: SA
- 355: SA
- 356: SA
- 357: SA
- 358: SA
- 359: SA
- 360: CN
- 361: CN
- 362: PW
- 363: PW
- 364: PW
- 365: PW
- 366: PW
- 367: PW
- 368: PW
- 369: PW
- 370: PW
- 371: DG

| ID | WBS | Task | Duration | Start | Finish | Predecessors | Complete | Remaining | Baseline start | Baseline finish | Baseline duration | Total slack | Free slack | Constraint | Resources | Work | Actual work | Cost | Baseline cost | Actual cost | Text1 |
| --- | --- | --- | --- | --- | --- | --- | --- | --- | --- | --- | --- | --- | --- | --- | --- | --- | --- | --- | --- | --- | --- |
| 372 | 4.3 | **Preliminary Design Phase Plan** | 253.63d? | 2007-03-05 A | 2008-02-20 |  | 66% | 85.75d? | 2007-03-05 | 2008-01-24 | 233.64d? | 6.72d | 0.37d |  |  | 192h | 60h | 13,493.19 | 14,007.59 | 4,144.55 |  |
| 373 | 4.3.1 | Preliminary Design Phase Plan Version 1 (to Support Observatory FY08 Planning) | 55d? | 2007-03-05 A | 2007-05-18 A |  | 100% |  | 2007-03-05 | 2007-03-30 | 20d? |  |  | finish no earlier than 2007-05-18 | Wizinowich [9.4%]; Dekany [6.2%]; Gavel [6.2%]; Max [3.1%] | 40h | 40h | 2,858.55 | 2,858.55 | 2,858.55 | -2hr; later |
| 374 | 4.3.2 | Preliminary Design Phase Plan Version 2 | 18.75d? | 2007-11-12 A | 2007-12-07 | 367 | 17% | 15.62d? | 2007-10-25 | 2007-11-21 | 18.75d? | 60.1d |  | start no earlier than 2007-04-09 | Wizinowich [20%]; Dekany [20%]; Gavel [20%]; Max [20%] | 80h | 20h | 5,717.1 | 5,717.1 | 1,286 |  |
| 375 | 4.3.3 | Preliminary Design Phase Plan Final Version | 14.06d? | 2008-01-31 | 2008-02-20 | 370 |  |  | 2008-01-03 | 2008-01-24 | 15.57d? | 6.72d |  | finish no earlier than 2008-02-13 | Wizinowich [26.7%]; Dekany [14.4%]; Gavel [14.4%]; Max [10%] | 72h |  | 4,917.54 | 5,431.94 |  | -4hr |
| 376 | 4.4 | **Integration and Test Plans** | 71d? | 2007-10-26 | 2008-02-01 |  |  |  | 2007-10-25 | 2008-02-01 | 70.4d? | 19.35d |  |  |  | 154h |  | 8,825.74 | 10,315.8 |  |  |
| 377 | 4.4.1 | **Subsystem Testing Plans** | 71d? | 2007-10-26 | 2008-02-01 |  |  |  | 2007-10-25 | 2008-02-01 | 70.4d? | 19.35d | 13d |  |  | 64h |  | 3,667.84 | 4,584.8 |  |  |
| 378 | 4.4.1.1 | AO System Test Plan | 17.6d? | 2007-10-26 | 2007-11-20 |  |  |  | 2007-10-25 | 2007-11-20 | 17.6d? | 19.55d | 0d | start no earlier than 2007-10-26 | Neyman [14.2%] | 20h |  | 1,146.2 | 1,146.2 |  |  |
| 379 | 4.4.1.2 | Laser System Test Plan | 17.6d? | 2007-11-20 | 2007-12-14 | 378 |  |  | 2007-11-20 | 2007-12-14 | 17.6d? | 19.55d | 0d |  | Neyman [14.2%] | 20h |  | 1,146.2 | 1,146.2 |  |  |
| 380 | 4.4.1.3 | Science Operations Test Plan | 17.6d? | 2007-12-14 | 2008-01-08 | 379 |  |  | 2007-12-14 | 2008-01-08 | 17.6d? | 19.55d | 0.2d |  | Le Mignant [14.2%] | 20h |  | 1,146.2 | 1,146.2 |  |  |
| 381 | 4.4.1.4 | Science Instruments Test Plan | 18d? | 2008-01-09 | 2008-02-01 | 380 |  |  | 2008-01-08 | 2008-02-01 | 17.6d? | 19.35d |  | start no earlier than 2008-01-09 | Adkins [2.8%] | 4h |  | 229.24 | 1,146.2 |  |  |
| 382 | 4.4.2 | System Integration & Test Plans | 44d? | 2007-12-03 | 2008-01-31 |  |  |  | 2007-10-25 | 2007-12-06 | 30d? | 20.35d | 14d | finish no earlier than 2008-01-31 | Neyman [25.6%]; Wizinowich [2.8%] | 90h |  | 5,157.9 | 5,731 |  | assignment |
| 383 | 4.5 | Configuration Management Plan | 30.5d? | 2007-12-07 | 2008-01-18 |  |  |  | 2007-10-25 | 2008-01-22 | 62.5d? | 29.35d | 23d | finish no earlier than 2008-01-18 | Johansson [8.2%]; Bell [10%]; Chin [5%] | 30h |  | 1,719.3 | 4,584.8 |  | assignment |
| 384 | 4.6 | Project Management Plan | 12.43d? | 2008-01-31 | 2008-02-18 | 370 |  |  | 2007-12-20 | 2008-01-17 | 20d? | 8.35d | 2d | finish no earlier than 2008-02-18 | Wizinowich [20.1%]; Dekany [20.1%]; Gavel [20.1%]; Max [20.1%] | 80h |  | 5,144 | 5,144 |  |  |
| 385 | 4.7 | SEMP Document | 7d | 2008-02-21 A | 2008-02-29 | 366, 372, 377, 382, 383, 384, 371 | 5% | 6.65d | 2008-02-01 | 2008-02-20 | 13d? | 6d | 0d | finish no earlier than 2008-02-29 | Wizinowich [57.1%]; Dekany [28.6%]; Gavel [28.6%]; Max [28.6%] | 80h | 4h | 5,032.16 | 5,032.16 | 251.61 |  |

Notes:
- 372: PW
- 373: PW
- 374: PW
- 375: PW
- 376: CN
- 377: CN
- 378: CN
- 379: CN
- 380: DLM
- 381: SA
- 382: CN
- 383: EJ
- 384: PW
- 385: PW
