# NGAO SD schedule v6

Schedule from MS Project, 2006-06-21 to 2008-04-04.
CARA

## Calendars

- Standard: Mon-Fri 08:00-12:00, 13:00-17:00; Sat-Sun off.

## Resources

| Resource |
| --- |
| 16 |
| Flicker |
| Gavel |
| Neyman |

## Schedule

| ID | WBS | Task | Type | Duration | Start | Finish | Predecessors | Total slack | Free slack | Constraint | Work |
| --- | --- | --- | --- | --- | --- | --- | --- | --- | --- | --- | --- |
| 1 | 1 | **SD Phase Management** |  | 468d? | 2006-06-21 | 2008-04-04 |  | 0d |  |  | 1745h |
| 2 | 1.1 | **Planning and Contracting** |  | 323d? | 2006-06-21 | 2007-09-14 |  | 145d |  |  | 220h |
| 3 | 1.1.1 | NGAO Proposal to SSC | milestone | 0d | 2006-06-21 | 2006-06-21 |  | 424d | 17d | start no earlier than 2006-06-21 |  |
| 4 | 1.1.2 | Management Structure Decision by Directors | milestone | 0d | 2006-07-14 | 2006-07-14 | 3 | 407d | 6d | start no earlier than 2006-07-14 |  |
| 5 | 1.1.3 | SD Phase System Engineering Management Plan |  | 44d? | 2006-07-24 | 2006-09-21 | 4 | 401d | 0d | finish no earlier than 2006-09-21 | 80h |
| 6 | 1.1.4 | SD Phase Contracts Generated |  | 19d? | 2006-09-05 | 2006-09-29 |  | 395d | 0d | finish no earlier than 2006-09-29 | 60h |
| 7 | 1.1.5 | Director Approval | milestone | 0d | 2006-09-29 | 2006-09-29 |  | 396d | 1d | start no earlier than 2006-09-29 |  |
| 8 | 1.1.6 | SD Partner Contracts Issued | milestone | 0d | 2006-10-02 | 2006-10-02 | 6, 7 | 395d |  | start no earlier than 2006-10-02 |  |
| 9 | 1.1.7 | Mid-year Replan |  | 10d? | 2007-03-05 | 2007-03-16 |  | 275d |  | finish no earlier than 2007-03-16 | 40h |
| 10 | 1.1.8 | FY08 Replan |  | 9d? | 2007-09-04 | 2007-09-14 |  | 145d |  | start no earlier than 2007-09-04 | 40h |
| 11 | 1.2 | **Project Meetings** |  | 443d? | 2006-07-26 | 2008-04-04 |  | 0d |  |  | 780h |
| 12 | 1.2.1 | Executive Committee Telecons |  | 438d? | 2006-07-26 | 2008-03-28 |  | 5d |  | finish no earlier than 2008-03-28 | 300h |
| 13 | 1.2.2 | Science Advisory Committee Telecons |  | 434d? | 2006-08-01 | 2008-03-28 |  | 5d |  | finish no earlier than 2008-03-28 | 40h |
| 14 | 1.2.3 | **Team Meetings** |  | 407d? | 2006-09-14 | 2008-04-04 |  | 0d |  |  | 440h |
| 15 | 1.2.3.1 | Team Meeting (mgmt, science & technical - Irvine) |  | 1d | 2006-09-14 | 2006-09-14 |  | 406d |  | start no earlier than 2006-09-14 | 40h |
| 16 | 1.2.3.2 | Team Meeting (CIT) |  | 1d | 2006-11-03 | 2006-11-03 |  | 370d |  | start no earlier than 2006-11-03 | 40h |
| 17 | 1.2.3.3 | Team Videocon |  | 1d? | 2006-12-13 | 2006-12-13 |  | 342d |  | start no earlier than 2006-12-13 | 10h |
| 18 | 1.2.3.4 | Team Meeting (Keck) |  | 1d | 2007-01-22 | 2007-01-22 |  | 314d |  | start no earlier than 2007-01-22 | 40h |
| 19 | 1.2.3.5 | Team Videocon |  | 1d? | 2007-03-07 | 2007-03-07 |  | 282d |  | start no earlier than 2007-03-07 | 10h |
| 20 | 1.2.3.6 | Team Meeting |  | 1d | 2007-04-18 | 2007-04-18 |  | 252d |  | start no earlier than 2007-04-18 | 10h |
| 21 | 1.2.3.7 | Team Videocon |  | 5d? | 2007-05-28 | 2007-06-01 |  | 220d |  | finish no earlier than 2007-06-01 | 10h |
| 22 | 1.2.3.8 | Team Retreat (UCSC) |  | 5d | 2007-07-09 | 2007-07-13 |  | 190d |  | start no earlier than 2007-07-09 | 140h |
| 23 | 1.2.3.9 | Team Videocon |  | 1d? | 2007-08-22 | 2007-08-22 |  | 162d |  | start no earlier than 2007-08-22 | 10h |
| 24 | 1.2.3.10 | Team Meeting (CIT) |  | 1d | 2007-09-20 | 2007-09-20 |  | 141d |  | start no earlier than 2007-09-20 | 40h |
| 25 | 1.2.3.11 | Team Videocon |  | 1d | 2007-11-05 | 2007-11-05 |  | 109d |  | start no earlier than 2007-11-05 | 10h |
| 26 | 1.2.3.12 | Team Meeting (Keck) |  | 3d? | 2007-12-12 | 2007-12-14 |  | 80d |  | finish no earlier than 2007-12-14 | 60h |
| 27 | 1.2.3.13 | Team Videocon |  | 1d? | 2008-01-11 | 2008-01-11 |  | 60d |  | start no earlier than 2008-01-11 | 10h |
| 28 | 1.2.3.14 | Team Meeting (CA) |  | 1d? | 2008-04-04 | 2008-04-04 | 39 | 0d |  | start no earlier than 2008-04-04 | 10h |

Notes:
- 1: PW
- 2: PW
- 5: PW
- 6: SA
- 8: SA
- 9: PW
- 10: PW
- 12: PW
- 13: CM

| ID | WBS | Task | Type | Duration | Start | Finish | Predecessors | Total slack | Free slack | Constraint | Work |
| --- | --- | --- | --- | --- | --- | --- | --- | --- | --- | --- | --- |
| 29 | 1.3 | **Tracking and Reporting** |  | 400d? | 2006-09-21 | 2008-04-03 |  | 1d |  |  | 120h |
| 30 | 1.3.1 | Report Preparation/Presentation |  | 390d? | 2006-10-02 | 2008-03-28 |  | 5d |  | start no earlier than 2006-10-02 | 120h |
| 31 | 1.3.2 | Keck Science Meeting 06 (UCI) | milestone | 0d | 2006-09-21 | 2006-09-21 | 5 | 401d |  | finish no earlier than 2006-09-16 |  |
| 32 | 1.3.3 | SSC meeting (UCLA) | milestone | 0d | 2006-11-06 | 2006-11-06 |  | 370d |  | start no earlier than 2006-11-06 |  |
| 33 | 1.3.4 | SSC meeting (Keck) | milestone | 0d | 2007-01-24 | 2007-01-24 |  | 313d |  | start no earlier than 2007-01-24 |  |
| 34 | 1.3.5 | SSC meeting (CA) | milestone | 0d | 2007-04-03 | 2007-04-03 |  | 264d |  | start no earlier than 2007-04-03 |  |
| 35 | 1.3.6 | SSC meeting (Keck) | milestone | 0d | 2007-06-20 | 2007-06-20 |  | 208d |  | start no earlier than 2007-06-20 |  |
| 36 | 1.3.7 | Keck Science Meeting 07 | milestone | 0d | 2007-09-22 | 2007-09-22 |  | 140d |  | finish no earlier than 2007-09-22 |  |
| 37 | 1.3.8 | SSC meeting (CA) | milestone | 0d | 2007-11-06 | 2007-11-06 |  | 109d |  | start no earlier than 2007-11-06 |  |
| 38 | 1.3.9 | SSC meeting (Keck) | milestone | 0d | 2008-01-24 | 2008-01-24 |  | 52d |  | start no earlier than 2008-01-24 |  |
| 39 | 1.3.10 | SSC meeting (CA) | milestone | 0d | 2008-04-03 | 2008-04-03 |  | 0d |  | finish no earlier than 2008-04-03 |  |
| 40 | 1.4 | **Proposal & Fundraising Activities** |  | 326d? | 2006-10-02 | 2007-12-31 |  | 69d |  |  | 160h |
| 41 | 1.4.1 | Dates & deliverables identified by Directors | milestone | 0d | 2006-10-02 | 2006-10-02 |  | 134d | 65d | start no earlier than 2006-10-02 |  |
| 42 | 1.4.2 | Activities |  | 261d? | 2007-01-01 | 2007-12-31 | 41 | 69d |  | finish no earlier than 2007-12-31 | 160h |
| 43 | 1.5 | **System Design Review** |  | 70d? | 2007-11-15 | 2008-02-20 |  | 32d |  |  | 465h |
| 44 | 1.5.1 | System Design Report |  | 8d? | 2008-01-02 | 2008-01-11 |  | 60d |  | finish no earlier than 2008-01-11 | 40h |
| 45 | 1.5.2 | **System Design Review Activities** |  | 70d? | 2007-11-15 | 2008-02-20 |  | 32d |  |  | 425h |
| 46 | 1.5.2.1 | Reviewers Identified |  | 22d? | 2007-11-15 | 2007-12-14 |  | 72d | 21d | finish no earlier than 2007-12-14 | 15h |
| 47 | 1.5.2.2 | Review Package Distributed | milestone | 0d | 2008-01-15 | 2008-01-15 | 46, 242, 221, 80 | 51d | 9d | start no earlier than 2008-01-14 |  |
| 48 | 1.5.2.3 | Reviewer Comments Received & Addressed |  | 5d? | 2008-01-28 | 2008-02-01 | 47 | 42d | 3d | finish no earlier than 2008-02-01 | 120h |
| 49 | 1.5.2.4 | System Design Review Prep & Attendance |  | 16d? | 2008-01-16 | 2008-02-06 |  | 39d | 0d | finish no earlier than 2008-02-06 | 250h |
| 50 | 1.5.2.5 | System Design Review Meeting | milestone | 0d | 2008-02-06 | 2008-02-06 | 49, 48 | 39d | 6d | start no earlier than 2008-02-06 |  |
| 51 | 1.5.2.6 | Reviewer Report Received | milestone | 0d | 2008-02-15 | 2008-02-15 | 50 | 33d | 1d | start no earlier than 2008-02-15 |  |
| 52 | 1.5.2.7 | Response to Reviewer Report & Distribution |  | 3d? | 2008-02-18 | 2008-02-20 | 51 | 32d |  | finish no earlier than 2008-02-20 | 40h |

Notes:
- 29: PW
- 30: PW
- 43: SA
- 44: PW

| ID | WBS | Task | Type | Duration | Start | Finish | Predecessors | Total slack | Free slack | Constraint | Work |
| --- | --- | --- | --- | --- | --- | --- | --- | --- | --- | --- | --- |
| 53 | 2 | **System Requirements** |  | 360d? | 2006-08-30 | 2008-01-15 |  | 58d |  |  | 4060h |
| 54 | 2.1 | **Science Requirements** |  | 158d? | 2006-08-30 | 2007-04-06 |  | 260d |  |  | 3660h |
| 55 | 2.1.1 | Solar System |  | 130d? | 2006-10-02 | 2007-03-30 |  | 265d |  | finish no earlier than 2007-03-30 | 1000h |
| 56 | 2.1.2 | **Galactic** |  | 153d? | 2006-08-30 | 2007-03-30 |  | 265d |  |  | 1200h |
| 57 | 2.1.2.1 | **Galactic Center** |  | 78d? | 2006-08-30 | 2006-12-15 |  | 340d |  |  | 200h |
| 58 | 2.1.2.1.1 | Astrometry performance requirement |  | 78d? | 2006-08-30 | 2006-12-15 |  | 340d |  | start no earlier than 2006-08-30 | 200h |
| 59 | 2.1.2.2 | **Debris Disks & Binary Brown Dwarfs** |  | 78d? | 2006-08-30 | 2006-12-15 |  | 340d |  |  | 200h |
| 60 | 2.1.2.2.1 | Companion sensitivity requirement |  | 78d? | 2006-08-30 | 2006-12-15 |  | 340d |  | start no earlier than 2006-08-30 | 200h |
| 61 | 2.1.2.3 | Other |  | 75d? | 2006-12-18 | 2007-03-30 |  | 265d |  | finish no earlier than 2007-03-30 | 800h |
| 62 | 2.1.3 | **Extragalactic** |  | 130d? | 2006-10-02 | 2007-03-30 |  | 265d |  |  | 1300h |
| 63 | 2.1.3.1 | **Resolved Stellar Populations** |  | 55d? | 2006-10-02 | 2006-12-15 |  | 340d |  |  | 300h |
| 64 | 2.1.3.1.1 | Contiguous science field requirement |  | 55d? | 2006-10-02 | 2006-12-15 |  | 340d |  | finish no earlier than 2006-12-15 | 100h |
| 65 | 2.1.3.1.2 | Photometry performance requirement |  | 55d? | 2006-10-02 | 2006-12-15 |  | 340d |  | finish no earlier than 2006-12-15 | 200h |
| 66 | 2.1.3.2 | **High Redshift Galaxies** |  | 55d? | 2006-10-02 | 2006-12-15 |  | 340d |  |  | 300h |
| 67 | 2.1.3.2.1 | Encircled energy requirement |  | 55d? | 2006-10-02 | 2006-12-15 |  | 340d |  | finish no earlier than 2006-12-15 | 100h |
| 68 | 2.1.3.2.2 | Background requirement |  | 55d? | 2006-10-02 | 2006-12-15 |  | 340d |  | finish no earlier than 2006-12-15 | 100h |
| 69 | 2.1.3.2.3 | d-IFU optimum lenslet scale |  | 55d? | 2006-10-02 | 2006-12-15 |  | 340d |  | finish no earlier than 2006-12-15 | 100h |
| 70 | 2.1.3.3 | Other |  | 75d? | 2006-12-18 | 2007-03-30 |  | 265d |  | finish no earlier than 2007-03-30 | 700h |
| 71 | 2.1.4 | **Science Requirements Summary** |  | 154d? | 2006-09-05 | 2007-04-06 |  | 260d | 20d |  | 160h |
| 72 | 2.1.4.1 | Rev. 1 Release |  | 29d? | 2006-09-05 | 2006-10-13 |  | 385d | 10d | finish no earlier than 2006-10-13 | 40h |
| 73 | 2.1.4.2 | Rev. 2 Release |  | 20d? | 2007-03-12 | 2007-04-06 |  | 260d | 20d | finish no earlier than 2007-04-06 | 120h |
| 74 | 2.2 | Observatory Requirements Updates |  | 20d? | 2006-10-02 | 2006-10-27 |  | 375d | 0d | start no earlier than 2006-10-02 | 40h |
| 75 | 2.3 | **System Requirements Document** |  | 337d? | 2006-10-02 | 2008-01-15 |  | 58d |  |  | 360h |
| 76 | 2.3.1 | Technical Requirements Flow Down |  | 128d? | 2006-11-01 | 2007-04-27 |  | 245d | 5d | finish no earlier than 2007-04-27 | 120h |
| 77 | 2.3.2 | System Requirements Document Writing |  | 337d? | 2006-10-02 | 2008-01-15 |  | 58d |  | finish no earlier than 2008-01-15 | 240h |
| 78 | 2.3.3 | Rev. 1 Release | milestone | 0d | 2006-10-27 | 2006-10-27 | 74, 72 | 375d |  | start no earlier than 2006-10-27 |  |
| 79 | 2.3.4 | Rev. 2 Release | milestone | 0d | 2007-05-04 | 2007-05-04 | 71, 73, 76 | 240d |  | finish no earlier than 2007-05-04 |  |
| 80 | 2.3.5 | Final SD version | milestone | 0d | 2008-01-15 | 2008-01-15 |  | 51d | 0d | start no earlier than 2008-01-15 |  |

Notes:
- 54: CM
- 55: FM
- 56: ML
- 62: CM
- 74: CN
- 76: CN

| ID | WBS | Task | Duration | Start | Finish | Predecessors | Total slack | Free slack | Constraint | Work |
| --- | --- | --- | --- | --- | --- | --- | --- | --- | --- | --- |
| 81 | 3 | **System Design** | 279d? | 2006-08-01 | 2007-08-24 |  | 160d |  |  | 10800h |
| 82 | 3.1 | **System Engineering** | 239d? | 2006-08-01 | 2007-06-29 |  | 162d |  |  | 5450h |
| 83 | 3.1.1 | **Performance Budgets** | 239d? | 2006-08-01 | 2007-06-29 |  | 152d |  |  | 2460h |
| 84 | 3.1.1.1 | **Model Assumptions** | 230d? | 2006-08-14 | 2007-06-29 |  | 152d |  |  | 260h |
| 85 | 3.1.1.1.1 | **TMT site monitoring data mining** | 230d? | 2006-08-14 | 2007-06-29 |  | 152d |  |  | 80h |
| 86 | 3.1.1.1.1.1 | Tools in place & 1st release | 24d? | 2006-08-14 | 2006-09-14 |  | 153d | 1d | finish no earlier than 2006-09-14 | 40h |
| 87 | 3.1.1.1.1.2 | Release updated data (every two months) | 205d? | 2006-09-18 | 2007-06-29 | 86 | 152d |  | finish no earlier than 2007-06-29 | 40h |
| 88 | 3.1.1.1.2 | Telescope dynamic performance data | 44d? | 2006-10-02 | 2006-11-30 |  | 268d | 1d | finish no earlier than 2006-11-30 | 120h |
| 89 | 3.1.1.1.3 | Telescope static wavefront errors | 44d? | 2006-10-02 | 2006-11-30 |  | 268d | 1d | finish no earlier than 2006-11-30 | 20h |
| 90 | 3.1.1.1.4 | Sodium return vs laser format | 22d? | 2006-11-01 | 2006-11-30 |  | 281d | 21d | finish no earlier than 2006-11-30 | 40h |
| 91 | 3.1.1.2 | **Model/Tool Validation** | 90d? | 2006-08-14 | 2006-12-15 |  | 270d | 10d |  | 180h |
| 92 | 3.1.1.2.1 | Agreement between Tomography Codes | 24d? | 2006-08-14 | 2006-09-14 |  | 336d |  | finish no earlier than 2006-09-14 | 40h |
| 93 | 3.1.1.2.2 | Agreement between Sky Coverage Codes | 23d? | 2006-09-18 | 2006-10-18 |  | 312d |  | finish no earlier than 2006-10-18 | 40h |
| 94 | 3.1.1.2.3 | Anchor to Keck II LGS AO PSFs | 21d? | 2006-10-02 | 2006-10-30 |  | 304d |  | finish no earlier than 2006-10-30 | 40h |
| 95 | 3.1.1.2.4 | Anchor to On-sky MGSU Experiments | 11d? | 2006-11-01 | 2006-11-15 |  | 270d | 0d | finish no earlier than 2006-11-15 | 30h |
| 96 | 3.1.1.2.5 | Anchor to LAO Lab Experiments | 22d? | 2006-11-16 | 2006-12-15 | 95 | 270d |  | finish no earlier than 2006-12-15 | 30h |
| 97 | 3.1.1.3 | Throughput | 65d? | 2006-10-02 | 2006-12-29 |  | 282d |  | finish no earlier than 2006-12-29 | 40h |
| 98 | 3.1.1.4 | **Background** | 109d? | 2006-08-01 | 2006-12-29 |  | 282d |  |  | 90h |
| 99 | 3.1.1.4.1 | Document Proposal Analysis | 9d? | 2006-08-01 | 2006-08-11 |  | 382d |  | finish no earlier than 2006-08-11 | 10h |
| 100 | 3.1.1.4.2 | Develop Background Performance Budget | 65d? | 2006-10-02 | 2006-12-29 |  | 282d |  | finish no earlier than 2006-12-29 | 80h |
| 101 | 3.1.1.5 | **Wavefront Error vs Sky Coverage** | 131d? | 2006-08-01 | 2007-01-30 |  | 260d |  |  | 110h |
| 102 | 3.1.1.5.1 | Document & release version 1 | 24d? | 2006-08-01 | 2006-09-01 |  | 367d |  | finish no earlier than 2006-09-01 | 40h |
| 103 | 3.1.1.5.2 | Develop version 2, document & release | 22d? | 2007-01-01 | 2007-01-30 | 86, 90, 91, 124 | 260d |  | finish no earlier than 2007-01-30 | 70h |
| 104 | 3.1.1.6 | **Encircled Energy vs Sky Coverage** | 50d? | 2006-10-23 | 2006-12-29 |  | 282d |  |  | 140h |
| 105 | 3.1.1.6.1 | Develop, document & release EE budget | 50d? | 2006-10-23 | 2006-12-29 |  | 282d |  | finish no earlier than 2006-12-29 | 140h |
| 106 | 3.1.1.7 | Photometric Accuracy | 75d? | 2006-10-16 | 2007-01-26 |  | 262d |  | start no earlier than 2006-10-16 | 240h |
| 107 | 3.1.1.8 | Astrometric Accuracy | 55d? | 2006-11-13 | 2007-01-26 |  | 262d |  | start no earlier than 2006-11-13 | 240h |
| 108 | 3.1.1.9 | Polarimetric Accuracy | 20d? | 2007-02-05 | 2007-03-02 |  | 237d |  | finish no earlier than 2007-03-02 | 40h |
| 109 | 3.1.1.10 | Companion Sensitivity | 55d? | 2006-11-13 | 2007-01-26 |  | 262d |  | start no earlier than 2006-11-13 | 640h |
| 110 | 3.1.1.11 | Point Source Sensitivities | 65d? | 2006-10-02 | 2006-12-29 |  | 282d |  | start no earlier than 2006-10-02 | 40h |
| 111 | 3.1.1.12 | PSF Stability | 1d? | 2006-11-06 | 2006-11-06 |  | 321d |  | start no earlier than 2006-11-06 | 40h |
| 112 | 3.1.1.13 | Observing Efficiency | 30d? | 2007-02-05 | 2007-03-16 |  | 227d |  | start no earlier than 2007-02-05 | 160h |
| 113 | 3.1.1.14 | Observing Uptime | 30d? | 2007-02-05 | 2007-03-16 |  | 227d |  | finish no earlier than 2007-03-16 | 80h |
| 114 | 3.1.1.15 | Performance Budgets Summary (Final SD version) | 25d? | 2007-05-14 | 2007-06-15 |  | 162d |  | finish no earlier than 2007-06-15 | 160h |

Notes:
- 84: CN
- 85: RF
- 88: CN
- 90: DG
- 91: CN
- 92: DG
- 93: RD
- 94: CN
- 95: RF
- 96: DG
- 98: AB
- 101: RD
- 104: DG
- 107: PW
- 109: BM
- 110: AB
- 111: CN

| ID | WBS | Task | Duration | Start | Finish | Predecessors | Total slack | Free slack | Constraint | Work |
| --- | --- | --- | --- | --- | --- | --- | --- | --- | --- | --- |
| 115 | 3.1.2 | **Trade Studies** | 151d? | 2006-10-02 | 2007-04-30 |  | 244d |  |  | 1790h |
| 116 | 3.1.2.1 | **System Architecture Trade Studies** | 58d? | 2006-10-02 | 2006-12-20 |  | 312d |  |  | 610h |
| 117 | 3.1.2.1.1 | NGAO versus Keck AO upgrades TS | 1d? | 2006-10-02 | 2006-10-02 |  | 394d |  | start no earlier than 2006-10-02 | 100h |
| 118 | 3.1.2.1.2 | Adaptive Secondary Mirror option TS | 1d? | 2006-10-02 | 2006-10-02 |  | 394d |  | start no earlier than 2006-10-02 | 40h |
| 119 | 3.1.2.1.3 | K & L-band Science TS | 1d? | 2006-10-02 | 2006-10-02 |  | 394d |  | start no earlier than 2006-10-02 | 40h |
| 120 | 3.1.2.1.4 | Keck Interferometer Support TS | 1d? | 2006-10-02 | 2006-10-02 |  | 394d |  | start no earlier than 2006-10-02 | 200h |
| 121 | 3.1.2.1.5 | Instrument Balance TS | 1d? | 2006-10-02 | 2006-10-02 |  | 394d |  | start no earlier than 2006-10-02 | 10h |
| 122 | 3.1.2.1.6 | GLAO for non-NGAO Instruments TS | 1d? | 2006-10-02 | 2006-10-02 |  | 394d |  | start no earlier than 2006-10-02 | 20h |
| 123 | 3.1.2.1.7 | Science Instrument Re-use Cost/Benefit TS | 1d? | 2006-10-02 | 2006-10-02 |  | 394d |  | start no earlier than 2006-10-02 | 120h |
| 124 | 3.1.2.1.8 | Telescope Wavefront Errors TS | 13d? | 2006-12-04 | 2006-12-20 | 88, 89 | 267d | 7d | finish no earlier than 2006-12-20 | 80h |
| 125 | 3.1.2.2 | **Adaptive Optics System Trade Studies** | 151d? | 2006-10-02 | 2007-04-30 |  | 244d |  |  | 950h |
| 126 | 3.1.2.2.1 | AO Enclosure Temperature TS | 85d? | 2007-01-02 | 2007-04-30 |  | 244d |  | finish no earlier than 2007-04-30 | 100h |
| 127 | 3.1.2.2.2 | Optical Relay TS | 1d? | 2006-10-02 | 2006-10-02 |  | 394d |  | start no earlier than 2006-10-02 | 60h |
| 128 | 3.1.2.2.3 | Field Rotation Strategy TS | 1d? | 2006-10-02 | 2006-10-02 |  | 394d |  | start no earlier than 2006-10-02 | 80h |
| 129 | 3.1.2.2.4 | Dichroics TS | 1d? | 2006-10-02 | 2006-10-02 |  | 394d |  | start no earlier than 2006-10-02 | 60h |
| 130 | 3.1.2.2.5 | Rayleigh Rejection TS | 15d? | 2006-10-02 | 2006-10-20 |  | 380d |  | finish no earlier than 2006-10-20 | 40h |
| 131 | 3.1.2.2.6 | LGS WFS Type TS | 1d? | 2006-10-02 | 2006-10-02 |  | 394d |  | start no earlier than 2006-10-02 | 30h |
| 132 | 3.1.2.2.7 | LGS WFS number of subapertures TS | 1d? | 2006-10-02 | 2006-10-02 |  | 394d |  | start no earlier than 2006-10-02 | 20h |
| 133 | 3.1.2.2.8 | Slow WFS TS | 1d? | 2006-10-02 | 2006-10-02 |  | 394d |  | start no earlier than 2006-10-02 | 80h |
| 134 | 3.1.2.2.9 | LOWFS Architecture TS | 1d? | 2006-10-02 | 2006-10-02 |  | 394d |  | start no earlier than 2006-10-02 | 200h |
| 135 | 3.1.2.2.10 | Number & Type of LOWFS TS | 1d? | 2006-10-02 | 2006-10-02 |  | 394d |  | start no earlier than 2006-10-02 | 60h |
| 136 | 3.1.2.2.11 | Centroid Anisoplanatism TS | 1d? | 2006-10-02 | 2006-10-02 |  | 394d |  | start no earlier than 2006-10-02 | 40h |
| 137 | 3.1.2.2.12 | Deformable Mirror Stroke Requirement TS | 1d? | 2006-10-02 | 2006-10-02 |  | 394d |  | start no earlier than 2006-10-02 | 50h |
| 138 | 3.1.2.2.13 | Stand-alone vs DM on T/T Stage TS | 1d? | 2006-10-02 | 2006-10-02 |  | 394d |  | start no earlier than 2006-10-02 | 60h |
| 139 | 3.1.2.2.14 | Correcting Fast T/T with DM TS | 1d? | 2006-10-02 | 2006-10-02 |  | 394d |  | start no earlier than 2006-10-02 | 40h |
| 140 | 3.1.2.2.15 | Focus Compensation TS | 1d? | 2006-10-02 | 2006-10-02 |  | 394d |  | start no earlier than 2006-10-02 | 30h |

Notes:
- 126: DM

| ID | WBS | Task | Duration | Start | Finish | Predecessors | Total slack | Free slack | Constraint | Work |
| --- | --- | --- | --- | --- | --- | --- | --- | --- | --- | --- |
| 141 | 3.1.2.3 | **Laser Facility Trade Studies** | 89d? | 2006-10-02 | 2007-02-01 |  | 306d |  |  | 230h |
| 142 | 3.1.2.3.1 | Laser Pulse Format TS | 1d? | 2006-10-02 | 2006-10-02 |  | 394d |  | start no earlier than 2006-10-02 | 100h |
| 143 | 3.1.2.3.2 | Free Space vs Fiber TS | 1d? | 2007-02-01 | 2007-02-01 |  | 306d |  | start no earlier than 2007-02-01 | 100h |
| 144 | 3.1.2.3.3 | LGS Asterism Geometry & Size TS | 5d? | 2006-10-30 | 2006-11-03 |  | 370d |  | finish no earlier than 2006-11-03 | 20h |
| 145 | 3.1.2.3.4 | Variable vs fixed LGS Asterism Cost/Benefit TS | 1d? | 2006-10-02 | 2006-10-02 |  | 394d |  | start no earlier than 2006-10-02 | 10h |
| 146 | 3.1.3 | System Architecture | 1d? | 2006-10-02 | 2006-10-02 |  | 322d | 65d | start no earlier than 2006-10-02 | 80h |
| 147 | 3.1.4 | **Functional Requirements** | 24d? | 2007-01-02 | 2007-02-02 | 146 | 257d | 105d |  | 1000h |
| 148 | 3.1.4.1 | AO System | 24d? | 2007-01-02 | 2007-02-02 |  | 257d |  | finish no earlier than 2007-02-02 | 300h |
| 149 | 3.1.4.2 | Laser System | 24d? | 2007-01-02 | 2007-02-02 |  | 257d |  | start no earlier than 2007-01-02 | 200h |
| 150 | 3.1.4.3 | Operations Tools | 24d? | 2007-01-02 | 2007-02-02 |  | 257d |  | start no earlier than 2007-01-02 | 200h |
| 151 | 3.1.4.4 | Science Instruments | 24d? | 2007-01-02 | 2007-02-02 |  | 257d |  | start no earlier than 2007-01-02 | 300h |
| 152 | 3.1.5 | Technology Drivers Summary | 21d? | 2007-06-01 | 2007-06-29 |  | 200d |  | finish no earlier than 2007-06-29 | 40h |
| 153 | 3.1.6 | Technical Risk Analysis | 21d? | 2007-06-01 | 2007-06-29 |  | 152d | 0d | finish no earlier than 2007-06-29 | 80h |
| 154 | 3.2 | **AO System** | 173d? | 2006-10-02 | 2007-05-30 |  | 174d | 22d |  | 2150h |
| 155 | 3.2.1 | **AO System Architecture** | 1d? | 2006-10-02 | 2006-10-02 |  | 346d |  |  | 900h |
| 156 | 3.2.1.1 | Other | 1d? | 2006-10-02 | 2006-10-02 |  | 394d |  | start no earlier than 2006-10-02 | 900h |
| 157 | 3.2.2 | **AO Enclosure** | 1d? | 2007-01-02 | 2007-01-02 |  | 280d |  |  | 100h |
| 158 | 3.2.2.1 | Other | 1d? | 2007-01-02 | 2007-01-02 |  | 328d |  | start no earlier than 2007-01-02 | 100h |
| 159 | 3.2.3 | **Opto-mechanical** | 1d? | 2006-10-02 | 2006-10-02 |  | 346d |  |  | 150h |
| 160 | 3.2.3.1 | Field Rotation | 1d? | 2006-10-02 | 2006-10-02 |  | 346d |  | start no earlier than 2006-10-02 |  |
| 161 | 3.2.3.2 | Optical Relay | 1d? | 2006-10-02 | 2006-10-02 |  | 346d |  | start no earlier than 2006-10-02 |  |
| 162 | 3.2.3.3 | Optical Switchyard | 1d? | 2006-10-02 | 2006-10-02 |  | 346d |  | start no earlier than 2006-10-02 |  |
| 163 | 3.2.3.4 | Optical Support Structure | 1d? | 2006-10-02 | 2006-10-02 |  | 346d |  | start no earlier than 2006-10-02 |  |
| 164 | 3.2.3.5 | **Wavefront Sensors** | 1d? | 2006-10-02 | 2006-10-02 |  | 346d |  |  |  |
| 165 | 3.2.3.5.1 | High Order LGS Wavefront Sensors | 1d? | 2006-10-02 | 2006-10-02 |  | 346d |  | start no earlier than 2006-10-02 |  |
| 166 | 3.2.3.5.2 | High Order NGS Wavefront Sensor | 1d? | 2006-10-02 | 2006-10-02 |  | 346d |  | start no earlier than 2006-10-02 |  |
| 167 | 3.2.3.5.3 | Low Order NGS Wavefront Sensors | 1d? | 2006-10-02 | 2006-10-02 |  | 346d |  | start no earlier than 2006-10-02 |  |
| 168 | 3.2.3.5.4 | Calibration Wavefront Sensor | 1d? | 2006-10-02 | 2006-10-02 |  | 346d |  | start no earlier than 2006-10-02 |  |

| ID | WBS | Task | Duration | Start | Finish | Total slack | Free slack | Constraint | Work |
| --- | --- | --- | --- | --- | --- | --- | --- | --- | --- |
| 169 | 3.2.3.6 | **Wavefront Correctors** | 1d? | 2006-10-02 | 2006-10-02 | 346d |  |  |  |
| 170 | 3.2.3.6.1 | Tip/Tilt Corrector | 1d? | 2006-10-02 | 2006-10-02 | 346d |  | start no earlier than 2006-10-02 |  |
| 171 | 3.2.3.6.2 | Deformable Mirror | 1d? | 2006-10-02 | 2006-10-02 | 346d |  | start no earlier than 2006-10-02 |  |
| 172 | 3.2.3.7 | **Acquisition Cameras** | 1d? | 2006-10-02 | 2006-10-02 | 346d |  |  |  |
| 173 | 3.2.3.7.1 | NGS Acquisition Camera | 1d? | 2006-10-02 | 2006-10-02 | 346d |  | start no earlier than 2006-10-02 |  |
| 174 | 3.2.3.7.2 | LGS Acquisition Camera | 1d? | 2006-10-02 | 2006-10-02 | 346d |  | start no earlier than 2006-10-02 |  |
| 175 | 3.2.3.8 | Atmospheric Dispersion Correction | 1d? | 2006-10-02 | 2006-10-02 | 346d |  | start no earlier than 2006-10-02 |  |
| 176 | 3.2.3.9 | Alignment, Calibration, Diagnostics, Metrology and Montoring | 1d? | 2006-10-02 | 2006-10-02 | 346d |  | start no earlier than 2006-10-02 |  |
| 177 | 3.2.3.10 | Other | 1d? | 2006-10-02 | 2006-10-02 | 394d |  | start no earlier than 2006-10-02 | 150h |
| 178 | 3.2.4 | **Non-real-time Control** | 85d? | 2007-02-01 | 2007-05-30 | 174d |  |  | 500h |
| 179 | 3.2.4.1 | Non-RTC Software Design | 63d? | 2007-02-01 | 2007-04-30 | 244d |  | finish no earlier than 2007-04-30 | 250h |
| 180 | 3.2.4.2 | Non-RTC Electrical Design | 85d? | 2007-02-01 | 2007-05-30 | 222d |  | finish no earlier than 2007-05-30 | 250h |
| 181 | 3.2.5 | **Real-time Control** | 151d? | 2006-11-01 | 2007-05-30 | 174d |  |  | 500h |
| 182 | 3.2.5.1 | RTC Architecture Analysis and Design Study | 86d? | 2006-11-01 | 2007-02-28 | 287d |  | finish no earlier than 2007-02-28 | 250h |
| 183 | 3.2.5.2 | RTC Software Module Definition | 85d? | 2007-02-01 | 2007-05-30 | 222d |  | finish no earlier than 2007-05-30 | 125h |
| 184 | 3.2.5.3 | RTC Hardware Module Definition | 85d? | 2007-02-01 | 2007-05-30 | 222d |  | finish no earlier than 2007-05-30 | 125h |
| 185 | 3.3 | **Laser Facility** | 173d? | 2006-10-02 | 2007-05-30 | 174d | 22d |  | 920h |
| 186 | 3.3.1 | Laser System Architecture | 151d? | 2006-10-02 | 2007-04-30 | 244d |  | start no earlier than 2006-10-02 | 100h |
| 187 | 3.3.2 | Laser Enclosure | 43d? | 2007-03-01 | 2007-04-30 | 244d |  | finish no earlier than 2007-04-30 | 100h |
| 188 | 3.3.3 | **Laser** | 1d? | 2006-10-02 | 2006-10-02 | 346d |  |  | 100h |
| 189 | 3.3.3.1 | Other | 1d? | 2006-10-02 | 2006-10-02 | 394d |  | start no earlier than 2006-10-02 | 100h |
| 190 | 3.3.4 | **Laser Launch Facility** | 87d? | 2007-01-30 | 2007-05-30 | 174d |  |  | 420h |
| 191 | 3.3.4.1 | **Laser Beam Transport** | 1d? | 2007-02-01 | 2007-02-01 | 258d |  |  | 60h |
| 192 | 3.3.4.1.1 | Other | 1d? | 2007-02-01 | 2007-02-01 | 306d |  | start no earlier than 2007-02-01 | 60h |
| 193 | 3.3.4.2 | Laser Pointing & Diagnostics | 43d? | 2007-04-02 | 2007-05-30 | 222d |  | finish no earlier than 2007-05-30 | 160h |
| 194 | 3.3.4.3 | Laser Launch Telescope | 65d? | 2007-01-30 | 2007-04-30 | 244d |  | finish no earlier than 2007-04-30 | 200h |

Notes:
- 181: DG

| ID | WBS | Task | Duration | Start | Finish | Predecessors | Total slack | Free slack | Constraint | Work |
| --- | --- | --- | --- | --- | --- | --- | --- | --- | --- | --- |
| 195 | 3.3.5 | **Laser Safety Systems** | 1d? | 2006-10-02 | 2006-10-02 |  | 346d |  |  | 40h |
| 196 | 3.3.5.1 | Personnel and Equipment Safety Systems | 1d? | 2006-10-02 | 2006-10-02 |  | 346d |  | start no earlier than 2006-10-02 | 20h |
| 197 | 3.3.5.2 | Aircraft and Satellite Safety Systems | 1d? | 2006-10-02 | 2006-10-02 |  | 346d |  | start no earlier than 2006-10-02 | 20h |
| 198 | 3.3.6 | Laser Traffic Control System | 1d? | 2006-10-02 | 2006-10-02 |  | 346d |  | start no earlier than 2006-10-02 | 10h |
| 199 | 3.3.7 | **Laser System Control** | 85d? | 2007-02-01 | 2007-05-30 |  | 174d |  |  | 150h |
| 200 | 3.3.7.1 | Laser System Software | 85d? | 2007-02-01 | 2007-05-30 |  | 174d |  | finish no earlier than 2007-05-30 | 80h |
| 201 | 3.3.7.2 | Laser System Electronics | 85d? | 2007-02-01 | 2007-05-30 |  | 174d |  | finish no earlier than 2007-05-30 | 70h |
| 202 | 3.4 | **Operations Tools** | 173d? | 2006-10-02 | 2007-05-30 |  | 174d | 22d |  | 900h |
| 203 | 3.4.1 | Operations Architecture | 151d? | 2006-10-02 | 2007-04-30 |  | 244d |  | start no earlier than 2006-10-02 | 200h |
| 204 | 3.4.2 | Observing Setup | 63d? | 2007-02-01 | 2007-04-30 |  | 244d |  | finish no earlier than 2007-04-30 | 100h |
| 205 | 3.4.3 | User Interface | 85d? | 2007-02-01 | 2007-05-30 |  | 222d |  | finish no earlier than 2007-05-30 | 100h |
| 206 | 3.4.4 | Astronomer Planning | 65d? | 2007-03-01 | 2007-05-30 |  | 222d |  | finish no earlier than 2007-05-30 | 100h |
| 207 | 3.4.5 | Science Instruments & Telescope Interface | 42d? | 2007-01-02 | 2007-02-28 |  | 287d |  | finish no earlier than 2007-02-28 | 100h |
| 208 | 3.4.6 | Performance Monitoring | 65d? | 2006-11-01 | 2007-01-30 |  | 308d |  | finish no earlier than 2007-01-30 | 100h |
| 209 | 3.4.7 | Automation & Optimization | 65d? | 2006-11-01 | 2007-01-30 |  | 308d |  | finish no earlier than 2007-01-30 | 200h |
| 210 | 3.5 | **Science Instruments** | 173d? | 2006-10-02 | 2007-05-30 |  | 174d | 22d |  | 1300h |
| 211 | 3.5.1 | OSIRIS | 43d? | 2006-12-01 | 2007-01-30 |  | 308d |  | finish no earlier than 2007-01-30 | 100h |
| 212 | 3.5.2 | **Interferometer** | 23d? | 2006-10-02 | 2006-11-01 |  | 324d |  |  | 200h |
| 213 | 3.5.2.1 | Define Requirements | 21d? | 2006-10-02 | 2006-10-30 |  | 374d |  | finish no earlier than 2006-10-30 | 20h |
| 214 | 3.5.2.2 | Other | 1d? | 2006-11-01 | 2006-11-01 |  | 372d |  | start no earlier than 2006-11-01 | 180h |
| 215 | 3.5.3 | OHANA | 20d? | 2007-02-01 | 2007-02-28 |  | 287d |  | finish no earlier than 2007-02-28 | 50h |
| 216 | 3.5.4 | Near-IR Imager | 87d? | 2006-10-02 | 2007-01-30 |  | 308d |  | finish no earlier than 2007-01-30 | 250h |
| 217 | 3.5.5 | Visible Imager | 87d? | 2006-10-02 | 2007-01-30 |  | 308d |  | finish no earlier than 2007-01-30 | 250h |
| 218 | 3.5.6 | Visible IFU | 64d? | 2007-01-02 | 2007-03-30 |  | 265d |  | finish no earlier than 2007-03-30 | 100h |
| 219 | 3.5.7 | Deployable Near-IR IFU | 63d? | 2007-02-01 | 2007-04-30 |  | 244d |  | finish no earlier than 2007-04-30 | 300h |
| 220 | 3.5.8 | Mid-IR IFU | 22d? | 2007-05-01 | 2007-05-30 |  | 222d |  | finish no earlier than 2007-05-30 | 50h |
| 221 | 3.6 | System Design Manual | 40d? | 2007-07-02 | 2007-08-24 | 147, 153, 210, 114, 202, 152, 185, 154 | 152d | 101d | finish no earlier than 2007-08-24 | 80h |

Notes:
- 210: SA
- 213: PW

| ID | WBS | Task | Duration | Start | Finish | Predecessors | Total slack | Free slack | Constraint | Work |
| --- | --- | --- | --- | --- | --- | --- | --- | --- | --- | --- |
| 222 | 4 | **Systems Engineering Management Plan (SEMP)** | 253d? | 2007-01-15 | 2008-01-02 |  | 59d |  |  | 980h |
| 223 | 4.1 | **Project Plan** | 72d? | 2007-08-30 | 2007-12-07 |  | 64d | 5d |  | 340h |
| 224 | 4.1.1 | Task Definition | 17d? | 2007-08-30 | 2007-09-21 |  | 119d |  | finish no earlier than 2007-09-21 | 80h |
| 225 | 4.1.2 | Cost Estimation | 27d? | 2007-09-27 | 2007-11-02 |  | 89d |  | finish no earlier than 2007-11-02 | 200h |
| 226 | 4.1.3 | Major Project Milestones | 5d? | 2007-11-07 | 2007-11-13 |  | 82d |  | finish no earlier than 2007-11-13 | 20h |
| 227 | 4.1.4 | MS Project Plan | 18d? | 2007-11-14 | 2007-12-07 |  | 64d |  | finish no earlier than 2007-12-07 | 40h |
| 228 | 4.2 | Risk Assessment & Management Plan | 23d? | 2007-11-14 | 2007-12-14 |  | 59d | 0d | finish no earlier than 2007-12-14 | 40h |
| 229 | 4.3 | **Preliminary Design Phase Plan** | 140d? | 2007-02-05 | 2007-08-17 |  | 144d | 85d |  | 160h |
| 230 | 4.3.1 | Rev 1 to Support Observatory FY08 Planning | 20d? | 2007-02-05 | 2007-03-02 |  | 264d |  | finish no earlier than 2007-03-02 | 40h |
| 231 | 4.3.2 | Intermediate versions | 30d? | 2007-04-09 | 2007-05-18 |  | 209d |  | finish no earlier than 2007-05-18 | 40h |
| 232 | 4.3.3 | Final version | 15d? | 2007-07-30 | 2007-08-17 |  | 144d |  | finish no earlier than 2007-08-17 | 80h |
| 233 | 4.4 | **Integration and Test Plans** | 187d? | 2007-03-12 | 2007-11-27 |  | 72d |  |  | 200h |
| 234 | 4.4.1 | **Subsystem Testing Plans** | 22d? | 2007-10-29 | 2007-11-27 |  | 72d | 13d |  | 100h |
| 235 | 4.4.1.1 | AO System | 22d? | 2007-10-29 | 2007-11-27 |  | 72d |  | start no earlier than 2007-10-29 | 25h |
| 236 | 4.4.1.2 | Laser System | 22d? | 2007-10-29 | 2007-11-27 |  | 72d |  | start no earlier than 2007-10-29 | 25h |
| 237 | 4.4.1.3 | Operations Tools | 22d? | 2007-10-29 | 2007-11-27 |  | 72d |  | start no earlier than 2007-10-29 | 25h |
| 238 | 4.4.1.4 | Science Instruments | 22d? | 2007-10-29 | 2007-11-27 |  | 72d |  | start no earlier than 2007-10-29 | 25h |
| 239 | 4.4.2 | System Integration & Test Plans | 30d? | 2007-03-12 | 2007-04-20 |  | 229d | 170d | finish no earlier than 2007-04-20 | 100h |
| 240 | 4.5 | Configuration Management Plan | 20d? | 2007-01-15 | 2007-02-09 |  | 279d | 220d | finish no earlier than 2007-02-09 | 80h |
| 241 | 4.6 | Project Management Plan | 20d? | 2007-02-12 | 2007-03-09 |  | 259d | 200d | finish no earlier than 2007-03-09 | 80h |
| 242 | 4.7 | SEMP Document | 13d? | 2007-12-17 | 2008-01-02 | 223, 229, 234, 239, 240, 241, 228 | 59d | 8d | finish no earlier than 2007-09-05 | 80h |

Notes:
- 222: PW
- 223: PW
- 229: PW
- 241: PW
- 242: PW
