# NGAO SD schedule v7

Schedule from MS Project, 2006-06-21 to 2008-04-04.
CARA

## Calendars

- Standard: Mon-Fri 08:00-12:00, 13:00-17:00; Sat-Sun off.

## Resources

| Resource |
| --- |
| 16 |
| Flicker |
| Gavel |
| Neyman |

## Schedule

| ID | WBS | Task | Type | Duration | Start | Finish | Predecessors | Total slack | Free slack | Constraint | Work |
| --- | --- | --- | --- | --- | --- | --- | --- | --- | --- | --- | --- |
| 1 | 1 | **SD Phase Management** |  | 468d? | 2006-06-21 | 2008-04-04 |  | 0d |  |  | 1745h |
| 2 | 1.1 | **Planning and Contracting** |  | 323d? | 2006-06-21 | 2007-09-14 |  | 145d |  |  | 220h |
| 3 | 1.1.1 | NGAO Proposal to SSC | milestone | 0d | 2006-06-21 | 2006-06-21 |  | 424d | 17d | start no earlier than 2006-06-21 |  |
| 4 | 1.1.2 | Management Structure Decision by Directors | milestone | 0d | 2006-07-14 | 2006-07-14 | 3 | 407d | 6d | start no earlier than 2006-07-14 |  |
| 5 | 1.1.3 | SD Phase System Engineering Management Plan |  | 44d? | 2006-07-24 | 2006-09-21 | 4 | 401d | 0d | finish no earlier than 2006-09-21 | 80h |
| 6 | 1.1.4 | SD Phase Contracts Generated |  | 19d? | 2006-09-05 | 2006-09-29 |  | 395d | 0d | finish no earlier than 2006-09-29 | 60h |
| 7 | 1.1.5 | Director Approval | milestone | 0d | 2006-09-29 | 2006-09-29 |  | 396d | 1d | start no earlier than 2006-09-29 |  |
| 8 | 1.1.6 | SD Partner Contracts Issued | milestone | 0d | 2006-10-02 | 2006-10-02 | 6, 7 | 395d |  | start no earlier than 2006-10-02 |  |
| 9 | 1.1.7 | Mid-year Replan |  | 10d? | 2007-03-05 | 2007-03-16 |  | 275d |  | finish no earlier than 2007-03-16 | 40h |
| 10 | 1.1.8 | FY08 Replan |  | 9d? | 2007-09-04 | 2007-09-14 |  | 145d |  | start no earlier than 2007-09-04 | 40h |
| 11 | 1.2 | **Project Meetings** |  | 443d? | 2006-07-26 | 2008-04-04 |  | 0d |  |  | 780h |
| 12 | 1.2.1 | Executive Committee Telecons |  | 438d? | 2006-07-26 | 2008-03-28 |  | 5d |  | finish no earlier than 2008-03-28 | 300h |
| 13 | 1.2.2 | Science Advisory Committee Telecons |  | 434d? | 2006-08-01 | 2008-03-28 |  | 5d |  | finish no earlier than 2008-03-28 | 40h |
| 14 | 1.2.3 | **Team Meetings** |  | 407d? | 2006-09-14 | 2008-04-04 |  | 0d |  |  | 440h |
| 15 | 1.2.3.1 | Team Meeting (mgmt, science & technical - Irvine) |  | 1d | 2006-09-14 | 2006-09-14 |  | 406d |  | start no earlier than 2006-09-14 | 40h |
| 16 | 1.2.3.2 | Team Meeting (CIT) |  | 1d | 2006-11-03 | 2006-11-03 |  | 370d |  | start no earlier than 2006-11-03 | 40h |
| 17 | 1.2.3.3 | Team Videocon |  | 1d? | 2006-12-13 | 2006-12-13 |  | 342d |  | start no earlier than 2006-12-13 | 10h |
| 18 | 1.2.3.4 | Team Meeting (Keck) |  | 1d | 2007-01-22 | 2007-01-22 |  | 314d |  | start no earlier than 2007-01-22 | 40h |
| 19 | 1.2.3.5 | Team Videocon |  | 1d? | 2007-03-07 | 2007-03-07 |  | 282d |  | start no earlier than 2007-03-07 | 10h |
| 20 | 1.2.3.6 | Team Meeting |  | 1d | 2007-04-18 | 2007-04-18 |  | 252d |  | start no earlier than 2007-04-18 | 10h |
| 21 | 1.2.3.7 | Team Videocon |  | 1d? | 2007-05-30 | 2007-05-30 |  | 222d |  | finish no earlier than 2007-05-30 | 10h |
| 22 | 1.2.3.8 | Team Retreat (UCSC) |  | 5d | 2007-07-09 | 2007-07-13 |  | 190d |  | start no earlier than 2007-07-09 | 140h |
| 23 | 1.2.3.9 | Team Videocon |  | 1d? | 2007-08-22 | 2007-08-22 |  | 162d |  | start no earlier than 2007-08-22 | 10h |
| 24 | 1.2.3.10 | Team Meeting (CIT) |  | 1d | 2007-09-13 | 2007-09-13 |  | 146d |  | start no earlier than 2007-09-13 | 40h |
| 25 | 1.2.3.11 | Team Videocon |  | 1d | 2007-11-05 | 2007-11-05 |  | 109d |  | start no earlier than 2007-11-05 | 10h |
| 26 | 1.2.3.12 | Team Meeting (Keck) |  | 3d? | 2007-12-12 | 2007-12-14 |  | 80d |  | finish no earlier than 2007-12-14 | 60h |
| 27 | 1.2.3.13 | Team Videocon |  | 1d? | 2008-01-09 | 2008-01-09 |  | 62d |  | start no earlier than 2008-01-09 | 10h |
| 28 | 1.2.3.14 | Team Meeting (CA) |  | 1d? | 2008-04-04 | 2008-04-04 | 39 | 0d |  | start no earlier than 2008-04-04 | 10h |

Notes:
- 1: PW
- 2: PW
- 5: PW
- 6: SA
- 8: SA
- 9: PW
- 10: PW
- 12: PW
- 13: CM

| ID | WBS | Task | Type | Duration | Start | Finish | Predecessors | Total slack | Free slack | Constraint | Work |
| --- | --- | --- | --- | --- | --- | --- | --- | --- | --- | --- | --- |
| 29 | 1.3 | **Tracking and Reporting** |  | 400d? | 2006-09-21 | 2008-04-03 |  | 1d |  |  | 120h |
| 30 | 1.3.1 | Report Preparation/Presentation |  | 390d? | 2006-10-02 | 2008-03-28 |  | 5d |  | start no earlier than 2006-10-02 | 120h |
| 31 | 1.3.2 | Keck Science Meeting 06 (UCI) | milestone | 0d | 2006-09-21 | 2006-09-21 | 5 | 401d |  | finish no earlier than 2006-09-16 |  |
| 32 | 1.3.3 | SSC meeting (UCLA) | milestone | 0d | 2006-11-06 | 2006-11-06 |  | 370d |  | start no earlier than 2006-11-06 |  |
| 33 | 1.3.4 | SSC meeting (Keck) | milestone | 0d | 2007-01-24 | 2007-01-24 |  | 313d |  | start no earlier than 2007-01-24 |  |
| 34 | 1.3.5 | SSC meeting (CA) | milestone | 0d | 2007-04-03 | 2007-04-03 |  | 264d |  | start no earlier than 2007-04-03 |  |
| 35 | 1.3.6 | SSC meeting (Keck) | milestone | 0d | 2007-06-20 | 2007-06-20 |  | 208d |  | start no earlier than 2007-06-20 |  |
| 36 | 1.3.7 | Keck Science Meeting 07 | milestone | 0d | 2007-09-22 | 2007-09-22 |  | 140d |  | finish no earlier than 2007-09-22 |  |
| 37 | 1.3.8 | SSC meeting (CA) | milestone | 0d | 2007-11-06 | 2007-11-06 |  | 109d |  | start no earlier than 2007-11-06 |  |
| 38 | 1.3.9 | SSC meeting (Keck) | milestone | 0d | 2008-01-24 | 2008-01-24 |  | 52d |  | start no earlier than 2008-01-24 |  |
| 39 | 1.3.10 | SSC meeting (CA) | milestone | 0d | 2008-04-03 | 2008-04-03 |  | 0d |  | finish no earlier than 2008-04-03 |  |
| 40 | 1.4 | **Proposal & Fundraising Activities** |  | 326d? | 2006-10-02 | 2007-12-31 |  | 69d |  |  | 160h |
| 41 | 1.4.1 | Dates & deliverables identified by Directors | milestone | 0d | 2006-10-02 | 2006-10-02 |  | 134d | 65d | start no earlier than 2006-10-02 |  |
| 42 | 1.4.2 | Activities |  | 261d? | 2007-01-01 | 2007-12-31 | 41 | 69d |  | finish no earlier than 2007-12-31 | 160h |
| 43 | 1.5 | **System Design Report & Review** |  | 70d? | 2007-11-15 | 2008-02-20 |  | 32d |  |  | 465h |
| 44 | 1.5.1 | System Design Report |  | 8d? | 2008-01-02 | 2008-01-11 |  | 60d |  | finish no earlier than 2008-01-11 | 40h |
| 45 | 1.5.2 | **System Design Review Activities** |  | 70d? | 2007-11-15 | 2008-02-20 |  | 32d |  |  | 425h |
| 46 | 1.5.2.1 | Reviewers Identified |  | 22d? | 2007-11-15 | 2007-12-14 |  | 72d | 21d | finish no earlier than 2007-12-14 | 15h |
| 47 | 1.5.2.2 | Review Package Distributed | milestone | 0d | 2008-01-15 | 2008-01-15 | 46, 289, 268, 132 | 51d | 9d | start no earlier than 2008-01-14 |  |
| 48 | 1.5.2.3 | Reviewer Comments Received & Addressed |  | 5d? | 2008-01-28 | 2008-02-01 | 47 | 42d | 3d | finish no earlier than 2008-02-01 | 120h |
| 49 | 1.5.2.4 | System Design Review Prep & Attendance |  | 16d? | 2008-01-16 | 2008-02-06 |  | 39d | 0d | finish no earlier than 2008-02-06 | 250h |
| 50 | 1.5.2.5 | System Design Review Meeting | milestone | 0d | 2008-02-06 | 2008-02-06 | 49, 48 | 39d | 6d | start no earlier than 2008-02-06 |  |
| 51 | 1.5.2.6 | Reviewer Report Received | milestone | 0d | 2008-02-15 | 2008-02-15 | 50 | 33d | 1d | start no earlier than 2008-02-15 |  |
| 52 | 1.5.2.7 | Response to Reviewer Report & Distribution |  | 3d? | 2008-02-18 | 2008-02-20 | 51 | 32d |  | finish no earlier than 2008-02-20 | 40h |

Notes:
- 29: PW
- 30: PW
- 43: SA
- 44: PW

| ID | WBS | Task | Duration | Start | Finish | Total slack | Constraint | Work |
| --- | --- | --- | --- | --- | --- | --- | --- | --- |
| 53 | 2 | **System Requirements** | 355d? | 2006-09-05 | 2008-01-15 | 59d |  | 3300h |
| 54 | 2.1 | **Science Requirements** | 344d? | 2006-09-05 | 2007-12-28 | 70d |  | 3090h |
| 55 | 2.1.1 | **Solar System** | 135d? | 2006-10-02 | 2007-04-06 | 260d |  | 650h |
| 56 | 2.1.1.1 | **Companions & Multiplicity of Small Solar System Bodies** | 75d? | 2006-10-02 | 2007-01-12 | 320d |  | 250h |
| 57 | 2.1.1.1.1 | Point Source Companion Sensitivity Requirements | 45d? | 2006-10-02 | 2006-12-01 | 350d | finish no earlier than 2006-12-01 | 100h |
| 58 | 2.1.1.1.2 | Spectral Sensitivity & Spectral Resolution Requirements | 45d? | 2006-10-02 | 2006-12-01 | 350d | finish no earlier than 2006-12-01 | 100h |
| 59 | 2.1.1.1.3 | Observing Scenarios | 30d? | 2006-12-04 | 2007-01-12 | 320d | finish no earlier than 2007-01-12 | 25h |
| 60 | 2.1.1.1.4 | Science Instrument Requirements | 30d? | 2006-12-04 | 2007-01-12 | 320d | start no earlier than 2006-12-04 | 25h |
| 61 | 2.1.1.2 | **Moons of the Giant Planets** | 70d? | 2006-12-04 | 2007-03-09 | 280d |  | 150h |
| 62 | 2.1.1.2.1 | Performance Requirements | 40d? | 2006-12-04 | 2007-01-26 | 310d | start no earlier than 2006-12-04 | 100h |
| 63 | 2.1.1.2.2 | Observing Scenarios | 30d? | 2007-01-29 | 2007-03-09 | 280d | finish no earlier than 2007-03-09 | 25h |
| 64 | 2.1.1.2.3 | Science Instrument Requirements | 30d? | 2007-01-29 | 2007-03-09 | 280d | start no earlier than 2007-01-29 | 25h |
| 65 | 2.1.1.3 | **Shape & Size of Asteroids** | 50d? | 2007-01-29 | 2007-04-06 | 260d |  | 250h |
| 66 | 2.1.1.3.1 | Spatial Resolution Requirements | 25d? | 2007-01-29 | 2007-03-02 | 285d | start no earlier than 2007-01-29 | 100h |
| 67 | 2.1.1.3.2 | Spectral Sensitivity & Spectral Resolution Requirements | 25d? | 2007-01-29 | 2007-03-02 | 285d | start no earlier than 2007-01-29 | 100h |
| 68 | 2.1.1.3.3 | Observing Scenarios | 25d? | 2007-03-05 | 2007-04-06 | 260d | finish no earlier than 2007-04-06 | 25h |
| 69 | 2.1.1.3.4 | Science Instrument Requirements | 25d? | 2007-03-05 | 2007-04-06 | 260d | start no earlier than 2007-03-05 | 25h |
| 70 | 2.1.2 | **Galactic** | 145d? | 2006-09-18 | 2007-04-06 | 260d |  | 1200h |
| 71 | 2.1.2.1 | **Galactic Center Proper Motions: Astrometry** | 85d? | 2006-09-18 | 2007-01-12 | 320d |  | 200h |
| 72 | 2.1.2.1.1 | Astrometry requirements | 50d? | 2006-09-18 | 2006-11-24 | 355d | finish no earlier than 2006-11-24 | 150h |
| 73 | 2.1.2.1.2 | Observing Scenarios | 35d? | 2006-11-27 | 2007-01-12 | 320d | finish no earlier than 2007-01-12 | 25h |
| 74 | 2.1.2.1.3 | Science Instrument Requirements | 35d? | 2006-11-27 | 2007-01-12 | 320d | start no earlier than 2006-11-27 | 25h |
| 75 | 2.1.2.2 | **Galactic Center Radial Velocities & Stellar Populations: Integral Field Spectroscopy** | 75d? | 2006-11-27 | 2007-03-09 | 280d |  | 200h |
| 76 | 2.1.2.2.1 | Performance Requirements | 45d? | 2006-11-27 | 2007-01-26 | 310d | finish no earlier than 2007-01-26 | 150h |
| 77 | 2.1.2.2.2 | Observing Scenarios | 30d? | 2007-01-29 | 2007-03-09 | 280d | start no earlier than 2007-01-29 | 25h |
| 78 | 2.1.2.2.3 | Science Instrument Requirements | 30d? | 2007-01-29 | 2007-03-09 | 280d | start no earlier than 2007-01-29 | 25h |

Notes:
- 54: CM
- 55: FM
- 70: ML

| ID | WBS | Task | Duration | Start | Finish | Total slack | Constraint | Work |
| --- | --- | --- | --- | --- | --- | --- | --- | --- |
| 79 | 2.1.2.3 | **Galactic Center Nature of Sgr A*: Flares, Spectra & Time Behavior** | 50d? | 2007-01-29 | 2007-04-06 | 260d |  | 200h |
| 80 | 2.1.2.3.1 | Performance Requirements | 25d? | 2007-01-29 | 2007-03-02 | 285d | finish no earlier than 2007-03-02 | 150h |
| 81 | 2.1.2.3.2 | Observing Scenarios | 25d? | 2007-03-05 | 2007-04-06 | 260d | start no earlier than 2007-03-05 | 25h |
| 82 | 2.1.2.3.3 | Science Instrument Requirements | 25d? | 2007-03-05 | 2007-04-06 | 260d | finish no earlier than 2007-04-06 | 25h |
| 83 | 2.1.2.4 | **Low-mass Companions: Planets & Binary Brown Dwarfs** | 85d? | 2006-09-18 | 2007-01-12 | 320d |  | 200h |
| 84 | 2.1.2.4.1 | Companion Sensitivity Performance Requirements | 50d? | 2006-09-18 | 2006-11-24 | 355d | finish no earlier than 2006-11-24 | 150h |
| 85 | 2.1.2.4.2 | Observing Scenarios | 35d? | 2006-11-27 | 2007-01-12 | 320d | start no earlier than 2006-11-27 | 25h |
| 86 | 2.1.2.4.3 | Science Instrument Requirements | 35d? | 2006-11-27 | 2007-01-12 | 320d | start no earlier than 2006-11-27 | 25h |
| 87 | 2.1.2.5 | **Debris Disks, Protostellar Envelopes & Outflows: Contrast** | 50d? | 2007-01-29 | 2007-04-06 | 260d |  | 200h |
| 88 | 2.1.2.5.1 | Contrast Performance Requirements | 25d? | 2007-01-29 | 2007-03-02 | 285d | finish no earlier than 2007-03-02 | 150h |
| 89 | 2.1.2.5.2 | Observing Scenarios | 25d? | 2007-03-05 | 2007-04-06 | 260d | start no earlier than 2007-03-05 | 25h |
| 90 | 2.1.2.5.3 | Science Instrument Requirements | 25d? | 2007-03-05 | 2007-04-06 | 260d | start no earlier than 2007-03-05 | 25h |
| 91 | 2.1.2.6 | **Debris Disks, Protostellar Envelopes & Outflows: Polarimetry** | 75d? | 2006-11-27 | 2007-03-09 | 280d |  | 200h |
| 92 | 2.1.2.6.1 | Polarimetry Performance Requirements | 45d? | 2006-11-27 | 2007-01-26 | 310d | finish no earlier than 2007-01-26 | 150h |
| 93 | 2.1.2.6.2 | Observing Scenarios | 30d? | 2007-01-29 | 2007-03-09 | 280d | start no earlier than 2007-01-29 | 25h |
| 94 | 2.1.2.6.3 | Science Instrument Requirements | 30d? | 2007-01-29 | 2007-03-09 | 280d | start no earlier than 2007-01-29 | 25h |
| 95 | 2.1.3 | **Extragalactic** | 160d? | 2006-09-18 | 2007-04-27 | 245d |  | 1000h |
| 96 | 2.1.3.1 | **Resolved Stellar Populations** | 100d? | 2006-09-18 | 2007-02-02 | 305d |  | 300h |
| 97 | 2.1.3.1.1 | Performance Requirements | 60d? | 2006-09-18 | 2006-12-08 | 345d | finish no earlier than 2006-12-08 | 250h |
| 98 | 2.1.3.1.2 | Observing Scenarios | 40d? | 2006-12-11 | 2007-02-02 | 305d | finish no earlier than 2007-02-02 | 25h |
| 99 | 2.1.3.1.3 | Science Instrument Requirements | 40d? | 2006-12-11 | 2007-02-02 | 305d | start no earlier than 2006-12-11 | 25h |
| 100 | 2.1.3.2 | **High Redshift Galaxies** | 100d? | 2006-09-18 | 2007-02-02 | 305d |  | 300h |
| 101 | 2.1.3.2.1 | Encircled Energy Performance Requirements | 60d? | 2006-09-18 | 2006-12-08 | 345d | finish no earlier than 2006-12-08 | 200h |
| 102 | 2.1.3.2.2 | Observing Scenarios | 40d? | 2006-12-11 | 2007-02-02 | 305d | start no earlier than 2006-12-11 | 50h |
| 103 | 2.1.3.2.3 | Science Instrument Requirements | 40d? | 2006-12-11 | 2007-02-02 | 305d | start no earlier than 2006-12-11 | 50h |

Notes:
- 95: CM

| ID | WBS | Task | Duration | Start | Finish | Total slack | Free slack | Constraint | Work |
| --- | --- | --- | --- | --- | --- | --- | --- | --- | --- |
| 104 | 2.1.3.3 | **Nearby Galaxies** | 100d? | 2006-12-11 | 2007-04-27 | 245d |  |  | 200h |
| 105 | 2.1.3.3.1 | Encircled Energy & PSF Performance Requirements | 60d? | 2006-12-11 | 2007-03-02 | 285d |  | finish no earlier than 2007-03-02 | 150h |
| 106 | 2.1.3.3.2 | Observing Scenarios | 40d? | 2007-03-05 | 2007-04-27 | 245d |  | finish no earlier than 2007-04-27 | 25h |
| 107 | 2.1.3.3.3 | Science Instrument Requirements | 40d? | 2007-03-05 | 2007-04-27 | 245d |  | start no earlier than 2007-03-05 | 25h |
| 108 | 2.1.3.4 | **Gravitational Lensing** | 100d? | 2006-12-11 | 2007-04-27 | 245d |  |  | 200h |
| 109 | 2.1.3.4.1 | Encircled Energy & PSF Performance Requirements | 60d? | 2006-12-11 | 2007-03-02 | 285d |  | start no earlier than 2006-12-11 | 150h |
| 110 | 2.1.3.4.2 | Observing Scenarios | 40d? | 2007-03-05 | 2007-04-27 | 245d |  | start no earlier than 2007-03-05 | 25h |
| 111 | 2.1.3.4.3 | Science Instrument Requirements | 40d? | 2007-03-05 | 2007-04-27 | 245d |  | start no earlier than 2007-03-05 | 25h |
| 112 | 2.1.4 | **Science Requirements Summary** | 344d? | 2006-09-05 | 2007-12-28 | 70d |  |  | 240h |
| 113 | 2.1.4.1 | Revision 1 | 29d? | 2006-09-05 | 2006-10-13 | 385d | 10d | finish no earlier than 2006-10-13 | 40h |
| 114 | 2.1.4.2 | Revision 2 | 21d? | 2007-02-02 | 2007-03-02 | 285d | 4d | finish no earlier than 2007-03-02 | 120h |
| 115 | 2.1.4.3 | Revision 3 | 15d? | 2007-06-04 | 2007-06-22 | 205d | 4d | finish no earlier than 2007-06-22 | 40h |
| 116 | 2.1.4.4 | Final SD Version | 20d? | 2007-12-03 | 2007-12-28 | 62d | 11d | finish no earlier than 2007-12-28 | 40h |
| 117 | 2.2 | **Observatory Requirements** | 325d? | 2006-10-02 | 2007-12-28 | 70d |  |  | 80h |
| 118 | 2.2.1 | Revision 1 | 20d? | 2006-10-02 | 2006-10-27 | 375d | 0d | finish no earlier than 2006-10-27 | 40h |
| 119 | 2.2.2 | Revision 2 | 10d? | 2007-02-19 | 2007-03-02 | 285d | 4d | start no earlier than 2007-02-19 | 20h |
| 120 | 2.2.3 | Revision 3 | 15d? | 2007-06-04 | 2007-06-22 | 205d | 4d | finish no earlier than 2007-06-22 | 10h |
| 121 | 2.2.4 | Revision 4 | 20d? | 2007-12-03 | 2007-12-28 | 62d | 11d | finish no earlier than 2007-12-28 | 10h |
| 122 | 2.3 | **System Requirements Document** | 331d? | 2006-10-09 | 2008-01-15 | 59d |  |  | 130h |
| 123 | 2.3.1 | **Technical Requirements Flow Down** | 331d? | 2006-10-09 | 2008-01-14 | 59d |  |  | 130h |
| 124 | 2.3.1.1 | Revision 1 | 10d? | 2006-10-09 | 2006-10-20 | 380d | 5d | finish no earlier than 2006-10-20 | 10h |
| 125 | 2.3.1.2 | Revision 2 | 89d? | 2006-11-01 | 2007-03-05 | 284d | 3d | finish no earlier than 2007-03-05 | 80h |
| 126 | 2.3.1.3 | Revision 3 | 10d? | 2007-06-15 | 2007-06-28 | 201d | 0d | finish no earlier than 2007-06-28 | 20h |
| 127 | 2.3.1.4 | Revision 4 | 9d? | 2008-01-02 | 2008-01-14 | 51d | 0d | finish no earlier than 2008-01-14 | 20h |

Notes:
- 117: CN
- 123: CN

| ID | WBS | Task | Type | Duration | Start | Finish | Predecessors | Total slack | Free slack | Constraint | Work |
| --- | --- | --- | --- | --- | --- | --- | --- | --- | --- | --- | --- |
| 128 | 2.3.2 | **System Requirements Document** |  | 316d | 2006-10-27 | 2008-01-15 |  | 59d |  |  |  |
| 129 | 2.3.2.1 | Revision 1 Release | milestone | 0d | 2006-10-27 | 2006-10-27 | 113, 124, 118 | 375d |  | start no earlier than 2006-10-27 |  |
| 130 | 2.3.2.2 | Revision 2 Release | milestone | 0d | 2007-03-09 | 2007-03-09 | 114, 125, 119 | 281d |  | start no earlier than 2007-03-09 |  |
| 131 | 2.3.2.3 | Revision 3 Release | milestone | 0d | 2007-06-29 | 2007-06-29 | 115, 126, 120 | 201d |  | start no earlier than 2007-06-29 |  |
| 132 | 2.3.2.4 | Final SD Version Release | milestone | 0d | 2008-01-15 | 2008-01-15 | 116, 127, 121 | 51d | 0d | start no earlier than 2008-01-15 |  |
| 133 | 3 | **System Design** |  | 279d? | 2006-08-01 | 2007-08-24 |  | 160d |  |  | 10800h |
| 134 | 3.1 | **System Engineering** |  | 239d? | 2006-08-01 | 2007-06-29 |  | 200d |  |  | 5450h |
| 135 | 3.1.1 | **Performance Budgets** |  | 239d? | 2006-08-01 | 2007-06-29 |  | 200d |  |  | 2460h |
| 136 | 3.1.1.1 | **Model Assumptions** |  | 230d? | 2006-08-14 | 2007-06-29 |  | 200d |  |  | 260h |
| 137 | 3.1.1.1.1 | **TMT site monitoring data mining** |  | 230d? | 2006-08-14 | 2007-06-29 |  | 200d |  |  | 80h |
| 138 | 3.1.1.1.1.1 | Tools in place & 1st release |  | 24d? | 2006-08-14 | 2006-09-14 |  | 201d | 1d | finish no earlier than 2006-09-14 | 40h |
| 139 | 3.1.1.1.1.2 | Release updated data (every two months) |  | 205d? | 2006-09-18 | 2007-06-29 | 138 | 200d |  | finish no earlier than 2007-06-29 | 40h |
| 140 | 3.1.1.1.2 | Telescope dynamic performance data |  | 44d? | 2006-10-02 | 2006-11-30 |  | 316d | 1d | finish no earlier than 2006-11-30 | 120h |
| 141 | 3.1.1.1.3 | Telescope static wavefront errors |  | 44d? | 2006-10-02 | 2006-11-30 |  | 316d | 1d | finish no earlier than 2006-11-30 | 20h |
| 142 | 3.1.1.1.4 | Sodium return vs laser format |  | 22d? | 2006-11-01 | 2006-11-30 |  | 329d | 21d | finish no earlier than 2006-11-30 | 40h |
| 143 | 3.1.1.2 | **Model/Tool Validation** |  | 90d? | 2006-08-14 | 2006-12-15 |  | 318d | 10d |  | 180h |
| 144 | 3.1.1.2.1 | Agreement between Tomography Codes |  | 24d? | 2006-08-14 | 2006-09-14 |  | 384d |  | finish no earlier than 2006-09-14 | 40h |
| 145 | 3.1.1.2.2 | Agreement between Sky Coverage Codes |  | 23d? | 2006-09-18 | 2006-10-18 |  | 360d |  | finish no earlier than 2006-10-18 | 40h |
| 146 | 3.1.1.2.3 | Anchor to Keck II LGS AO PSFs |  | 21d? | 2006-10-02 | 2006-10-30 |  | 352d |  | finish no earlier than 2006-10-30 | 40h |
| 147 | 3.1.1.2.4 | Anchor to On-sky MGSU Experiments |  | 11d? | 2006-11-01 | 2006-11-15 |  | 318d | 0d | finish no earlier than 2006-11-15 | 30h |
| 148 | 3.1.1.2.5 | Anchor to LAO Lab Experiments |  | 22d? | 2006-11-16 | 2006-12-15 | 147 | 318d |  | finish no earlier than 2006-12-15 | 30h |
| 149 | 3.1.1.3 | Throughput |  | 65d? | 2006-10-02 | 2006-12-29 |  | 330d |  | finish no earlier than 2006-12-29 | 40h |
| 150 | 3.1.1.4 | **Background** |  | 109d? | 2006-08-01 | 2006-12-29 |  | 330d |  |  | 90h |
| 151 | 3.1.1.4.1 | Document Proposal Analysis |  | 9d? | 2006-08-01 | 2006-08-11 |  | 430d |  | finish no earlier than 2006-08-11 | 10h |
| 152 | 3.1.1.4.2 | Develop Background Performance Budget |  | 65d? | 2006-10-02 | 2006-12-29 |  | 330d |  | finish no earlier than 2006-12-29 | 80h |

Notes:
- 136: CN
- 137: RF
- 140: CN
- 142: DG
- 143: CN
- 144: DG
- 145: RD
- 146: CN
- 147: RF
- 148: DG
- 150: AB

| ID | WBS | Task | Duration | Start | Finish | Predecessors | Total slack | Free slack | Constraint | Work |
| --- | --- | --- | --- | --- | --- | --- | --- | --- | --- | --- |
| 153 | 3.1.1.5 | **Wavefront Error vs Sky Coverage** | 131d? | 2006-08-01 | 2007-01-30 |  | 308d |  |  | 110h |
| 154 | 3.1.1.5.1 | Document & release version 1 | 24d? | 2006-08-01 | 2006-09-01 |  | 415d |  | finish no earlier than 2006-09-01 | 40h |
| 155 | 3.1.1.5.2 | Develop version 2, document & release | 22d? | 2007-01-01 | 2007-01-30 | 138, 142, 143, 176 | 308d |  | finish no earlier than 2007-01-30 | 70h |
| 156 | 3.1.1.6 | **Encircled Energy vs Sky Coverage** | 50d? | 2006-10-23 | 2006-12-29 |  | 330d |  |  | 140h |
| 157 | 3.1.1.6.1 | Develop, document & release EE budget | 50d? | 2006-10-23 | 2006-12-29 |  | 330d |  | finish no earlier than 2006-12-29 | 140h |
| 158 | 3.1.1.7 | Photometric Accuracy | 75d? | 2006-10-16 | 2007-01-26 |  | 310d |  | start no earlier than 2006-10-16 | 240h |
| 159 | 3.1.1.8 | Astrometric Accuracy | 55d? | 2006-11-13 | 2007-01-26 |  | 310d |  | start no earlier than 2006-11-13 | 240h |
| 160 | 3.1.1.9 | Polarimetric Accuracy | 20d? | 2007-02-05 | 2007-03-02 |  | 285d |  | finish no earlier than 2007-03-02 | 40h |
| 161 | 3.1.1.10 | Companion Sensitivity | 55d? | 2006-11-13 | 2007-01-26 |  | 310d |  | start no earlier than 2006-11-13 | 640h |
| 162 | 3.1.1.11 | Point Source Sensitivities | 15d? | 2007-01-08 | 2007-01-26 |  | 310d |  | start no earlier than 2007-01-08 | 40h |
| 163 | 3.1.1.12 | PSF Stability | 15d? | 2007-01-08 | 2007-01-26 |  | 310d |  | finish no earlier than 2007-01-26 | 40h |
| 164 | 3.1.1.13 | Observing Efficiency | 30d? | 2007-02-05 | 2007-03-16 |  | 275d |  | start no earlier than 2007-02-05 | 160h |
| 165 | 3.1.1.14 | Observing Uptime | 30d? | 2007-02-05 | 2007-03-16 |  | 275d |  | finish no earlier than 2007-03-16 | 80h |
| 166 | 3.1.1.15 | Performance Budgets Summary (Final SD version) | 25d? | 2007-05-14 | 2007-06-15 |  | 162d | 10d | finish no earlier than 2007-06-15 | 160h |
| 167 | 3.1.2 | **Trade Studies** | 160d? | 2006-10-16 | 2007-05-25 |  | 225d |  |  | 1790h |
| 168 | 3.1.2.1 | **System Architecture Trade Studies** | 100d? | 2006-10-16 | 2007-03-02 |  | 285d |  |  | 610h |
| 169 | 3.1.2.1.1 | NGAO versus Keck AO upgrades TS (meeting 5) | 20d? | 2007-02-05 | 2007-03-02 |  | 285d |  | start no earlier than 2007-02-05 | 100h |
| 170 | 3.1.2.1.2 | Adaptive Secondary Mirror option TS (m5) | 20d? | 2007-02-05 | 2007-03-02 |  | 285d |  | start no earlier than 2007-02-05 | 40h |
| 171 | 3.1.2.1.3 | K & L-band Science TS (m5) | 20d? | 2007-02-05 | 2007-03-02 |  | 285d |  | start no earlier than 2007-02-05 | 40h |
| 172 | 3.1.2.1.4 | Keck Interferometer Support TS (m5) | 100d? | 2006-10-16 | 2007-03-02 |  | 285d |  | start no earlier than 2006-10-16 | 200h |
| 173 | 3.1.2.1.5 | Instrument Balance TS | 20d? | 2006-11-13 | 2006-12-08 |  | 345d |  | start no earlier than 2006-11-13 | 10h |
| 174 | 3.1.2.1.6 | GLAO for non-NGAO Instruments TS (m5) | 20d? | 2007-02-05 | 2007-03-02 |  | 285d |  | start no earlier than 2007-02-05 | 20h |
| 175 | 3.1.2.1.7 | Science Instrument Re-use Cost/Benefit TS (m3) | 20d? | 2006-11-13 | 2006-12-08 |  | 345d |  | finish no earlier than 2006-12-08 | 120h |
| 176 | 3.1.2.1.8 | Telescope Wavefront Errors TS | 13d? | 2006-12-04 | 2006-12-20 | 140, 141 | 315d | 7d | finish no earlier than 2006-12-20 | 80h |

Notes:
- 153: RD
- 156: DG
- 159: PW
- 161: BM
- 162: AB
- 163: CN

| ID | WBS | Task | Duration | Start | Finish | Predecessors | Total slack | Free slack | Constraint | Work |
| --- | --- | --- | --- | --- | --- | --- | --- | --- | --- | --- |
| 177 | 3.1.2.2 | **Adaptive Optics System Trade Studies** | 150d? | 2006-10-30 | 2007-05-25 |  | 225d |  |  | 950h |
| 178 | 3.1.2.2.1 | AO Enclosure Temperature TS (m6) | 74d? | 2007-01-02 | 2007-04-13 |  | 255d |  | finish no earlier than 2007-04-13 | 100h |
| 179 | 3.1.2.2.2 | Optical Relay TS (m6) | 74d? | 2007-01-02 | 2007-04-13 |  | 255d |  | start no earlier than 2007-01-02 | 60h |
| 180 | 3.1.2.2.3 | Field Rotation Strategy TS (m6) | 74d? | 2007-01-02 | 2007-04-13 |  | 255d |  | start no earlier than 2007-01-02 | 80h |
| 181 | 3.1.2.2.4 | Dichroics & Beamsplitters TS (m6) | 74d? | 2007-01-02 | 2007-04-13 |  | 255d |  | start no earlier than 2007-01-02 | 60h |
| 182 | 3.1.2.2.5 | Rayleigh Rejection TS (m3) | 30d? | 2006-10-30 | 2006-12-08 |  | 345d |  | start no earlier than 2006-10-30 | 40h |
| 183 | 3.1.2.2.6 | LGS WFS Type TS (m4) | 35d? | 2006-12-04 | 2007-01-19 |  | 315d |  | start no earlier than 2006-12-04 | 30h |
| 184 | 3.1.2.2.7 | LGS WFS number of subapertures TS (m4) | 35d? | 2006-12-04 | 2007-01-19 |  | 315d |  | start no earlier than 2006-12-04 | 20h |
| 185 | 3.1.2.2.8 | Slow WFS TS (m7) | 25d? | 2007-04-23 | 2007-05-25 |  | 225d |  | start no earlier than 2007-04-23 | 80h |
| 186 | 3.1.2.2.9 | LOWFS Architecture TS | 35d? | 2006-12-04 | 2007-01-19 |  | 315d |  | start no earlier than 2006-12-04 | 200h |
| 187 | 3.1.2.2.10 | Number & Type of LOWFS TS (m4) | 35d? | 2006-12-04 | 2007-01-19 |  | 315d |  | start no earlier than 2006-12-04 | 60h |
| 188 | 3.1.2.2.11 | Centroid Anisoplanatism TS (m7) | 25d? | 2007-04-23 | 2007-05-25 |  | 225d |  | start no earlier than 2007-04-23 | 40h |
| 189 | 3.1.2.2.12 | Deformable Mirror Stroke Requirement TS (m6) | 74d? | 2007-01-02 | 2007-04-13 |  | 255d |  | start no earlier than 2007-01-02 | 50h |
| 190 | 3.1.2.2.13 | Stand-alone vs DM on T/T Stage TS (m3) | 30d? | 2006-10-30 | 2006-12-08 |  | 345d |  | start no earlier than 2006-10-30 | 60h |
| 191 | 3.1.2.2.14 | Correcting Fast T/T with DM TS | 30d? | 2006-10-30 | 2006-12-08 |  | 345d |  | start no earlier than 2006-10-30 | 40h |
| 192 | 3.1.2.2.15 | Focus Compensation TS (m6) | 74d? | 2007-01-02 | 2007-04-13 |  | 255d |  | start no earlier than 2007-01-02 | 30h |
| 193 | 3.1.2.3 | **Laser Facility Trade Studies** | 155d? | 2006-10-23 | 2007-05-25 |  | 225d |  |  | 230h |
| 194 | 3.1.2.3.1 | Laser Pulse Format TS (m6) | 74d? | 2007-01-02 | 2007-04-13 |  | 255d |  | start no earlier than 2007-01-02 | 100h |
| 195 | 3.1.2.3.2 | Free Space vs Fiber TS (m7) | 25d? | 2007-04-23 | 2007-05-25 |  | 225d |  | start no earlier than 2007-04-23 | 100h |
| 196 | 3.1.2.3.3 | LGS Asterism Geometry & Size TS (m2) | 5d? | 2006-10-23 | 2006-10-27 |  | 375d |  | finish no earlier than 2006-10-27 | 20h |
| 197 | 3.1.2.3.4 | Variable vs fixed LGS Asterism Cost/Benefit TS (m2) | 5d? | 2006-10-23 | 2006-10-27 |  | 375d |  | finish no earlier than 2006-10-27 | 10h |
| 198 | 3.1.3 | System Architecture | 40d? | 2006-10-30 | 2006-12-22 |  | 263d | 6d | finish no earlier than 2006-12-22 | 80h |
| 199 | 3.1.4 | **Functional Requirements** | 24d? | 2007-01-02 | 2007-02-02 | 198 | 257d | 105d |  | 1000h |
| 200 | 3.1.4.1 | AO System | 24d? | 2007-01-02 | 2007-02-02 |  | 257d |  | finish no earlier than 2007-02-02 | 300h |
| 201 | 3.1.4.2 | Laser System | 24d? | 2007-01-02 | 2007-02-02 |  | 257d |  | start no earlier than 2007-01-02 | 200h |
| 202 | 3.1.4.3 | Operations Tools | 24d? | 2007-01-02 | 2007-02-02 |  | 257d |  | start no earlier than 2007-01-02 | 200h |
| 203 | 3.1.4.4 | Science Instruments | 24d? | 2007-01-02 | 2007-02-02 |  | 257d |  | start no earlier than 2007-01-02 | 300h |
| 204 | 3.1.5 | Technology Drivers Summary | 21d? | 2007-06-01 | 2007-06-29 |  | 152d | 0d | finish no earlier than 2007-06-29 | 40h |
| 205 | 3.1.6 | Technical Risk Analysis | 21d? | 2007-06-01 | 2007-06-29 |  | 152d | 0d | finish no earlier than 2007-06-29 | 80h |

Notes:
- 178: DM

| ID | WBS | Task | Duration | Start | Finish | Total slack | Free slack | Constraint | Work |
| --- | --- | --- | --- | --- | --- | --- | --- | --- | --- |
| 206 | 3.2 | **AO System** | 173d? | 2006-11-01 | 2007-06-29 | 152d | 0d |  | 2150h |
| 207 | 3.2.1 | AO System Architecture | 84d? | 2007-01-02 | 2007-04-27 | 197d |  | finish no earlier than 2007-04-27 | 650h |
| 208 | 3.2.2 | AO Enclosure | 70d? | 2007-01-22 | 2007-04-27 | 197d |  | start no earlier than 2007-01-22 | 100h |
| 209 | 3.2.3 | **Opto-mechanical** | 95d? | 2007-02-19 | 2007-06-29 | 152d |  |  | 400h |
| 210 | 3.2.3.1 | Field Rotation | 85d? | 2007-03-05 | 2007-06-29 | 152d |  | finish no earlier than 2007-06-29 | 30h |
| 211 | 3.2.3.2 | Optical Relay | 85d? | 2007-03-05 | 2007-06-29 | 152d |  | start no earlier than 2007-03-05 | 40h |
| 212 | 3.2.3.3 | Optical Switchyard | 85d? | 2007-03-05 | 2007-06-29 | 152d |  | start no earlier than 2007-03-05 | 50h |
| 213 | 3.2.3.4 | Optical Support Structure | 85d? | 2007-03-05 | 2007-06-29 | 152d |  | start no earlier than 2007-03-05 | 20h |
| 214 | 3.2.3.5 | **Wavefront Sensors** | 85d? | 2007-02-19 | 2007-06-15 | 162d |  |  | 120h |
| 215 | 3.2.3.5.1 | High Order LGS Wavefront Sensors | 85d? | 2007-02-19 | 2007-06-15 | 162d |  | finish no earlier than 2007-06-15 | 40h |
| 216 | 3.2.3.5.2 | High Order NGS Wavefront Sensor | 85d? | 2007-02-19 | 2007-06-15 | 162d |  | start no earlier than 2007-02-19 | 20h |
| 217 | 3.2.3.5.3 | Low Order NGS Wavefront Sensors | 85d? | 2007-02-19 | 2007-06-15 | 162d |  | start no earlier than 2007-02-19 | 40h |
| 218 | 3.2.3.5.4 | Calibration Wavefront Sensor | 85d? | 2007-02-19 | 2007-06-15 | 162d |  | start no earlier than 2007-02-19 | 20h |
| 219 | 3.2.3.6 | **Wavefront Correctors** | 85d? | 2007-03-05 | 2007-06-29 | 152d |  |  | 40h |
| 220 | 3.2.3.6.1 | Tip/Tilt Corrector | 85d? | 2007-03-05 | 2007-06-29 | 152d |  | start no earlier than 2007-03-05 | 20h |
| 221 | 3.2.3.6.2 | Deformable Mirror | 85d? | 2007-03-05 | 2007-06-29 | 152d |  | start no earlier than 2007-03-05 | 20h |
| 222 | 3.2.3.7 | **Acquisition Cameras** | 85d? | 2007-03-05 | 2007-06-29 | 152d |  |  | 20h |
| 223 | 3.2.3.7.1 | NGS Acquisition Camera | 85d? | 2007-03-05 | 2007-06-29 | 152d |  | start no earlier than 2007-03-05 | 10h |
| 224 | 3.2.3.7.2 | LGS Acquisition Camera | 85d? | 2007-03-05 | 2007-06-29 | 152d |  | start no earlier than 2007-03-05 | 10h |
| 225 | 3.2.3.8 | Atmospheric Dispersion Correction | 85d? | 2007-03-05 | 2007-06-29 | 152d |  | start no earlier than 2007-03-05 | 20h |
| 226 | 3.2.3.9 | Alignment, Calibration, Diagnostics, Metrology and Montoring | 85d? | 2007-03-05 | 2007-06-29 | 152d |  | start no earlier than 2007-03-05 | 60h |
| 227 | 3.2.4 | **Non-real-time Control** | 85d? | 2007-02-01 | 2007-05-30 | 174d |  |  | 500h |
| 228 | 3.2.4.1 | Non-RTC Software Design | 63d? | 2007-02-01 | 2007-04-30 | 196d |  | finish no earlier than 2007-04-30 | 250h |
| 229 | 3.2.4.2 | Non-RTC Electrical Design | 85d? | 2007-02-01 | 2007-05-30 | 174d |  | finish no earlier than 2007-05-30 | 250h |

| ID | WBS | Task | Duration | Start | Finish | Total slack | Free slack | Constraint | Work |
| --- | --- | --- | --- | --- | --- | --- | --- | --- | --- |
| 230 | 3.2.5 | **Real-time Control** | 151d? | 2006-11-01 | 2007-05-30 | 174d |  |  | 500h |
| 231 | 3.2.5.1 | RTC Architecture Analysis and Design Study | 86d? | 2006-11-01 | 2007-02-28 | 239d |  | finish no earlier than 2007-02-28 | 250h |
| 232 | 3.2.5.2 | RTC Software Module Definition | 85d? | 2007-02-01 | 2007-05-30 | 174d |  | finish no earlier than 2007-05-30 | 125h |
| 233 | 3.2.5.3 | RTC Hardware Module Definition | 85d? | 2007-02-01 | 2007-05-30 | 174d |  | finish no earlier than 2007-05-30 | 125h |
| 234 | 3.3 | **Laser Facility** | 129d? | 2007-01-02 | 2007-06-29 | 152d | 0d |  | 920h |
| 235 | 3.3.1 | Laser System Architecture | 85d? | 2007-01-02 | 2007-04-30 | 196d |  | start no earlier than 2007-01-02 | 100h |
| 236 | 3.3.2 | Laser Enclosure | 43d? | 2007-03-01 | 2007-04-30 | 196d |  | finish no earlier than 2007-04-30 | 100h |
| 237 | 3.3.3 | Laser | 35d? | 2007-01-15 | 2007-03-02 | 237d |  | start no earlier than 2007-01-15 | 100h |
| 238 | 3.3.4 | **Laser Launch Facility** | 87d? | 2007-01-30 | 2007-05-30 | 174d |  |  | 420h |
| 239 | 3.3.4.1 | Laser Beam Transport | 60d? | 2007-02-05 | 2007-04-27 | 197d |  | finish no earlier than 2007-04-27 | 60h |
| 240 | 3.3.4.2 | Laser Pointing & Diagnostics | 43d? | 2007-04-02 | 2007-05-30 | 174d |  | finish no earlier than 2007-05-30 | 160h |
| 241 | 3.3.4.3 | Laser Launch Telescope | 65d? | 2007-01-30 | 2007-04-30 | 196d |  | finish no earlier than 2007-04-30 | 200h |
| 242 | 3.3.5 | **Laser Safety Systems** | 20d? | 2007-06-04 | 2007-06-29 | 152d |  |  | 40h |
| 243 | 3.3.5.1 | Personnel and Equipment Safety Systems | 20d? | 2007-06-04 | 2007-06-29 | 152d |  | start no earlier than 2007-06-04 | 20h |
| 244 | 3.3.5.2 | Aircraft and Satellite Safety Systems | 20d? | 2007-06-04 | 2007-06-29 | 152d |  | start no earlier than 2007-06-04 | 20h |
| 245 | 3.3.6 | Laser Traffic Control System | 20d? | 2007-06-04 | 2007-06-29 | 152d |  | start no earlier than 2007-06-04 | 10h |
| 246 | 3.3.7 | **Laser System Control** | 85d? | 2007-02-01 | 2007-05-30 | 174d |  |  | 150h |
| 247 | 3.3.7.1 | Laser System Software | 85d? | 2007-02-01 | 2007-05-30 | 174d |  | finish no earlier than 2007-05-30 | 80h |
| 248 | 3.3.7.2 | Laser System Electronics | 85d? | 2007-02-01 | 2007-05-30 | 174d |  | finish no earlier than 2007-05-30 | 70h |
| 249 | 3.4 | **Operations Tools** | 173d? | 2006-10-02 | 2007-05-30 | 174d | 22d |  | 900h |
| 250 | 3.4.1 | Operations Architecture | 151d? | 2006-10-02 | 2007-04-30 | 196d |  | start no earlier than 2006-10-02 | 200h |
| 251 | 3.4.2 | Observing Setup | 63d? | 2007-02-01 | 2007-04-30 | 196d |  | finish no earlier than 2007-04-30 | 100h |
| 252 | 3.4.3 | User Interface | 85d? | 2007-02-01 | 2007-05-30 | 174d |  | finish no earlier than 2007-05-30 | 100h |
| 253 | 3.4.4 | Astronomer Planning | 65d? | 2007-03-01 | 2007-05-30 | 174d |  | finish no earlier than 2007-05-30 | 100h |
| 254 | 3.4.5 | Science Instruments & Telescope Interface | 42d? | 2007-01-02 | 2007-02-28 | 239d |  | finish no earlier than 2007-02-28 | 100h |
| 255 | 3.4.6 | Performance Monitoring | 65d? | 2006-11-01 | 2007-01-30 | 260d |  | finish no earlier than 2007-01-30 | 100h |
| 256 | 3.4.7 | Automation & Optimization | 65d? | 2006-11-01 | 2007-01-30 | 260d |  | finish no earlier than 2007-01-30 | 200h |

Notes:
- 230: DG

| ID | WBS | Task | Duration | Start | Finish | Predecessors | Total slack | Free slack | Constraint | Work |
| --- | --- | --- | --- | --- | --- | --- | --- | --- | --- | --- |
| 257 | 3.5 | **Science Instruments** | 173d? | 2006-10-02 | 2007-05-30 |  | 174d | 22d |  | 1300h |
| 258 | 3.5.1 | OSIRIS | 43d? | 2006-12-01 | 2007-01-30 |  | 260d |  | finish no earlier than 2007-01-30 | 100h |
| 259 | 3.5.2 | **Interferometer** | 130d? | 2006-10-02 | 2007-03-30 |  | 217d |  |  | 200h |
| 260 | 3.5.2.1 | Define Requirements | 21d? | 2006-10-02 | 2006-10-30 |  | 326d |  | finish no earlier than 2006-10-30 | 20h |
| 261 | 3.5.2.2 | Other | 64d? | 2007-01-02 | 2007-03-30 |  | 217d |  | start no earlier than 2007-01-02 | 180h |
| 262 | 3.5.3 | OHANA | 20d? | 2007-02-01 | 2007-02-28 |  | 239d |  | finish no earlier than 2007-02-28 | 50h |
| 263 | 3.5.4 | Near-IR Imager | 87d? | 2006-10-02 | 2007-01-30 |  | 260d |  | finish no earlier than 2007-01-30 | 250h |
| 264 | 3.5.5 | Visible Imager | 87d? | 2006-10-02 | 2007-01-30 |  | 260d |  | finish no earlier than 2007-01-30 | 250h |
| 265 | 3.5.6 | Visible IFU | 64d? | 2007-01-02 | 2007-03-30 |  | 217d |  | finish no earlier than 2007-03-30 | 100h |
| 266 | 3.5.7 | Deployable Near-IR IFU | 63d? | 2007-02-01 | 2007-04-30 |  | 196d |  | finish no earlier than 2007-04-30 | 300h |
| 267 | 3.5.8 | Mid-IR IFU | 22d? | 2007-05-01 | 2007-05-30 |  | 174d |  | finish no earlier than 2007-05-30 | 50h |
| 268 | 3.6 | System Design Manual | 40d? | 2007-07-02 | 2007-08-24 | 199, 205, 257, 166, 249, 204, 234, 206 | 152d | 101d | finish no earlier than 2007-08-24 | 80h |
| 269 | 4 | **Systems Engineering Management Plan (SEMP)** | 253d? | 2007-01-15 | 2008-01-02 |  | 59d |  |  | 980h |
| 270 | 4.1 | **Project Plan** | 72d? | 2007-08-30 | 2007-12-07 |  | 64d | 5d |  | 340h |
| 271 | 4.1.1 | Task Definition | 17d? | 2007-08-30 | 2007-09-21 |  | 119d |  | finish no earlier than 2007-09-21 | 80h |
| 272 | 4.1.2 | Cost Estimation | 27d? | 2007-09-27 | 2007-11-02 |  | 89d |  | finish no earlier than 2007-11-02 | 200h |
| 273 | 4.1.3 | Major Project Milestones | 5d? | 2007-11-07 | 2007-11-13 |  | 82d |  | finish no earlier than 2007-11-13 | 20h |
| 274 | 4.1.4 | MS Project Plan | 18d? | 2007-11-14 | 2007-12-07 |  | 64d |  | finish no earlier than 2007-12-07 | 40h |
| 275 | 4.2 | Risk Assessment & Management Plan | 23d? | 2007-11-14 | 2007-12-14 |  | 59d | 0d | finish no earlier than 2007-12-14 | 40h |
| 276 | 4.3 | **Preliminary Design Phase Plan** | 140d? | 2007-02-05 | 2007-08-17 |  | 144d | 85d |  | 160h |
| 277 | 4.3.1 | Rev 1 to Support Observatory FY08 Planning | 20d? | 2007-02-05 | 2007-03-02 |  | 264d |  | finish no earlier than 2007-03-02 | 40h |
| 278 | 4.3.2 | Intermediate versions | 30d? | 2007-04-09 | 2007-05-18 |  | 209d |  | finish no earlier than 2007-05-18 | 40h |
| 279 | 4.3.3 | Final version | 15d? | 2007-07-30 | 2007-08-17 |  | 144d |  | finish no earlier than 2007-08-17 | 80h |
| 280 | 4.4 | **Integration and Test Plans** | 187d? | 2007-03-12 | 2007-11-27 |  | 72d |  |  | 200h |
| 281 | 4.4.1 | **Subsystem Testing Plans** | 22d? | 2007-10-29 | 2007-11-27 |  | 72d | 13d |  | 100h |
| 282 | 4.4.1.1 | AO System | 22d? | 2007-10-29 | 2007-11-27 |  | 72d |  | start no earlier than 2007-10-29 | 25h |
| 283 | 4.4.1.2 | Laser System | 22d? | 2007-10-29 | 2007-11-27 |  | 72d |  | start no earlier than 2007-10-29 | 25h |
| 284 | 4.4.1.3 | Operations Tools | 22d? | 2007-10-29 | 2007-11-27 |  | 72d |  | start no earlier than 2007-10-29 | 25h |
| 285 | 4.4.1.4 | Science Instruments | 22d? | 2007-10-29 | 2007-11-27 |  | 72d |  | start no earlier than 2007-10-29 | 25h |
| 286 | 4.4.2 | System Integration & Test Plans | 30d? | 2007-03-12 | 2007-04-20 |  | 229d | 170d | finish no earlier than 2007-04-20 | 100h |
| 287 | 4.5 | Configuration Management Plan | 20d? | 2007-01-15 | 2007-02-09 |  | 279d | 220d | finish no earlier than 2007-02-09 | 80h |
| 288 | 4.6 | Project Management Plan | 20d? | 2007-02-12 | 2007-03-09 |  | 259d | 200d | finish no earlier than 2007-03-09 | 80h |
| 289 | 4.7 | SEMP Document | 13d? | 2007-12-17 | 2008-01-02 | 270, 276, 281, 286, 287, 288, 275 | 59d | 8d | finish no earlier than 2007-09-05 | 80h |

Notes:
- 257: SA
- 260: PW
- 269: PW
- 270: PW
- 276: PW
- 288: PW
- 289: PW
